# Finish New Office Workspace.mpp

How a schedule from MS Project changed from version to version. A marks actual dates.

## Version 1 (saved 2017-04-22, file JT New Workspace 10.mpp)

| ID | WBS | Task | Duration | Start | Finish | Predecessors | Complete | Total float | Constraint |
| --- | --- | --- | --- | --- | --- | --- | --- | --- | --- |
| 1 | 1 | **JT Move Status Meetings** | 10.12d | 2018-07-05 | 2018-07-19 |  |  | 4.88d |  |
| 2 |  | JT Move Status Meetings 1 | 1h | 2018-07-05 | 2018-07-05 |  |  | 14.88d | start no earlier than 2018-07-05 |
| 3 |  | JT Move Status Meetings 2 | 1h | 2018-07-12 | 2018-07-12 |  |  | 9.88d | start no earlier than 2018-07-12 |
| 4 |  | JT Move Status Meetings 3 | 1h | 2018-07-19 | 2018-07-19 |  |  | 4.88d | start no earlier than 2018-07-19 |
| 5 | 2 | **Office Number 101** | 17d | 2018-07-02 A | 2018-07-25 |  | 13% | 0d |  |
| 6 |  | Paint the walls | 2d | 2018-07-02 A | 2018-07-03 A |  | 100% |  |  |
| 7 |  | Install Partitions | 1d | 2018-07-04 A | 2018-07-04 | 6 | 25% | 0d |  |
| 8 |  | Install Network Cables | 3d | 2018-07-05 | 2018-07-09 | 7 |  | 0d |  |
| 9 |  | Lay Carpet | 2d | 2018-07-10 | 2018-07-11 | 8 |  | 0d |  |
| 10 |  | Prepare Offices | 5d | 2018-07-12 | 2018-07-18 | 9 |  | 0d |  |
| 11 |  | Assemble Furniture | 2d | 2018-07-19 | 2018-07-20 | 10 |  | 0d |  |
| 12 |  | Hook up Computers | 1d | 2018-07-23 | 2018-07-23 | 11 |  | 0d |  |
| 13 |  | Move in Belongings | 2d | 2018-07-24 | 2018-07-25 | 12 |  | 0d |  |
| 14 |  | Office 101 Complete | 0d | 2018-07-25 | 2018-07-25 | 13 |  | 0d |  |
| 15 | 3 | **Office Number 102** | 5d | 2018-07-01 | 2018-07-09 |  |  | 12d |  |
| 16 |  | Paint the walls | 2d | 2018-07-02 | 2018-07-03 |  |  | 15d |  |
| 17 |  | Install Partitions | 1d | 2018-07-02 | 2018-07-02 |  |  | 16d |  |
| 18 |  | Install Network Cables | 3d | 2018-07-02 | 2018-07-05 |  |  | 14d |  |
| 19 |  | Lay Carpet | 2d | 2018-07-02 | 2018-07-03 |  |  | 15d |  |
| 20 |  | Prepare Offices | 5d | 2018-07-02 | 2018-07-09 |  |  | 12d |  |
| 21 |  | Assemble Furniture | 2d | 2018-07-02 | 2018-07-03 |  |  | 15d |  |
| 22 |  | Hook up Computers | 1d | 2018-07-02 | 2018-07-02 |  |  | 16d |  |
| 23 |  | Move in Belongings | 2d | 2018-07-02 | 2018-07-03 |  |  | 15d |  |
| 24 |  | Office 102 Complete | 0d | 2018-07-01 | 2018-07-01 |  |  | 17d |  |

## Version 2 (saved 2019-05-22, file JT New Workspace.mpp)

Last finish 2018-07-25 → 2019-07-29 (+369d). Complete tasks 1 → 0.

Added:

| ID | Task | Duration | Start | Finish | Predecessors |
| --- | --- | --- | --- | --- | --- |
| 21 | **Office Number 103** | 18d | 2019-07-03 | 2019-07-29 |  |
| 22 | Paint the walls | 2d | 2019-07-03 | 2019-07-05 | 12 |
| 23 | Install Partitions | 1d | 2019-07-08 | 2019-07-08 | 22 |
| 24 | Install Network Cables | 3d | 2019-07-09 | 2019-07-11 | 23 |
| 25 | Lay Carpet | 2d | 2019-07-12 | 2019-07-15 | 24 |
| 26 | Prepare Offices | 5d | 2019-07-16 | 2019-07-22 | 25 |
| 27 | Assemble Furniture | 2d | 2019-07-23 | 2019-07-24 | 26 |
| 28 | Hook up Computers | 1d | 2019-07-25 | 2019-07-25 | 27 |
| 29 | Move in Belongings | 2d | 2019-07-26 | 2019-07-29 | 28 |
| 30 | Office 103 Complete | 0d | 2019-07-29 | 2019-07-29 | 29 |
| 31 | Finsih New Office Worspace Complete | 0d | 2019-07-29 | 2019-07-29 | 30, 10, 20 |

Removed: 1 JT Move Status Meetings; 2 JT Move Status Meetings 1; 3 JT Move Status Meetings 2; 4 JT Move Status Meetings 3

Changed:

| ID | Task | Start | Finish | Duration | Complete | Total float | Predecessors | Other |
| --- | --- | --- | --- | --- | --- | --- | --- | --- |
| 1 | **Office Number 101** | 2018-07-02 A → 2019-07-01 (+364d) | 2018-07-25 → 2019-07-24 (+364d) |  | 13% → 0% |  |  | baseline start 2018-07-02 → none; baseline finish 2018-07-25 → none |
| 2 | Paint the walls | 2018-07-02 A → 2019-07-01 (+364d) | 2018-07-03 A → 2019-07-02 (+364d) |  | 100% → 0% | none → 0d |  | baseline start 2018-07-02 → none; baseline finish 2018-07-03 → none |
| 3 | Install Partitions | 2018-07-04 A → 2019-07-03 (+364d) | 2018-07-04 → 2019-07-03 (+364d) |  | 25% → 0% | 0d → 2d |  | baseline start 2018-07-04 → none; baseline finish 2018-07-04 → none |
| 4 | Install Network Cables | 2018-07-05 → 2019-07-04 (+364d) | 2018-07-09 → 2019-07-08 (+364d) |  |  | 0d → 2d |  | baseline start 2018-07-05 → none; baseline finish 2018-07-09 → none |
| 5 | Lay Carpet | 2018-07-10 → 2019-07-09 (+364d) | 2018-07-11 → 2019-07-10 (+364d) |  |  | 0d → 3d |  | baseline start 2018-07-10 → none; baseline finish 2018-07-11 → none |
| 6 | Prepare Offices | 2018-07-12 → 2019-07-11 (+364d) | 2018-07-18 → 2019-07-17 (+364d) |  |  | 0d → 3d |  | baseline start 2018-07-12 → none; baseline finish 2018-07-18 → none |
| 7 | Assemble Furniture | 2018-07-19 → 2019-07-18 (+364d) | 2018-07-20 → 2019-07-19 (+364d) |  |  | 0d → 3d |  | baseline start 2018-07-19 → none; baseline finish 2018-07-20 → none |
| 8 | Hook up Computers | 2018-07-23 → 2019-07-22 (+364d) | 2018-07-23 → 2019-07-22 (+364d) |  |  | 0d → 3d |  | baseline start 2018-07-23 → none; baseline finish 2018-07-23 → none |
| 9 | Move in Belongings | 2018-07-24 → 2019-07-23 (+364d) | 2018-07-25 → 2019-07-24 (+364d) |  |  | 0d → 3d |  | baseline start 2018-07-24 → none; baseline finish 2018-07-25 → none |
| 10 | Office 101 Complete | 2018-07-25 → 2019-07-24 (+364d) | 2018-07-25 → 2019-07-24 (+364d) |  |  | 0d → 3d |  | baseline start 2018-07-25 → none; baseline finish 2018-07-25 → none |
| 11 | **Office Number 102** | 2018-07-01 → 2019-07-02 (+366d) | 2018-07-09 → 2019-07-29 (+385d) | 5d → 18d |  | 12d → 0d |  |  |
| 12 | Paint the walls | 2018-07-02 → 2019-07-02 (+365d) | 2018-07-03 → 2019-07-02 (+364d) | 2d → 0d |  | 15d → 0d | none → 2 |  |
| 13 | Install Partitions | 2018-07-02 → 2019-07-03 (+366d) | 2018-07-02 → 2019-07-03 (+366d) |  |  | 16d → 2d | none → 12 |  |
| 14 | Install Network Cables | 2018-07-02 → 2019-07-05 (+368d) | 2018-07-05 → 2019-07-09 (+369d) |  |  | 14d → 2d | none → 13 |  |
| 15 | Lay Carpet | 2018-07-02 → 2019-07-10 (+373d) | 2018-07-03 → 2019-07-11 (+373d) |  |  | 15d → 2d | none → 14 |  |
| 16 | Prepare Offices | 2018-07-02 → 2019-07-12 (+375d) | 2018-07-09 → 2019-07-18 (+374d) |  |  | 12d → 2d | none → 15 |  |
| 17 | Assemble Furniture | 2018-07-02 → 2019-07-19 (+382d) | 2018-07-03 → 2019-07-22 (+384d) |  |  | 15d → 2d | none → 16 |  |
| 18 | Hook up Computers | 2018-07-02 → 2019-07-23 (+386d) | 2018-07-02 → 2019-07-23 (+386d) |  |  | 16d → 2d | none → 17 |  |
| 19 | Move in Belongings | 2018-07-02 → 2019-07-24 (+387d) | 2018-07-03 → 2019-07-25 (+387d) |  |  | 15d → 2d | none → 18 |  |
| 20 | Office 102 Complete | 2018-07-01 → 2019-07-25 (+389d) | 2018-07-01 → 2019-07-25 (+389d) |  |  | 17d → 2d | none → 19 |  |

## Version 3 (saved 2019-05-22, file JT New Workspace 2.mpp)

Last finish 2019-07-29 → 2019-07-30 (+1d). Complete tasks 0 → 1.

Changed:

| ID | Task | Start | Finish | Duration | Complete | Total float | Other |
| --- | --- | --- | --- | --- | --- | --- | --- |
| 1 | **Office Number 101** | 2019-07-01 → 2019-07-02 A (+1d) | 2019-07-24 → 2019-07-26 (+2d) | 17d → 18d | 0% → 13% | 0d → 2d | baseline start none → 2018-07-02; baseline finish none → 2018-07-25 |
| 2 | Paint the walls | 2019-07-01 → 2019-07-02 A (+1d) | 2019-07-02 → 2019-07-03 A (+1d) |  | 0% → 100% | 0d → none | baseline start none → 2018-07-02; baseline finish none → 2018-07-03 |
| 3 | Install Partitions | 2019-07-03 → 2019-07-05 A (+2d) | 2019-07-03 → 2019-07-05 (+2d) |  | 0% → 25% |  | baseline start none → 2018-07-04; baseline finish none → 2018-07-04 |
| 4 | Install Network Cables | 2019-07-04 → 2019-07-08 (+4d) | 2019-07-08 → 2019-07-10 (+2d) |  |  |  | baseline start none → 2018-07-05; baseline finish none → 2018-07-09 |
| 5 | Lay Carpet | 2019-07-09 → 2019-07-11 (+2d) | 2019-07-10 → 2019-07-12 (+2d) |  |  | 3d → 2d | baseline start none → 2018-07-10; baseline finish none → 2018-07-11 |
| 6 | Prepare Offices | 2019-07-11 → 2019-07-15 (+4d) | 2019-07-17 → 2019-07-19 (+2d) |  |  | 3d → 2d | baseline start none → 2018-07-12; baseline finish none → 2018-07-18 |
| 7 | Assemble Furniture | 2019-07-18 → 2019-07-22 (+4d) | 2019-07-19 → 2019-07-23 (+4d) |  |  | 3d → 2d | baseline start none → 2018-07-19; baseline finish none → 2018-07-20 |
| 8 | Hook up Computers | 2019-07-22 → 2019-07-24 (+2d) | 2019-07-22 → 2019-07-24 (+2d) |  |  | 3d → 2d | baseline start none → 2018-07-23; baseline finish none → 2018-07-23 |
| 9 | Move in Belongings | 2019-07-23 → 2019-07-25 (+2d) | 2019-07-24 → 2019-07-26 (+2d) |  |  | 3d → 2d | baseline start none → 2018-07-24; baseline finish none → 2018-07-25 |
| 10 | Office 101 Complete | 2019-07-24 → 2019-07-26 (+2d) | 2019-07-24 → 2019-07-26 (+2d) |  |  | 3d → 2d | baseline start none → 2018-07-25; baseline finish none → 2018-07-25 |
| 11 | **Office Number 102** | 2019-07-02 → 2019-07-03 (+1d) | 2019-07-29 → 2019-07-30 (+1d) |  |  |  | baseline start none → 2018-07-05; baseline finish none → 2018-08-01 |
| 12 | Paint the walls | 2019-07-02 → 2019-07-03 (+1d) | 2019-07-02 → 2019-07-03 (+1d) |  |  |  | baseline start none → 2018-07-05; baseline finish none → 2018-07-06 |
| 13 | Install Partitions | 2019-07-03 → 2019-07-05 (+2d) | 2019-07-03 → 2019-07-05 (+2d) |  |  |  | baseline start none → 2018-07-09; baseline finish none → 2018-07-09 |
| 14 | Install Network Cables | 2019-07-05 → 2019-07-08 (+3d) | 2019-07-09 → 2019-07-10 (+1d) |  |  |  | baseline start none → 2018-07-10; baseline finish none → 2018-07-12 |
| 15 | Lay Carpet | 2019-07-10 → 2019-07-11 (+1d) | 2019-07-11 → 2019-07-12 (+1d) |  |  |  | baseline start none → 2018-07-13; baseline finish none → 2018-07-16 |
| 16 | Prepare Offices | 2019-07-12 → 2019-07-15 (+3d) | 2019-07-18 → 2019-07-19 (+1d) |  |  |  | baseline start none → 2018-07-17; baseline finish none → 2018-07-23 |
| 17 | Assemble Furniture | 2019-07-19 → 2019-07-22 (+3d) | 2019-07-22 → 2019-07-23 (+1d) |  |  |  | baseline start none → 2018-07-24; baseline finish none → 2018-07-25 |
| 18 | Hook up Computers | 2019-07-23 → 2019-07-24 (+1d) | 2019-07-23 → 2019-07-24 (+1d) |  |  |  | baseline start none → 2018-07-26; baseline finish none → 2018-07-26 |
| 19 | Move in Belongings | 2019-07-24 → 2019-07-25 (+1d) | 2019-07-25 → 2019-07-26 (+1d) |  |  |  | baseline start none → 2018-07-27; baseline finish none → 2018-07-30 |
| 20 | Office 102 Complete | 2019-07-25 → 2019-07-26 (+1d) | 2019-07-25 → 2019-07-26 (+1d) |  |  |  | baseline start none → 2018-07-30; baseline finish none → 2018-07-30 |
| 21 | **Office Number 103** | 2019-07-03 → 2019-07-05 (+2d) | 2019-07-29 → 2019-07-30 (+1d) |  |  |  | baseline start none → 2018-07-09; baseline finish none → 2018-08-01 |
| 22 | Paint the walls | 2019-07-03 → 2019-07-05 (+2d) | 2019-07-05 → 2019-07-08 (+3d) |  |  |  | baseline start none → 2018-07-09; baseline finish none → 2018-07-10 |
| 23 | Install Partitions | 2019-07-08 → 2019-07-09 (+1d) | 2019-07-08 → 2019-07-09 (+1d) |  |  |  | baseline start none → 2018-07-11; baseline finish none → 2018-07-11 |
| 24 | Install Network Cables | 2019-07-09 → 2019-07-10 (+1d) | 2019-07-11 → 2019-07-12 (+1d) |  |  |  | baseline start none → 2018-07-12; baseline finish none → 2018-07-16 |
| 25 | Lay Carpet | 2019-07-12 → 2019-07-15 (+3d) | 2019-07-15 → 2019-07-16 (+1d) |  |  |  | baseline start none → 2018-07-17; baseline finish none → 2018-07-18 |
| 26 | Prepare Offices | 2019-07-16 → 2019-07-17 (+1d) | 2019-07-22 → 2019-07-23 (+1d) |  |  |  | baseline start none → 2018-07-19; baseline finish none → 2018-07-25 |
| 27 | Assemble Furniture | 2019-07-23 → 2019-07-24 (+1d) | 2019-07-24 → 2019-07-25 (+1d) |  |  |  | baseline start none → 2018-07-26; baseline finish none → 2018-07-27 |
| 28 | Hook up Computers | 2019-07-25 → 2019-07-26 (+1d) | 2019-07-25 → 2019-07-26 (+1d) |  |  |  | baseline start none → 2018-07-30; baseline finish none → 2018-07-30 |
| 29 | Move in Belongings | 2019-07-26 → 2019-07-29 (+3d) | 2019-07-29 → 2019-07-30 (+1d) |  |  |  | baseline start none → 2018-07-31; baseline finish none → 2018-08-01 |
| 30 | Office 103 Complete | 2019-07-29 → 2019-07-30 (+1d) | 2019-07-29 → 2019-07-30 (+1d) |  |  |  | baseline start none → 2018-08-01; baseline finish none → 2018-08-01 |
| 31 | Finsih New Office Worspace Complete | 2019-07-29 → 2019-07-30 (+1d) | 2019-07-29 → 2019-07-30 (+1d) |  |  |  | baseline start none → 2018-08-01; baseline finish none → 2018-08-01 |
