# JT Corporate Move

How a schedule from MS Project changed from version to version. A marks actual dates.

## Version 1 (saved 2019-05-30, file JT Corporate Move Critical Path.mpp)

| ID | WBS | Task | Duration | Start | Finish | Predecessors | Total float | Constraint |
| --- | --- | --- | --- | --- | --- | --- | --- | --- |
| 1 | 1 | **JT Move Status Meetings** | 10.12d | 2019-07-05 | 2019-07-19 |  | 97.38d |  |
| 2 |  | JT Move Status Meetings 1 | 1h | 2019-07-05 | 2019-07-05 |  | 107.38d | start no earlier than 2019-07-05 |
| 3 |  | JT Move Status Meetings 2 | 1h | 2019-07-12 | 2019-07-12 |  | 102.38d | start no earlier than 2019-07-12 |
| 4 |  | JT Move Status Meetings 3 | 1h | 2019-07-19 | 2019-07-19 |  | 97.38d | start no earlier than 2019-07-19 |
| 5 | 2 | **Planning the Move** | 49.38d | 2019-07-01 | 2019-09-09 |  | 2.62d |  |
| 6 |  | Identify Move Team Members | 2d | 2019-07-01 | 2019-07-02 |  | 2.62d |  |
| 7 |  | Plan Infastructure Upgrades | 2w | 2019-07-03 | 2019-07-17 | 6 | 2.62d |  |
| 8 |  | Plan IT Move | 2w | 2019-07-18 | 2019-07-31 | 7 | 2.62d |  |
| 9 |  | Plan Physical Move | 2w | 2019-07-22 | 2019-08-05 | 8FS-7.5% | 2.62d |  |
| 10 |  | Plan for Continous Operations During the Move | 4d | 2019-08-05 | 2019-08-09 | 9 | 2.62d |  |
| 11 |  | Obtain Estimates from Moving Services | 1w | 2019-08-09 | 2019-08-16 | 10 | 2.62d |  |
| 12 |  | Interview and Select Movers | 1w | 2019-08-16 | 2019-08-23 | 11 | 2.62d |  |
| 13 |  | Obtain Estimates from IT Installation Companies | 1w | 2019-08-16 | 2019-08-23 | 11 | 2.62d |  |
| 14 |  | Interview and Select IT Installation Company | 1w | 2019-08-23 | 2019-08-30 | 13, 12 | 2.62d |  |
| 15 |  | Order Boxes and Materials needed for the Move | 3h | 2019-08-30 | 2019-08-30 | 14 | 2.62d |  |
| 16 |  | Planning the Move Complete | 0d | 2019-08-30 | 2019-08-30 | 15 | 2.62d |  |
| 17 | 2.12 | **Communications** | 5.5d | 2019-08-30 | 2019-09-09 |  | 2.62d |  |
| 18 |  | Communicate Move Plan to Employees | 3d | 2019-08-30 | 2019-09-04 | 16 | 2.62d |  |
| 19 |  | Gather Feedback From Employees | 2d | 2019-09-04 | 2019-09-06 | 18 | 2.62d |  |
| 20 |  | Communicate Move Information to Suppliers | 2h | 2019-09-06 | 2019-09-09 | 19 | 2.62d |  |
| 21 |  | Communicate Move Information to Customers | 2h | 2019-09-09 | 2019-09-09 | 20 | 2.62d |  |
| 22 |  | Communications Complete | 0d | 2019-09-09 | 2019-09-09 | 21 | 2.62d |  |
| 23 | 3 | **JT Corporate Center Preparation** | 24d | 2019-09-09 | 2019-10-11 |  | 2.62d |  |
| 24 | 3.1 | **JT Call Center Refurbishing New Location** | 22d | 2019-09-09 | 2019-10-09 |  | 2.62d |  |
| 25 |  | Install Network Cables | 3d | 2019-09-09 | 2019-09-12 | 22 | 2.62d |  |
| 26 |  | Install TeleCommunication Lines | 1w | 2019-09-12 | 2019-09-19 | 25 | 4.62d |  |
| 27 |  | Paint the walls | 2d | 2019-09-19 | 2019-09-23 | 26 | 4.62d |  |
| 28 |  | Lay Carpet | 2d | 2019-09-24 | 2019-09-26 | 27FS+1ed | 4.62d |  |
| 29 |  | Install Partitions | 1d | 2019-09-26 | 2019-09-27 | 28 | 4.62d |  |
| 30 |  | Prepare Offices | 5d | 2019-09-27 | 2019-10-04 | 29 | 4.62d |  |
| 31 |  | Assemble Furniture | 2d | 2019-10-04 | 2019-10-08 | 30 | 4.62d |  |
| 32 |  | Hook up Computers | 1d | 2019-10-08 | 2019-10-09 | 31 | 4.62d |  |
| 33 |  | Hook up Phones | 1d | 2019-10-08 | 2019-10-09 | 32FF | 4.62d |  |
| 34 |  | JT Call Center Complete | 0d | 2019-10-09 | 2019-10-09 | 33 | 4.62d |  |
| 35 | 3.2 | **JT Internet Sales Center Refurbishing New Location** | 24d | 2019-09-09 | 2019-10-11 |  | 2.62d |  |
| 36 |  | Install Network Cables | 3d | 2019-09-09 | 2019-09-12 | 25SS | 2.62d |  |
| 37 |  | Install TeleCommunication Lines | 1w | 2019-09-12 | 2019-09-19 | 36 | 2.62d |  |
| 38 |  | Paint the walls | 2d | 2019-09-19 | 2019-09-23 | 37 | 2.62d |  |
| 39 |  | Lay Carpet | 2d | 2019-09-24 | 2019-09-26 | 38FS+1ed | 2.62d |  |
| 40 |  | Install Partitions | 1d | 2019-09-26 | 2019-09-27 | 39 | 2.62d |  |
| 41 |  | Prepare Offices | 5d | 2019-09-27 | 2019-10-04 | 40 | 2.62d |  |
| 42 |  | Assemble Furniture | 2d | 2019-10-04 | 2019-10-08 | 41 | 2.62d |  |
| 43 |  | Hook up Computers | 1d | 2019-10-08 | 2019-10-09 | 42 | 2.62d |  |
| 44 |  | Hook up Phones | 1d | 2019-10-08 | 2019-10-09 | 43FF | 2.62d |  |
| 45 |  | Move in Belongings | 2d | 2019-10-09 | 2019-10-11 | 44 | 2.62d |  |
| 46 |  | JT Internet Sales Center Complete | 0d | 2019-10-11 | 2019-10-11 | 45 | 2.62d |  |
| 47 | 3.3 | **JT Administration Offices Refurbishing New Location** | 24d | 2019-09-09 | 2019-10-11 |  | 2.62d |  |
| 48 |  | Install Network Cables | 3d | 2019-09-09 | 2019-09-12 | 36SS | 2.62d |  |
| 49 |  | Install TeleCommunication Lines | 1w | 2019-09-12 | 2019-09-19 | 48 | 2.62d |  |
| 50 |  | Paint the walls | 2d | 2019-09-19 | 2019-09-23 | 49 | 2.62d |  |
| 51 |  | Lay Carpet | 2d | 2019-09-24 | 2019-09-26 | 50FS+1ed | 2.62d |  |
| 52 |  | Install Partitions | 1d | 2019-09-26 | 2019-09-27 | 51 | 2.62d |  |
| 53 |  | Prepare Offices | 5d | 2019-09-27 | 2019-10-04 | 52 | 2.62d |  |
| 54 |  | Assemble Furniture | 2d | 2019-10-04 | 2019-10-08 | 53 | 2.62d |  |
| 55 |  | Hook up Computers | 1d | 2019-10-08 | 2019-10-09 | 54 | 2.62d |  |
| 56 |  | Hook up Phones | 1d | 2019-10-08 | 2019-10-09 | 55FF | 2.62d |  |
| 57 |  | Move in Belongings | 2d | 2019-10-09 | 2019-10-11 | 56 | 2.62d |  |
| 58 |  | JT Administrative Offices Complete | 0d | 2019-10-11 | 2019-10-11 | 57 | 2.62d |  |
| 59 |  | JT Offices Refurbishing Complete | 0d | 2019-10-11 | 2019-10-11 | 34, 46, 58 | 2.62d |  |
| 60 | 4 | **Moving** | 32.25d | 2019-10-16 | 2019-11-29 |  | 0d |  |
| 61 | 4.1 | **Packing** | 25.25d | 2019-10-16 | 2019-11-20 |  | 0d |  |
| 62 |  | Distribute Boxes to Employees | 3d | 2019-10-16 | 2019-10-18 | 59 | 0d | start no earlier than 2019-10-16 |
| 63 |  | Communicate Timetable and Packing Requirements to Employees | 1d | 2019-10-21 | 2019-10-21 | 62 | 0d |  |
| 64 |  | Tag Furniture and Equipment to Identify New Area Staging | 2w | 2019-10-22 | 2019-11-04 | 63 | 0d |  |
| 65 |  | Tag Computer Equipment to Identify New Are Staging | 2w | 2019-11-05 | 2019-11-18 | 64 | 0d |  |
| 66 |  | Packing Complete | 0d | 2019-11-18 | 2019-11-18 | 65 | 0d |  |
| 67 | 4.1.6 | **Final Moving Preperations** | 1.25d | 2019-11-19 | 2019-11-20 |  | 0d |  |
| 68 |  | Communicate Rotation Schedule to Insure Continous Operations | 3h | 2019-11-19 | 2019-11-19 | 66 | 0d |  |
| 69 |  | Walk-through to Double Chjeck Tagging of All Furniture and Equipment | 2h | 2019-11-19 | 2019-11-19 | 68 | 0d |  |
| 70 |  | Review Move Schedule with Team Leaders | 3h | 2019-11-19 | 2019-11-19 | 69 | 0d |  |

| ID | WBS | Task | Duration | Start | Finish | Predecessors | Total float | Constraint |
| --- | --- | --- | --- | --- | --- | --- | --- | --- |
| 71 |  | Review Move Schedule with Movers | 2h | 2019-11-20 | 2019-11-20 | 70 | 0d |  |
| 72 |  | Final Moving Preperations Complete | 0d | 2019-11-20 | 2019-11-20 | 71 | 0d |  |
| 73 | 4.2 | **Move Furniture and Equipment** | 7d | 2019-11-20 | 2019-11-29 |  | 0d |  |
| 74 |  | Move JT Administrative Offices | 2d | 2019-11-20 | 2019-11-22 | 72 | 0d |  |
| 75 |  | Move First Wave JT Call Center | 1d | 2019-11-22 | 2019-11-25 | 74 | 0d |  |
| 76 |  | Move First Wave JT Internet Sales Center | 1d | 2019-11-25 | 2019-11-26 | 75 | 0d |  |
| 77 |  | Setup New JT Call Center for Operations | 0.5d | 2019-11-26 | 2019-11-26 | 76 | 0d |  |
| 78 |  | Setup New JT Internet Sales Center for Operations | 0.5d | 2019-11-26 | 2019-11-27 | 77 | 0d |  |
| 79 |  | New JT Call Center Operational | 0d | 2019-11-27 | 2019-11-27 | 78 | 0d |  |
| 80 |  | New JT Internet Sales Center Operational | 0d | 2019-11-27 | 2019-11-27 | 79 | 0d |  |
| 81 |  | Move Final Group JT Call Center | 1d | 2019-11-27 | 2019-11-28 | 80 | 0d |  |
| 82 |  | Move Final Group JT Internet Sales Center | 1d | 2019-11-28 | 2019-11-29 | 81 | 0d |  |
| 83 |  | Move Furniture and Equipment Complete | 0d | 2019-11-29 | 2019-11-29 | 82 | 0d |  |
| 84 |  | Move Complete | 0d | 2019-11-29 | 2019-11-29 | 83 | 0d |  |
| 85 | 5 | **JT Corporate Move Closeout** | 2.25d | 2019-11-29 | 2019-12-03 |  | 0d |  |
| 86 |  | Unpacking all areas | 2d | 2019-11-29 | 2019-12-03 | 84 | 0d |  |
| 87 |  | Company-Wide Meeting | 2h | 2019-12-03 | 2019-12-03 | 86 | 0d |  |
| 88 |  | Move Evaluation | 0.5d | 2019-12-02 | 2019-12-03 | 87SF | 0.12d |  |
| 89 |  | Pay Movers | 1h | 2019-12-03 | 2019-12-03 | 88 | 0.12d |  |
| 90 |  | JT Corporate Move Closeout Complete | 0d | 2019-12-03 | 2019-12-03 | 89 | 0.12d |  |
| 91 |  | JT Corporate Move Complete | 0d | 2019-12-03 | 2019-12-03 | 90 | 0.12d | finish no later than 2019-12-05 |

## Version 2 (saved 2019-05-30, file JT Corporate Move Baseline .mpp)

Last finish stays 2019-12-03.

Changed:

| ID | Task | Other |
| --- | --- | --- |
| 6 | Identify Move Team Members | resources Laura Lynn → none |
| 7 | Plan Infastructure Upgrades | resources Juan Silva → none |
| 8 | Plan IT Move | resources Charlie Mejia; Rick Herrera → none |
| 9 | Plan Physical Move | resources Charlie Mejia; Rick Herrera → none |
| 10 | Plan for Continous Operations During the Move | resources Dorothy Windle [50%]; Juan Silva [50%] → none |
| 11 | Obtain Estimates from Moving Services | resources Administration Services [200%] → none |
| 12 | Interview and Select Movers | resources Administration Services [200%] → none |
| 13 | Obtain Estimates from IT Installation Companies | resources Administration Services [200%] → none |
| 14 | Interview and Select IT Installation Company | resources Administration Services [200%] → none |
| 15 | Order Boxes and Materials needed for the Move | resources Administration Services [200%] → none |
| 18 | Communicate Move Plan to Employees | resources Ron Sova [50%] → none |
| 19 | Gather Feedback From Employees | resources Ron Sova [50%] → none |
| 20 | Communicate Move Information to Suppliers | resources Ron Sova [50%] → none |
| 21 | Communicate Move Information to Customers | resources Ron Sova [50%] → none |
| 25 | Install Network Cables | resources Network Heroes → none |
| 26 | Install TeleCommunication Lines | resources Network Heroes → none |
| 27 | Paint the walls | resources Extreme Designs → none |
| 28 | Lay Carpet | resources Extreme Designs → none |
| 29 | Install Partitions | resources Extreme Designs → none |
| 30 | Prepare Offices | resources Extreme Designs → none |
| 31 | Assemble Furniture | resources Extreme Designs → none |
| 32 | Hook up Computers | resources Network Heroes → none |
| 33 | Hook up Phones | resources Network Heroes → none |
| 36 | Install Network Cables | resources Network Heroes → none |
| 37 | Install TeleCommunication Lines | resources Network Heroes → none |
| 38 | Paint the walls | resources Extreme Designs → none |
| 39 | Lay Carpet | resources Extreme Designs → none |
| 40 | Install Partitions | resources Extreme Designs → none |
| 41 | Prepare Offices | resources Extreme Designs → none |
| 42 | Assemble Furniture | resources Extreme Designs → none |
| 43 | Hook up Computers | resources Network Heroes → none |
| 44 | Hook up Phones | resources Network Heroes → none |
| 48 | Install Network Cables | resources Network Heroes → none |
| 49 | Install TeleCommunication Lines | resources Network Heroes → none |
| 50 | Paint the walls | resources Extreme Designs → none |
| 51 | Lay Carpet | resources Extreme Designs → none |
| 52 | Install Partitions | resources Extreme Designs → none |
| 53 | Prepare Offices | resources Extreme Designs → none |
| 54 | Assemble Furniture | resources Extreme Designs → none |
| 55 | Hook up Computers | resources Network Heroes → none |
| 56 | Hook up Phones | resources Network Heroes → none |
| 62 | Distribute Boxes to Employees | resources Maintenance → none |
| 63 | Communicate Timetable and Packing Requirements to Employees | resources Ron Sova → none |
| 64 | Tag Furniture and Equipment to Identify New Area Staging | resources Internet Sales Day Operators [700%]; Call Center Day Analysts [600%] → none |
| 65 | Tag Computer Equipment to Identify New Are Staging | resources Informations Technology Systems [300%] → none |
| 68 | Communicate Rotation Schedule to Insure Continous Operations | resources Ron Sova → none |
| 69 | Walk-through to Double Chjeck Tagging of All Furniture and Equipment | resources Charlie Mejia → none |
| 70 | Review Move Schedule with Team Leaders | resources Charlie Mejia [20%] → none |
| 71 | Review Move Schedule with Movers | resources Charlie Mejia [20%] → none |
| 74 | Move JT Administrative Offices | resources Maintenance [200%] → none |
| 75 | Move First Wave JT Call Center | resources Maintenance [200%] → none |
| 76 | Move First Wave JT Internet Sales Center | resources Maintenance [200%] → none |
| 77 | Setup New JT Call Center for Operations | resources Network Heroes → none |
| 78 | Setup New JT Internet Sales Center for Operations | resources Network Heroes → none |

## Version 3 (saved 2019-05-31, file JT Corporate Move View Tracking Gantt.mpp)

Last finish stays 2019-12-03.

Changed:

| ID | Task | Other |
| --- | --- | --- |
| 1 | **JT Move Status Meetings** | baseline start none → 2019-07-05; baseline finish none → 2019-07-19 |
| 2 | JT Move Status Meetings 1 | baseline start none → 2019-07-05; baseline finish none → 2019-07-05 |
| 3 | JT Move Status Meetings 2 | baseline start none → 2019-07-12; baseline finish none → 2019-07-12 |
| 4 | JT Move Status Meetings 3 | baseline start none → 2019-07-19; baseline finish none → 2019-07-19 |
| 5 | **Planning the Move** | baseline start none → 2019-07-01; baseline finish none → 2019-09-09 |
| 6 | Identify Move Team Members | baseline start none → 2019-07-01; baseline finish none → 2019-07-02 |
| 7 | Plan Infastructure Upgrades | baseline start none → 2019-07-03; baseline finish none → 2019-07-17 |
| 8 | Plan IT Move | baseline start none → 2019-07-18; baseline finish none → 2019-07-31 |
| 9 | Plan Physical Move | baseline start none → 2019-07-22; baseline finish none → 2019-08-05 |
| 10 | Plan for Continous Operations During the Move | baseline start none → 2019-08-05; baseline finish none → 2019-08-09 |
| 11 | Obtain Estimates from Moving Services | baseline start none → 2019-08-09; baseline finish none → 2019-08-16 |
| 12 | Interview and Select Movers | baseline start none → 2019-08-16; baseline finish none → 2019-08-23 |
| 13 | Obtain Estimates from IT Installation Companies | baseline start none → 2019-08-16; baseline finish none → 2019-08-23 |
| 14 | Interview and Select IT Installation Company | baseline start none → 2019-08-23; baseline finish none → 2019-08-30 |
| 15 | Order Boxes and Materials needed for the Move | baseline start none → 2019-08-30; baseline finish none → 2019-08-30 |
| 16 | Planning the Move Complete | baseline start none → 2019-08-30; baseline finish none → 2019-08-30 |
| 17 | **Communications** | baseline start none → 2019-08-30; baseline finish none → 2019-09-09 |
| 18 | Communicate Move Plan to Employees | baseline start none → 2019-08-30; baseline finish none → 2019-09-04 |
| 19 | Gather Feedback From Employees | baseline start none → 2019-09-04; baseline finish none → 2019-09-06 |
| 20 | Communicate Move Information to Suppliers | baseline start none → 2019-09-06; baseline finish none → 2019-09-09 |
| 21 | Communicate Move Information to Customers | baseline start none → 2019-09-09; baseline finish none → 2019-09-09 |
| 22 | Communications Complete | baseline start none → 2019-09-09; baseline finish none → 2019-09-09 |
| 23 | **JT Corporate Center Preparation** | baseline start none → 2019-09-09; baseline finish none → 2019-10-11 |
| 24 | **JT Call Center Refurbishing New Location** | baseline start none → 2019-09-09; baseline finish none → 2019-10-09 |
| 25 | Install Network Cables | baseline start none → 2019-09-09; baseline finish none → 2019-09-12 |
| 26 | Install TeleCommunication Lines | baseline start none → 2019-09-12; baseline finish none → 2019-09-19 |
| 27 | Paint the walls | baseline start none → 2019-09-19; baseline finish none → 2019-09-23 |
| 28 | Lay Carpet | baseline start none → 2019-09-24; baseline finish none → 2019-09-26 |
| 29 | Install Partitions | baseline start none → 2019-09-26; baseline finish none → 2019-09-27 |
| 30 | Prepare Offices | baseline start none → 2019-09-27; baseline finish none → 2019-10-04 |
| 31 | Assemble Furniture | baseline start none → 2019-10-04; baseline finish none → 2019-10-08 |
| 32 | Hook up Computers | baseline start none → 2019-10-08; baseline finish none → 2019-10-09 |
| 33 | Hook up Phones | baseline start none → 2019-10-08; baseline finish none → 2019-10-09 |
| 34 | JT Call Center Complete | baseline start none → 2019-10-09; baseline finish none → 2019-10-09 |
| 35 | **JT Internet Sales Center Refurbishing New Location** | baseline start none → 2019-09-09; baseline finish none → 2019-10-11 |
| 36 | Install Network Cables | baseline start none → 2019-09-09; baseline finish none → 2019-09-12 |
| 37 | Install TeleCommunication Lines | baseline start none → 2019-09-12; baseline finish none → 2019-09-19 |
| 38 | Paint the walls | baseline start none → 2019-09-19; baseline finish none → 2019-09-23 |
| 39 | Lay Carpet | baseline start none → 2019-09-24; baseline finish none → 2019-09-26 |
| 40 | Install Partitions | baseline start none → 2019-09-26; baseline finish none → 2019-09-27 |
| 41 | Prepare Offices | baseline start none → 2019-09-27; baseline finish none → 2019-10-04 |
| 42 | Assemble Furniture | baseline start none → 2019-10-04; baseline finish none → 2019-10-08 |
| 43 | Hook up Computers | baseline start none → 2019-10-08; baseline finish none → 2019-10-09 |
| 44 | Hook up Phones | baseline start none → 2019-10-08; baseline finish none → 2019-10-09 |
| 45 | Move in Belongings | baseline start none → 2019-10-09; baseline finish none → 2019-10-11 |
| 46 | JT Internet Sales Center Complete | baseline start none → 2019-10-11; baseline finish none → 2019-10-11 |
| 47 | **JT Administration Offices Refurbishing New Location** | baseline start none → 2019-09-09; baseline finish none → 2019-10-11 |
| 48 | Install Network Cables | baseline start none → 2019-09-09; baseline finish none → 2019-09-12 |
| 49 | Install TeleCommunication Lines | baseline start none → 2019-09-12; baseline finish none → 2019-09-19 |
| 50 | Paint the walls | baseline start none → 2019-09-19; baseline finish none → 2019-09-23 |
| 51 | Lay Carpet | baseline start none → 2019-09-24; baseline finish none → 2019-09-26 |
| 52 | Install Partitions | baseline start none → 2019-09-26; baseline finish none → 2019-09-27 |
| 53 | Prepare Offices | baseline start none → 2019-09-27; baseline finish none → 2019-10-04 |
| 54 | Assemble Furniture | baseline start none → 2019-10-04; baseline finish none → 2019-10-08 |
| 55 | Hook up Computers | baseline start none → 2019-10-08; baseline finish none → 2019-10-09 |
| 56 | Hook up Phones | baseline start none → 2019-10-08; baseline finish none → 2019-10-09 |
| 57 | Move in Belongings | baseline start none → 2019-10-09; baseline finish none → 2019-10-11 |
| 58 | JT Administrative Offices Complete | baseline start none → 2019-10-11; baseline finish none → 2019-10-11 |
| 59 | JT Offices Refurbishing Complete | baseline start none → 2019-10-11; baseline finish none → 2019-10-11 |
| 60 | **Moving** | baseline start none → 2019-10-16; baseline finish none → 2019-11-29 |
| 61 | **Packing** | baseline start none → 2019-10-16; baseline finish none → 2019-11-20 |
| 62 | Distribute Boxes to Employees | baseline start none → 2019-10-16; baseline finish none → 2019-10-18 |
| 63 | Communicate Timetable and Packing Requirements to Employees | baseline start none → 2019-10-21; baseline finish none → 2019-10-21 |
| 64 | Tag Furniture and Equipment to Identify New Area Staging | baseline start none → 2019-10-22; baseline finish none → 2019-11-04 |
| 65 | Tag Computer Equipment to Identify New Are Staging | baseline start none → 2019-11-05; baseline finish none → 2019-11-18 |
| 66 | Packing Complete | baseline start none → 2019-11-18; baseline finish none → 2019-11-18 |
| 67 | **Final Moving Preperations** | baseline start none → 2019-11-19; baseline finish none → 2019-11-20 |
| 68 | Communicate Rotation Schedule to Insure Continous Operations | baseline start none → 2019-11-19; baseline finish none → 2019-11-19 |
| 69 | Walk-through to Double Chjeck Tagging of All Furniture and Equipment | baseline start none → 2019-11-19; baseline finish none → 2019-11-19 |
| 70 | Review Move Schedule with Team Leaders | baseline start none → 2019-11-19; baseline finish none → 2019-11-19 |

| ID | Task | Other |
| --- | --- | --- |
| 71 | Review Move Schedule with Movers | baseline start none → 2019-11-20; baseline finish none → 2019-11-20 |
| 72 | Final Moving Preperations Complete | baseline start none → 2019-11-20; baseline finish none → 2019-11-20 |
| 73 | **Move Furniture and Equipment** | baseline start none → 2019-11-20; baseline finish none → 2019-11-29 |
| 74 | Move JT Administrative Offices | baseline start none → 2019-11-20; baseline finish none → 2019-11-22 |
| 75 | Move First Wave JT Call Center | baseline start none → 2019-11-22; baseline finish none → 2019-11-25 |
| 76 | Move First Wave JT Internet Sales Center | baseline start none → 2019-11-25; baseline finish none → 2019-11-26 |
| 77 | Setup New JT Call Center for Operations | baseline start none → 2019-11-26; baseline finish none → 2019-11-26 |
| 78 | Setup New JT Internet Sales Center for Operations | baseline start none → 2019-11-26; baseline finish none → 2019-11-27 |
| 79 | New JT Call Center Operational | baseline start none → 2019-11-27; baseline finish none → 2019-11-27 |
| 80 | New JT Internet Sales Center Operational | baseline start none → 2019-11-27; baseline finish none → 2019-11-27 |
| 81 | Move Final Group JT Call Center | baseline start none → 2019-11-27; baseline finish none → 2019-11-28 |
| 82 | Move Final Group JT Internet Sales Center | baseline start none → 2019-11-28; baseline finish none → 2019-11-29 |
| 83 | Move Furniture and Equipment Complete | baseline start none → 2019-11-29; baseline finish none → 2019-11-29 |
| 84 | Move Complete | baseline start none → 2019-11-29; baseline finish none → 2019-11-29 |
| 85 | **JT Corporate Move Closeout** | baseline start none → 2019-11-29; baseline finish none → 2019-12-03 |
| 86 | Unpacking all areas | baseline start none → 2019-11-29; baseline finish none → 2019-12-03 |
| 87 | Company-Wide Meeting | baseline start none → 2019-12-03; baseline finish none → 2019-12-03 |
| 88 | Move Evaluation | baseline start none → 2019-12-02; baseline finish none → 2019-12-03 |
| 89 | Pay Movers | baseline start none → 2019-12-03; baseline finish none → 2019-12-03 |
| 90 | JT Corporate Move Closeout Complete | baseline start none → 2019-12-03; baseline finish none → 2019-12-03 |
| 91 | JT Corporate Move Complete | baseline start none → 2019-12-03; baseline finish none → 2019-12-03 |

## Version 4 (saved 2019-05-31, file JT Corporate Move Updating Tasks.mpp)

Last finish 2019-12-03 → 2019-12-06 (+3d).

Added:

| ID | Task | Duration | Start | Finish | Constraint |
| --- | --- | --- | --- | --- | --- |
| 5 | JT Move Status Meetings 4 | 1h | 2019-07-26 08:00 | 2019-07-26 09:00 | start no earlier than 2019-07-26 08:00 |
| 6 | JT Move Status Meetings 5 | 1h | 2019-08-02 08:00 | 2019-08-02 09:00 | start no earlier than 2019-08-02 08:00 |
| 7 | JT Move Status Meetings 6 | 1h | 2019-08-09 08:00 | 2019-08-09 09:00 | start no earlier than 2019-08-09 08:00 |
| 8 | JT Move Status Meetings 7 | 1h | 2019-08-16 08:00 | 2019-08-16 09:00 | start no earlier than 2019-08-16 08:00 |
| 9 | JT Move Status Meetings 8 | 1h | 2019-08-23 08:00 | 2019-08-23 09:00 | start no earlier than 2019-08-23 08:00 |
| 10 | JT Move Status Meetings 9 | 1h | 2019-08-30 08:00 | 2019-08-30 09:00 | start no earlier than 2019-08-30 08:00 |
| 11 | JT Move Status Meetings 10 | 1h | 2019-09-06 08:00 | 2019-09-06 09:00 | start no earlier than 2019-09-06 08:00 |
| 12 | JT Move Status Meetings 11 | 1h | 2019-09-13 08:00 | 2019-09-13 09:00 | start no earlier than 2019-09-13 08:00 |
| 13 | JT Move Status Meetings 12 | 1h | 2019-09-20 08:00 | 2019-09-20 09:00 | start no earlier than 2019-09-20 08:00 |
| 14 | JT Move Status Meetings 13 | 1h | 2019-09-27 08:00 | 2019-09-27 09:00 | start no earlier than 2019-09-27 08:00 |
| 15 | JT Move Status Meetings 14 | 1h | 2019-10-04 08:00 | 2019-10-04 09:00 | start no earlier than 2019-10-04 08:00 |
| 16 | JT Move Status Meetings 15 | 1h | 2019-10-11 08:00 | 2019-10-11 09:00 | start no earlier than 2019-10-11 08:00 |
| 17 | JT Move Status Meetings 16 | 1h | 2019-10-18 08:00 | 2019-10-18 09:00 | start no earlier than 2019-10-18 08:00 |
| 18 | JT Move Status Meetings 17 | 1h | 2019-10-25 08:00 | 2019-10-25 09:00 | start no earlier than 2019-10-25 08:00 |
| 19 | JT Move Status Meetings 18 | 1h | 2019-11-01 08:00 | 2019-11-01 09:00 | start no earlier than 2019-11-01 08:00 |
| 20 | JT Move Status Meetings 19 | 1h | 2019-11-08 08:00 | 2019-11-08 09:00 | start no earlier than 2019-11-08 08:00 |
| 21 | JT Move Status Meetings 20 | 1h | 2019-11-15 08:00 | 2019-11-15 09:00 | start no earlier than 2019-11-15 08:00 |
| 22 | JT Move Status Meetings 21 | 1h | 2019-11-22 08:00 | 2019-11-22 09:00 | start no earlier than 2019-11-22 08:00 |
| 23 | JT Move Status Meetings 22 | 1h | 2019-11-29 08:00 | 2019-11-29 09:00 | start no earlier than 2019-11-29 08:00 |
| 24 | JT Move Status Meetings 23 | 1h | 2019-12-06 08:00 | 2019-12-06 09:00 | start no earlier than 2019-12-06 08:00 |

Changed:

| ID | Task | Start | Finish | Duration | Total float | Other |
| --- | --- | --- | --- | --- | --- | --- |
| 1 | **JT Move Status Meetings** | 2019-07-05 → 2019-07-05 08:00 | 2019-07-19 → 2019-12-06 09:00 (+140d) | 10.12d → 110.12d | 97.38d → 0d | baseline start 2019-07-05 → 2019-07-05 08:00; baseline finish 2019-07-19 → 2019-12-06 09:00 |
| 2 | JT Move Status Meetings 1 | 2019-07-05 → 2019-07-05 08:00 | 2019-07-05 → 2019-07-05 09:00 |  | 107.38d → 110d | constraint start no earlier than 2019-07-05 → start no earlier than 2019-07-05 08:00; baseline start 2019-07-05 → 2019-07-05 08:00; baseline finish 2019-07-05 → 2019-07-05 09:00 |
| 3 | JT Move Status Meetings 2 | 2019-07-12 → 2019-07-12 08:00 | 2019-07-12 → 2019-07-12 09:00 |  | 102.38d → 105d | constraint start no earlier than 2019-07-12 → start no earlier than 2019-07-12 08:00; baseline start 2019-07-12 → 2019-07-12 08:00; baseline finish 2019-07-12 → 2019-07-12 09:00 |
| 4 | JT Move Status Meetings 3 | 2019-07-19 → 2019-07-19 08:00 | 2019-07-19 → 2019-07-19 09:00 |  | 97.38d → 100d | constraint start no earlier than 2019-07-19 → start no earlier than 2019-07-19 08:00; baseline start 2019-07-19 → 2019-07-19 08:00; baseline finish 2019-07-19 → 2019-07-19 09:00 |
| 25 | **Planning the Move** | 2019-07-01 → 2019-07-01 08:00 | 2019-09-09 → 2019-09-09 11:00 |  | 2.62d → 5.25d | baseline start 2019-07-01 → 2019-07-01 08:00; baseline finish 2019-09-09 → 2019-09-09 11:00 |
| 26 | Identify Move Team Members | 2019-07-01 → 2019-07-01 08:00 | 2019-07-02 → 2019-07-02 17:00 |  | 2.62d → 5.25d | baseline start 2019-07-01 → 2019-07-01 08:00; baseline finish 2019-07-02 → 2019-07-02 17:00 |
| 27 | Plan Infastructure Upgrades | 2019-07-03 → 2019-07-03 08:00 | 2019-07-17 → 2019-07-17 17:00 |  | 2.62d → 5.25d | baseline start 2019-07-03 → 2019-07-03 08:00; baseline finish 2019-07-17 → 2019-07-17 17:00 |
| 28 | Plan IT Move | 2019-07-18 → 2019-07-18 08:00 | 2019-07-31 → 2019-07-31 17:00 |  | 2.62d → 5.25d | baseline start 2019-07-18 → 2019-07-18 08:00; baseline finish 2019-07-31 → 2019-07-31 17:00 |
| 29 | Plan Physical Move | 2019-07-22 → 2019-07-22 13:00 | 2019-08-05 → 2019-08-05 12:00 |  | 2.62d → 5.25d | baseline start 2019-07-22 → 2019-07-22 13:00; baseline finish 2019-08-05 → 2019-08-05 12:00 |
| 30 | Plan for Continous Operations During the Move | 2019-08-05 → 2019-08-05 13:00 | 2019-08-09 → 2019-08-09 12:00 |  | 2.62d → 5.25d | baseline start 2019-08-05 → 2019-08-05 13:00; baseline finish 2019-08-09 → 2019-08-09 12:00 |
| 31 | Obtain Estimates from Moving Services | 2019-08-09 → 2019-08-09 13:00 | 2019-08-16 → 2019-08-16 12:00 |  | 2.62d → 5.25d | baseline start 2019-08-09 → 2019-08-09 13:00; baseline finish 2019-08-16 → 2019-08-16 12:00 |
| 32 | Interview and Select Movers | 2019-08-16 → 2019-08-16 13:00 | 2019-08-23 → 2019-08-23 12:00 |  | 2.62d → 5.25d | baseline start 2019-08-16 → 2019-08-16 13:00; baseline finish 2019-08-23 → 2019-08-23 12:00 |
| 33 | Obtain Estimates from IT Installation Companies | 2019-08-16 → 2019-08-16 13:00 | 2019-08-23 → 2019-08-23 12:00 |  | 2.62d → 5.25d | baseline start 2019-08-16 → 2019-08-16 13:00; baseline finish 2019-08-23 → 2019-08-23 12:00 |
| 34 | Interview and Select IT Installation Company | 2019-08-23 → 2019-08-23 13:00 | 2019-08-30 → 2019-08-30 12:00 |  | 2.62d → 5.25d | baseline start 2019-08-23 → 2019-08-23 13:00; baseline finish 2019-08-30 → 2019-08-30 12:00 |
| 35 | Order Boxes and Materials needed for the Move | 2019-08-30 → 2019-08-30 13:00 | 2019-08-30 → 2019-08-30 16:00 |  | 2.62d → 5.25d | baseline start 2019-08-30 → 2019-08-30 13:00; baseline finish 2019-08-30 → 2019-08-30 16:00 |
| 36 | Planning the Move Complete | 2019-08-30 → 2019-08-30 16:00 | 2019-08-30 → 2019-08-30 16:00 |  | 2.62d → 5.25d | baseline start 2019-08-30 → 2019-08-30 16:00; baseline finish 2019-08-30 → 2019-08-30 16:00 |
| 37 | **Communications** | 2019-08-30 → 2019-08-30 16:00 | 2019-09-09 → 2019-09-09 11:00 |  | 2.62d → 5.25d | baseline start 2019-08-30 → 2019-08-30 16:00; baseline finish 2019-09-09 → 2019-09-09 11:00 |
| 38 | Communicate Move Plan to Employees | 2019-08-30 → 2019-08-30 16:00 | 2019-09-04 → 2019-09-04 16:00 |  | 2.62d → 5.25d | baseline start 2019-08-30 → 2019-08-30 16:00; baseline finish 2019-09-04 → 2019-09-04 16:00 |
| 39 | Gather Feedback From Employees | 2019-09-04 → 2019-09-04 16:00 | 2019-09-06 → 2019-09-06 16:00 |  | 2.62d → 5.25d | baseline start 2019-09-04 → 2019-09-04 16:00; baseline finish 2019-09-06 → 2019-09-06 16:00 |
| 40 | Communicate Move Information to Suppliers | 2019-09-06 → 2019-09-06 16:00 | 2019-09-09 → 2019-09-09 09:00 |  | 2.62d → 5.25d | baseline start 2019-09-06 → 2019-09-06 16:00; baseline finish 2019-09-09 → 2019-09-09 09:00 |
| 41 | Communicate Move Information to Customers | 2019-09-09 → 2019-09-09 09:00 | 2019-09-09 → 2019-09-09 11:00 |  | 2.62d → 5.25d | baseline start 2019-09-09 → 2019-09-09 09:00; baseline finish 2019-09-09 → 2019-09-09 11:00 |
| 42 | Communications Complete | 2019-09-09 → 2019-09-09 11:00 | 2019-09-09 → 2019-09-09 11:00 |  | 2.62d → 5.25d | baseline start 2019-09-09 → 2019-09-09 11:00; baseline finish 2019-09-09 → 2019-09-09 11:00 |
| 43 | **JT Corporate Center Preparation** | 2019-09-09 → 2019-09-09 11:00 | 2019-10-11 → 2019-10-11 11:00 |  | 2.62d → 5.25d | baseline start 2019-09-09 → 2019-09-09 11:00; baseline finish 2019-10-11 → 2019-10-11 11:00 |
| 44 | **JT Call Center Refurbishing New Location** | 2019-09-09 → 2019-09-09 11:00 | 2019-10-09 → 2019-10-09 11:00 |  | 2.62d → 5.25d | baseline start 2019-09-09 → 2019-09-09 11:00; baseline finish 2019-10-09 → 2019-10-09 11:00 |
| 45 | Install Network Cables | 2019-09-09 → 2019-09-09 11:00 | 2019-09-12 → 2019-09-12 11:00 |  | 2.62d → 5.25d | baseline start 2019-09-09 → 2019-09-09 11:00; baseline finish 2019-09-12 → 2019-09-12 11:00 |
| 46 | Install TeleCommunication Lines | 2019-09-12 → 2019-09-12 11:00 | 2019-09-19 → 2019-09-19 11:00 |  | 4.62d → 7.25d | baseline start 2019-09-12 → 2019-09-12 11:00; baseline finish 2019-09-19 → 2019-09-19 11:00 |
| 47 | Paint the walls | 2019-09-19 → 2019-09-19 11:00 | 2019-09-23 → 2019-09-23 11:00 |  | 4.62d → 7.25d | baseline start 2019-09-19 → 2019-09-19 11:00; baseline finish 2019-09-23 → 2019-09-23 11:00 |
| 48 | Lay Carpet | 2019-09-24 → 2019-09-24 11:00 | 2019-09-26 → 2019-09-26 11:00 |  | 4.62d → 7.25d | baseline start 2019-09-24 → 2019-09-24 11:00; baseline finish 2019-09-26 → 2019-09-26 11:00 |
| 49 | Install Partitions | 2019-09-26 → 2019-09-26 11:00 | 2019-09-27 → 2019-09-27 11:00 |  | 4.62d → 7.25d | baseline start 2019-09-26 → 2019-09-26 11:00; baseline finish 2019-09-27 → 2019-09-27 11:00 |
| 50 | Prepare Offices | 2019-09-27 → 2019-09-27 11:00 | 2019-10-04 → 2019-10-04 11:00 |  | 4.62d → 7.25d | baseline start 2019-09-27 → 2019-09-27 11:00; baseline finish 2019-10-04 → 2019-10-04 11:00 |
| 51 | Assemble Furniture | 2019-10-04 → 2019-10-04 11:00 | 2019-10-08 → 2019-10-08 11:00 |  | 4.62d → 7.25d | baseline start 2019-10-04 → 2019-10-04 11:00; baseline finish 2019-10-08 → 2019-10-08 11:00 |
| 52 | Hook up Computers | 2019-10-08 → 2019-10-08 11:00 | 2019-10-09 → 2019-10-09 11:00 |  | 4.62d → 7.25d | baseline start 2019-10-08 → 2019-10-08 11:00; baseline finish 2019-10-09 → 2019-10-09 11:00 |
| 53 | Hook up Phones | 2019-10-08 → 2019-10-08 11:00 | 2019-10-09 → 2019-10-09 11:00 |  | 4.62d → 7.25d | baseline start 2019-10-08 → 2019-10-08 11:00; baseline finish 2019-10-09 → 2019-10-09 11:00 |
| 54 | JT Call Center Complete | 2019-10-09 → 2019-10-09 11:00 | 2019-10-09 → 2019-10-09 11:00 |  | 4.62d → 7.25d | baseline start 2019-10-09 → 2019-10-09 11:00; baseline finish 2019-10-09 → 2019-10-09 11:00 |
| 55 | **JT Internet Sales Center Refurbishing New Location** | 2019-09-09 → 2019-09-09 11:00 | 2019-10-11 → 2019-10-11 11:00 |  | 2.62d → 5.25d | baseline start 2019-09-09 → 2019-09-09 11:00; baseline finish 2019-10-11 → 2019-10-11 11:00 |
| 56 | Install Network Cables | 2019-09-09 → 2019-09-09 11:00 | 2019-09-12 → 2019-09-12 11:00 |  | 2.62d → 5.25d | baseline start 2019-09-09 → 2019-09-09 11:00; baseline finish 2019-09-12 → 2019-09-12 11:00 |
| 57 | Install TeleCommunication Lines | 2019-09-12 → 2019-09-12 11:00 | 2019-09-19 → 2019-09-19 11:00 |  | 2.62d → 5.25d | baseline start 2019-09-12 → 2019-09-12 11:00; baseline finish 2019-09-19 → 2019-09-19 11:00 |
| 58 | Paint the walls | 2019-09-19 → 2019-09-19 11:00 | 2019-09-23 → 2019-09-23 11:00 |  | 2.62d → 5.25d | baseline start 2019-09-19 → 2019-09-19 11:00; baseline finish 2019-09-23 → 2019-09-23 11:00 |
| 59 | Lay Carpet | 2019-09-24 → 2019-09-24 11:00 | 2019-09-26 → 2019-09-26 11:00 |  | 2.62d → 5.25d | baseline start 2019-09-24 → 2019-09-24 11:00; baseline finish 2019-09-26 → 2019-09-26 11:00 |
| 60 | Install Partitions | 2019-09-26 → 2019-09-26 11:00 | 2019-09-27 → 2019-09-27 11:00 |  | 2.62d → 5.25d | baseline start 2019-09-26 → 2019-09-26 11:00; baseline finish 2019-09-27 → 2019-09-27 11:00 |
| 61 | Prepare Offices | 2019-09-27 → 2019-09-27 11:00 | 2019-10-04 → 2019-10-04 11:00 |  | 2.62d → 5.25d | baseline start 2019-09-27 → 2019-09-27 11:00; baseline finish 2019-10-04 → 2019-10-04 11:00 |
| 62 | Assemble Furniture | 2019-10-04 → 2019-10-04 11:00 | 2019-10-08 → 2019-10-08 11:00 |  | 2.62d → 5.25d | baseline start 2019-10-04 → 2019-10-04 11:00; baseline finish 2019-10-08 → 2019-10-08 11:00 |
| 63 | Hook up Computers | 2019-10-08 → 2019-10-08 11:00 | 2019-10-09 → 2019-10-09 11:00 |  | 2.62d → 5.25d | baseline start 2019-10-08 → 2019-10-08 11:00; baseline finish 2019-10-09 → 2019-10-09 11:00 |
| 64 | Hook up Phones | 2019-10-08 → 2019-10-08 11:00 | 2019-10-09 → 2019-10-09 11:00 |  | 2.62d → 5.25d | baseline start 2019-10-08 → 2019-10-08 11:00; baseline finish 2019-10-09 → 2019-10-09 11:00 |
| 65 | Move in Belongings | 2019-10-09 → 2019-10-09 11:00 | 2019-10-11 → 2019-10-11 11:00 |  | 2.62d → 5.25d | baseline start 2019-10-09 → 2019-10-09 11:00; baseline finish 2019-10-11 → 2019-10-11 11:00 |
| 66 | JT Internet Sales Center Complete | 2019-10-11 → 2019-10-11 11:00 | 2019-10-11 → 2019-10-11 11:00 |  | 2.62d → 5.25d | baseline start 2019-10-11 → 2019-10-11 11:00; baseline finish 2019-10-11 → 2019-10-11 11:00 |
| 67 | **JT Administration Offices Refurbishing New Location** | 2019-09-09 → 2019-09-09 11:00 | 2019-10-11 → 2019-10-11 11:00 |  | 2.62d → 5.25d | baseline start 2019-09-09 → 2019-09-09 11:00; baseline finish 2019-10-11 → 2019-10-11 11:00 |
| 68 | Install Network Cables | 2019-09-09 → 2019-09-09 11:00 | 2019-09-12 → 2019-09-12 11:00 |  | 2.62d → 5.25d | baseline start 2019-09-09 → 2019-09-09 11:00; baseline finish 2019-09-12 → 2019-09-12 11:00 |
| 69 | Install TeleCommunication Lines | 2019-09-12 → 2019-09-12 11:00 | 2019-09-19 → 2019-09-19 11:00 |  | 2.62d → 5.25d | baseline start 2019-09-12 → 2019-09-12 11:00; baseline finish 2019-09-19 → 2019-09-19 11:00 |
| 70 | Paint the walls | 2019-09-19 → 2019-09-19 11:00 | 2019-09-23 → 2019-09-23 11:00 |  | 2.62d → 5.25d | baseline start 2019-09-19 → 2019-09-19 11:00; baseline finish 2019-09-23 → 2019-09-23 11:00 |
| 71 | Lay Carpet | 2019-09-24 → 2019-09-24 11:00 | 2019-09-26 → 2019-09-26 11:00 |  | 2.62d → 5.25d | baseline start 2019-09-24 → 2019-09-24 11:00; baseline finish 2019-09-26 → 2019-09-26 11:00 |
| 72 | Install Partitions | 2019-09-26 → 2019-09-26 11:00 | 2019-09-27 → 2019-09-27 11:00 |  | 2.62d → 5.25d | baseline start 2019-09-26 → 2019-09-26 11:00; baseline finish 2019-09-27 → 2019-09-27 11:00 |
| 73 | Prepare Offices | 2019-09-27 → 2019-09-27 11:00 | 2019-10-04 → 2019-10-04 11:00 |  | 2.62d → 5.25d | baseline start 2019-09-27 → 2019-09-27 11:00; baseline finish 2019-10-04 → 2019-10-04 11:00 |
| 74 | Assemble Furniture | 2019-10-04 → 2019-10-04 11:00 | 2019-10-08 → 2019-10-08 11:00 |  | 2.62d → 5.25d | baseline start 2019-10-04 → 2019-10-04 11:00; baseline finish 2019-10-08 → 2019-10-08 11:00 |
| 75 | Hook up Computers | 2019-10-08 → 2019-10-08 11:00 | 2019-10-09 → 2019-10-09 11:00 |  | 2.62d → 5.25d | baseline start 2019-10-08 → 2019-10-08 11:00; baseline finish 2019-10-09 → 2019-10-09 11:00 |
| 76 | Hook up Phones | 2019-10-08 → 2019-10-08 11:00 | 2019-10-09 → 2019-10-09 11:00 |  | 2.62d → 5.25d | baseline start 2019-10-08 → 2019-10-08 11:00; baseline finish 2019-10-09 → 2019-10-09 11:00 |
| 77 | Move in Belongings | 2019-10-09 → 2019-10-09 11:00 | 2019-10-11 → 2019-10-11 11:00 |  | 2.62d → 5.25d | baseline start 2019-10-09 → 2019-10-09 11:00; baseline finish 2019-10-11 → 2019-10-11 11:00 |
| 78 | JT Administrative Offices Complete | 2019-10-11 → 2019-10-11 11:00 | 2019-10-11 → 2019-10-11 11:00 |  | 2.62d → 5.25d | baseline start 2019-10-11 → 2019-10-11 11:00; baseline finish 2019-10-11 → 2019-10-11 11:00 |
| 79 | JT Offices Refurbishing Complete | 2019-10-11 → 2019-10-11 11:00 | 2019-10-11 → 2019-10-11 11:00 |  | 2.62d → 5.25d | baseline start 2019-10-11 → 2019-10-11 11:00; baseline finish 2019-10-11 → 2019-10-11 11:00 |
| 80 | **Moving** | 2019-10-16 → 2019-10-16 08:00 | 2019-11-29 → 2019-11-29 10:00 |  | 0d → 2.62d | baseline start 2019-10-16 → 2019-10-16 08:00; baseline finish 2019-11-29 → 2019-11-29 10:00 |
| 81 | **Packing** | 2019-10-16 → 2019-10-16 08:00 | 2019-11-20 → 2019-11-20 10:00 |  | 0d → 2.62d | baseline start 2019-10-16 → 2019-10-16 08:00; baseline finish 2019-11-20 → 2019-11-20 10:00 |
| 82 | Distribute Boxes to Employees | 2019-10-16 → 2019-10-16 08:00 | 2019-10-18 → 2019-10-18 17:00 |  | 0d → 2.62d | constraint start no earlier than 2019-10-16 → start no earlier than 2019-10-16 08:00; baseline start 2019-10-16 → 2019-10-16 08:00; baseline finish 2019-10-18 → 2019-10-18 17:00 |
| 83 | Communicate Timetable and Packing Requirements to Employees | 2019-10-21 → 2019-10-21 08:00 | 2019-10-21 → 2019-10-21 17:00 |  | 0d → 2.62d | baseline start 2019-10-21 → 2019-10-21 08:00; baseline finish 2019-10-21 → 2019-10-21 17:00 |
| 84 | Tag Furniture and Equipment to Identify New Area Staging | 2019-10-22 → 2019-10-22 08:00 | 2019-11-04 → 2019-11-04 17:00 |  | 0d → 2.62d | baseline start 2019-10-22 → 2019-10-22 08:00; baseline finish 2019-11-04 → 2019-11-04 17:00 |
| 85 | Tag Computer Equipment to Identify New Are Staging | 2019-11-05 → 2019-11-05 08:00 | 2019-11-18 → 2019-11-18 17:00 |  | 0d → 2.62d | baseline start 2019-11-05 → 2019-11-05 08:00; baseline finish 2019-11-18 → 2019-11-18 17:00 |
| 86 | Packing Complete | 2019-11-18 → 2019-11-18 17:00 | 2019-11-18 → 2019-11-18 17:00 |  | 0d → 2.62d | baseline start 2019-11-18 → 2019-11-18 17:00; baseline finish 2019-11-18 → 2019-11-18 17:00 |
| 87 | **Final Moving Preperations** | 2019-11-19 → 2019-11-19 08:00 | 2019-11-20 → 2019-11-20 10:00 |  | 0d → 2.62d | baseline start 2019-11-19 → 2019-11-19 08:00; baseline finish 2019-11-20 → 2019-11-20 10:00 |
| 88 | Communicate Rotation Schedule to Insure Continous Operations | 2019-11-19 → 2019-11-19 08:00 | 2019-11-19 → 2019-11-19 11:00 |  | 0d → 2.62d | baseline start 2019-11-19 → 2019-11-19 08:00; baseline finish 2019-11-19 → 2019-11-19 11:00 |
| 89 | Walk-through to Double Chjeck Tagging of All Furniture and Equipment | 2019-11-19 → 2019-11-19 11:00 | 2019-11-19 → 2019-11-19 14:00 |  | 0d → 2.62d | baseline start 2019-11-19 → 2019-11-19 11:00; baseline finish 2019-11-19 → 2019-11-19 14:00 |
| 90 | Review Move Schedule with Team Leaders | 2019-11-19 → 2019-11-19 14:00 | 2019-11-19 → 2019-11-19 17:00 |  | 0d → 2.62d | baseline start 2019-11-19 → 2019-11-19 14:00; baseline finish 2019-11-19 → 2019-11-19 17:00 |

| ID | Task | Start | Finish | Total float | Other |
| --- | --- | --- | --- | --- | --- |
| 91 | Review Move Schedule with Movers | 2019-11-20 → 2019-11-20 08:00 | 2019-11-20 → 2019-11-20 10:00 | 0d → 2.62d | baseline start 2019-11-20 → 2019-11-20 08:00; baseline finish 2019-11-20 → 2019-11-20 10:00 |
| 92 | Final Moving Preperations Complete | 2019-11-20 → 2019-11-20 10:00 | 2019-11-20 → 2019-11-20 10:00 | 0d → 2.62d | baseline start 2019-11-20 → 2019-11-20 10:00; baseline finish 2019-11-20 → 2019-11-20 10:00 |
| 93 | **Move Furniture and Equipment** | 2019-11-20 → 2019-11-20 10:00 | 2019-11-29 → 2019-11-29 10:00 | 0d → 2.62d | baseline start 2019-11-20 → 2019-11-20 10:00; baseline finish 2019-11-29 → 2019-11-29 10:00 |
| 94 | Move JT Administrative Offices | 2019-11-20 → 2019-11-20 10:00 | 2019-11-22 → 2019-11-22 10:00 | 0d → 2.62d | baseline start 2019-11-20 → 2019-11-20 10:00; baseline finish 2019-11-22 → 2019-11-22 10:00 |
| 95 | Move First Wave JT Call Center | 2019-11-22 → 2019-11-22 10:00 | 2019-11-25 → 2019-11-25 10:00 | 0d → 2.62d | baseline start 2019-11-22 → 2019-11-22 10:00; baseline finish 2019-11-25 → 2019-11-25 10:00 |
| 96 | Move First Wave JT Internet Sales Center | 2019-11-25 → 2019-11-25 10:00 | 2019-11-26 → 2019-11-26 10:00 | 0d → 2.62d | baseline start 2019-11-25 → 2019-11-25 10:00; baseline finish 2019-11-26 → 2019-11-26 10:00 |
| 97 | Setup New JT Call Center for Operations | 2019-11-26 → 2019-11-26 10:00 | 2019-11-26 → 2019-11-26 15:00 | 0d → 2.62d | baseline start 2019-11-26 → 2019-11-26 10:00; baseline finish 2019-11-26 → 2019-11-26 15:00 |
| 98 | Setup New JT Internet Sales Center for Operations | 2019-11-26 → 2019-11-26 15:00 | 2019-11-27 → 2019-11-27 10:00 | 0d → 2.62d | baseline start 2019-11-26 → 2019-11-26 15:00; baseline finish 2019-11-27 → 2019-11-27 10:00 |
| 99 | New JT Call Center Operational | 2019-11-27 → 2019-11-27 10:00 | 2019-11-27 → 2019-11-27 10:00 | 0d → 2.62d | baseline start 2019-11-27 → 2019-11-27 10:00; baseline finish 2019-11-27 → 2019-11-27 10:00 |
| 100 | New JT Internet Sales Center Operational | 2019-11-27 → 2019-11-27 10:00 | 2019-11-27 → 2019-11-27 10:00 | 0d → 2.62d | baseline start 2019-11-27 → 2019-11-27 10:00; baseline finish 2019-11-27 → 2019-11-27 10:00 |
| 101 | Move Final Group JT Call Center | 2019-11-27 → 2019-11-27 10:00 | 2019-11-28 → 2019-11-28 10:00 | 0d → 2.62d | baseline start 2019-11-27 → 2019-11-27 10:00; baseline finish 2019-11-28 → 2019-11-28 10:00 |
| 102 | Move Final Group JT Internet Sales Center | 2019-11-28 → 2019-11-28 10:00 | 2019-11-29 → 2019-11-29 10:00 | 0d → 2.62d | baseline start 2019-11-28 → 2019-11-28 10:00; baseline finish 2019-11-29 → 2019-11-29 10:00 |
| 103 | Move Furniture and Equipment Complete | 2019-11-29 → 2019-11-29 10:00 | 2019-11-29 → 2019-11-29 10:00 | 0d → 2.62d | baseline start 2019-11-29 → 2019-11-29 10:00; baseline finish 2019-11-29 → 2019-11-29 10:00 |
| 104 | Move Complete | 2019-11-29 → 2019-11-29 10:00 | 2019-11-29 → 2019-11-29 10:00 | 0d → 2.62d | baseline start 2019-11-29 → 2019-11-29 10:00; baseline finish 2019-11-29 → 2019-11-29 10:00 |
| 105 | **JT Corporate Move Closeout** | 2019-11-29 → 2019-11-29 10:00 | 2019-12-03 → 2019-12-03 12:00 | 0d → 2.62d | baseline start 2019-11-29 → 2019-11-29 10:00; baseline finish 2019-12-03 → 2019-12-03 12:00 |
| 106 | Unpacking all areas | 2019-11-29 → 2019-11-29 10:00 | 2019-12-03 → 2019-12-03 10:00 | 0d → 2.62d | baseline start 2019-11-29 → 2019-11-29 10:00; baseline finish 2019-12-03 → 2019-12-03 10:00 |
| 107 | Company-Wide Meeting | 2019-12-03 → 2019-12-03 10:00 | 2019-12-03 → 2019-12-03 12:00 | 0d → 2.62d | baseline start 2019-12-03 → 2019-12-03 10:00; baseline finish 2019-12-03 → 2019-12-03 12:00 |
| 108 | Move Evaluation | 2019-12-02 → 2019-12-02 15:00 | 2019-12-03 → 2019-12-03 10:00 | 0.12d → 2.62d | baseline start 2019-12-02 → 2019-12-02 15:00; baseline finish 2019-12-03 → 2019-12-03 10:00 |
| 109 | Pay Movers | 2019-12-03 → 2019-12-03 10:00 | 2019-12-03 → 2019-12-03 11:00 | 0.12d → 2.62d | baseline start 2019-12-03 → 2019-12-03 10:00; baseline finish 2019-12-03 → 2019-12-03 11:00 |
| 110 | JT Corporate Move Closeout Complete | 2019-12-03 → 2019-12-03 11:00 | 2019-12-03 → 2019-12-03 11:00 | 0.12d → 2.62d | baseline start 2019-12-03 → 2019-12-03 11:00; baseline finish 2019-12-03 → 2019-12-03 11:00 |
| 111 | JT Corporate Move Complete | 2019-12-03 → 2019-12-03 11:00 | 2019-12-03 → 2019-12-03 11:00 | 0.12d → 2.62d | constraint finish no later than 2019-12-05 → finish no later than 2019-12-05 17:00; baseline start 2019-12-03 → 2019-12-03 11:00; baseline finish 2019-12-03 → 2019-12-03 11:00 |

## Version 5 (saved 2019-05-31, file JT Corporate Move Updating Tasks Actual Start and Finish.mpp)

Last finish stays 2019-12-06. Complete tasks 0 → 5.

Changed:

| ID | Task | Start | Finish | Duration | Complete | Total float | Other |
| --- | --- | --- | --- | --- | --- | --- | --- |
| 25 | **Planning the Move** | 2019-07-01 08:00 → 2019-07-02 08:00 A (+1d) | 2019-09-09 11:00 → 2019-09-09 16:00 | 49.38d → 48.88d | 0% → 64% | 5.25d → 4.75d | baseline start 2019-07-01 08:00 → 2019-07-02 08:00; baseline finish 2019-09-09 11:00 → 2019-09-09 16:00 |
| 26 | Identify Move Team Members | 2019-07-01 08:00 → 2019-07-02 08:00 A (+1d) | 2019-07-02 17:00 → 2019-07-03 17:00 A (+1d) |  | 0% → 100% | 5.25d → none | baseline start 2019-07-01 08:00 → 2019-07-02 08:00; baseline finish 2019-07-02 17:00 → 2019-07-03 17:00 |
| 27 | Plan Infastructure Upgrades | 2019-07-03 08:00 → 2019-07-05 08:00 A (+2d) | 2019-07-17 17:00 → 2019-07-18 17:00 A (+1d) |  | 0% → 100% | 5.25d → none | baseline start 2019-07-03 08:00 → 2019-07-05 08:00; baseline finish 2019-07-17 17:00 → 2019-07-18 17:00 |
| 28 | Plan IT Move | 2019-07-18 08:00 → 2019-07-19 08:00 A (+1d) | 2019-07-31 17:00 → 2019-08-01 17:00 A (+1d) |  | 0% → 100% | 5.25d → none | baseline start 2019-07-18 08:00 → 2019-07-19 08:00; baseline finish 2019-07-31 17:00 → 2019-08-01 17:00 |
| 29 | Plan Physical Move | 2019-07-22 13:00 → 2019-07-23 13:00 A (+1d) | 2019-08-05 12:00 → 2019-08-06 12:00 A (+1d) |  | 0% → 100% | 5.25d → none | baseline start 2019-07-22 13:00 → 2019-07-23 13:00; baseline finish 2019-08-05 12:00 → 2019-08-06 12:00 |
| 30 | Plan for Continous Operations During the Move | 2019-08-05 13:00 → 2019-08-06 13:00 A (+1d) | 2019-08-09 12:00 → 2019-08-12 12:00 A (+3d) |  | 0% → 100% | 5.25d → none | baseline start 2019-08-05 13:00 → 2019-08-06 13:00; baseline finish 2019-08-09 12:00 → 2019-08-12 12:00 |
| 31 | Obtain Estimates from Moving Services | 2019-08-09 13:00 → 2019-08-12 08:00 A (+3d) | 2019-08-16 12:00 → 2019-08-16 17:00 |  | 0% → 75% | 5.25d → 4.75d | baseline start 2019-08-09 13:00 → 2019-08-12 08:00; baseline finish 2019-08-16 12:00 → 2019-08-16 17:00 |
| 32 | Interview and Select Movers | 2019-08-16 13:00 → 2019-08-19 08:00 (+3d) | 2019-08-23 12:00 → 2019-08-23 17:00 |  |  | 5.25d → 4.75d | baseline start 2019-08-16 13:00 → 2019-08-19 08:00; baseline finish 2019-08-23 12:00 → 2019-08-23 17:00 |
| 33 | Obtain Estimates from IT Installation Companies | 2019-08-16 13:00 → 2019-08-19 08:00 (+3d) | 2019-08-23 12:00 → 2019-08-23 17:00 |  |  | 5.25d → 4.75d | baseline start 2019-08-16 13:00 → 2019-08-19 08:00; baseline finish 2019-08-23 12:00 → 2019-08-23 17:00 |
| 34 | Interview and Select IT Installation Company | 2019-08-23 13:00 → 2019-08-26 08:00 (+3d) | 2019-08-30 12:00 → 2019-08-30 17:00 |  |  | 5.25d → 4.75d | baseline start 2019-08-23 13:00 → 2019-08-26 08:00; baseline finish 2019-08-30 12:00 → 2019-08-30 17:00 |
| 35 | Order Boxes and Materials needed for the Move | 2019-08-30 13:00 → 2019-09-02 08:00 (+3d) | 2019-08-30 16:00 → 2019-09-02 11:00 (+3d) |  |  | 5.25d → 4.75d | baseline start 2019-08-30 13:00 → 2019-09-02 08:00; baseline finish 2019-08-30 16:00 → 2019-09-02 11:00 |
| 36 | Planning the Move Complete | 2019-08-30 16:00 → 2019-09-02 11:00 (+3d) | 2019-08-30 16:00 → 2019-09-02 11:00 (+3d) |  |  | 5.25d → 4.75d | baseline start 2019-08-30 16:00 → 2019-09-02 11:00; baseline finish 2019-08-30 16:00 → 2019-09-02 11:00 |
| 37 | **Communications** | 2019-08-30 16:00 → 2019-09-02 11:00 (+3d) | 2019-09-09 11:00 → 2019-09-09 16:00 |  |  | 5.25d → 4.75d | baseline start 2019-08-30 16:00 → 2019-09-02 11:00; baseline finish 2019-09-09 11:00 → 2019-09-09 16:00 |
| 38 | Communicate Move Plan to Employees | 2019-08-30 16:00 → 2019-09-02 11:00 (+3d) | 2019-09-04 16:00 → 2019-09-05 11:00 (+1d) |  |  | 5.25d → 4.75d | baseline start 2019-08-30 16:00 → 2019-09-02 11:00; baseline finish 2019-09-04 16:00 → 2019-09-05 11:00 |
| 39 | Gather Feedback From Employees | 2019-09-04 16:00 → 2019-09-05 11:00 (+1d) | 2019-09-06 16:00 → 2019-09-09 11:00 (+3d) |  |  | 5.25d → 4.75d | baseline start 2019-09-04 16:00 → 2019-09-05 11:00; baseline finish 2019-09-06 16:00 → 2019-09-09 11:00 |
| 40 | Communicate Move Information to Suppliers | 2019-09-06 16:00 → 2019-09-09 11:00 (+3d) | 2019-09-09 09:00 → 2019-09-09 14:00 |  |  | 5.25d → 4.75d | baseline start 2019-09-06 16:00 → 2019-09-09 11:00; baseline finish 2019-09-09 09:00 → 2019-09-09 14:00 |
| 41 | Communicate Move Information to Customers | 2019-09-09 09:00 → 2019-09-09 14:00 | 2019-09-09 11:00 → 2019-09-09 16:00 |  |  | 5.25d → 4.75d | baseline start 2019-09-09 09:00 → 2019-09-09 14:00; baseline finish 2019-09-09 11:00 → 2019-09-09 16:00 |
| 42 | Communications Complete | 2019-09-09 11:00 → 2019-09-09 16:00 | 2019-09-09 11:00 → 2019-09-09 16:00 |  |  | 5.25d → 4.75d | baseline start 2019-09-09 11:00 → 2019-09-09 16:00; baseline finish 2019-09-09 11:00 → 2019-09-09 16:00 |
| 43 | **JT Corporate Center Preparation** | 2019-09-09 11:00 → 2019-09-09 16:00 | 2019-10-11 11:00 → 2019-10-11 16:00 |  |  | 5.25d → 4.75d | baseline start 2019-09-09 11:00 → 2019-09-09 16:00; baseline finish 2019-10-11 11:00 → 2019-10-11 16:00 |
| 44 | **JT Call Center Refurbishing New Location** | 2019-09-09 11:00 → 2019-09-09 16:00 | 2019-10-09 11:00 → 2019-10-09 16:00 |  |  | 5.25d → 4.75d | baseline start 2019-09-09 11:00 → 2019-09-09 16:00; baseline finish 2019-10-09 11:00 → 2019-10-09 16:00 |
| 45 | Install Network Cables | 2019-09-09 11:00 → 2019-09-09 16:00 | 2019-09-12 11:00 → 2019-09-12 16:00 |  |  | 5.25d → 4.75d | baseline start 2019-09-09 11:00 → 2019-09-09 16:00; baseline finish 2019-09-12 11:00 → 2019-09-12 16:00 |
| 46 | Install TeleCommunication Lines | 2019-09-12 11:00 → 2019-09-12 16:00 | 2019-09-19 11:00 → 2019-09-19 16:00 |  |  | 7.25d → 6.75d | baseline start 2019-09-12 11:00 → 2019-09-12 16:00; baseline finish 2019-09-19 11:00 → 2019-09-19 16:00 |
| 47 | Paint the walls | 2019-09-19 11:00 → 2019-09-19 16:00 | 2019-09-23 11:00 → 2019-09-23 16:00 |  |  | 7.25d → 6.75d | baseline start 2019-09-19 11:00 → 2019-09-19 16:00; baseline finish 2019-09-23 11:00 → 2019-09-23 16:00 |
| 48 | Lay Carpet | 2019-09-24 11:00 → 2019-09-24 16:00 | 2019-09-26 11:00 → 2019-09-26 16:00 |  |  | 7.25d → 6.75d | baseline start 2019-09-24 11:00 → 2019-09-24 16:00; baseline finish 2019-09-26 11:00 → 2019-09-26 16:00 |
| 49 | Install Partitions | 2019-09-26 11:00 → 2019-09-26 16:00 | 2019-09-27 11:00 → 2019-09-27 16:00 |  |  | 7.25d → 6.75d | baseline start 2019-09-26 11:00 → 2019-09-26 16:00; baseline finish 2019-09-27 11:00 → 2019-09-27 16:00 |
| 50 | Prepare Offices | 2019-09-27 11:00 → 2019-09-27 16:00 | 2019-10-04 11:00 → 2019-10-04 16:00 |  |  | 7.25d → 6.75d | baseline start 2019-09-27 11:00 → 2019-09-27 16:00; baseline finish 2019-10-04 11:00 → 2019-10-04 16:00 |
| 51 | Assemble Furniture | 2019-10-04 11:00 → 2019-10-04 16:00 | 2019-10-08 11:00 → 2019-10-08 16:00 |  |  | 7.25d → 6.75d | baseline start 2019-10-04 11:00 → 2019-10-04 16:00; baseline finish 2019-10-08 11:00 → 2019-10-08 16:00 |
| 52 | Hook up Computers | 2019-10-08 11:00 → 2019-10-08 16:00 | 2019-10-09 11:00 → 2019-10-09 16:00 |  |  | 7.25d → 6.75d | baseline start 2019-10-08 11:00 → 2019-10-08 16:00; baseline finish 2019-10-09 11:00 → 2019-10-09 16:00 |
| 53 | Hook up Phones | 2019-10-08 11:00 → 2019-10-08 16:00 | 2019-10-09 11:00 → 2019-10-09 16:00 |  |  | 7.25d → 6.75d | baseline start 2019-10-08 11:00 → 2019-10-08 16:00; baseline finish 2019-10-09 11:00 → 2019-10-09 16:00 |
| 54 | JT Call Center Complete | 2019-10-09 11:00 → 2019-10-09 16:00 | 2019-10-09 11:00 → 2019-10-09 16:00 |  |  | 7.25d → 6.75d | baseline start 2019-10-09 11:00 → 2019-10-09 16:00; baseline finish 2019-10-09 11:00 → 2019-10-09 16:00 |
| 55 | **JT Internet Sales Center Refurbishing New Location** | 2019-09-09 11:00 → 2019-09-09 16:00 | 2019-10-11 11:00 → 2019-10-11 16:00 |  |  | 5.25d → 4.75d | baseline start 2019-09-09 11:00 → 2019-09-09 16:00; baseline finish 2019-10-11 11:00 → 2019-10-11 16:00 |
| 56 | Install Network Cables | 2019-09-09 11:00 → 2019-09-09 16:00 | 2019-09-12 11:00 → 2019-09-12 16:00 |  |  | 5.25d → 4.75d | baseline start 2019-09-09 11:00 → 2019-09-09 16:00; baseline finish 2019-09-12 11:00 → 2019-09-12 16:00 |
| 57 | Install TeleCommunication Lines | 2019-09-12 11:00 → 2019-09-12 16:00 | 2019-09-19 11:00 → 2019-09-19 16:00 |  |  | 5.25d → 4.75d | baseline start 2019-09-12 11:00 → 2019-09-12 16:00; baseline finish 2019-09-19 11:00 → 2019-09-19 16:00 |
| 58 | Paint the walls | 2019-09-19 11:00 → 2019-09-19 16:00 | 2019-09-23 11:00 → 2019-09-23 16:00 |  |  | 5.25d → 4.75d | baseline start 2019-09-19 11:00 → 2019-09-19 16:00; baseline finish 2019-09-23 11:00 → 2019-09-23 16:00 |
| 59 | Lay Carpet | 2019-09-24 11:00 → 2019-09-24 16:00 | 2019-09-26 11:00 → 2019-09-26 16:00 |  |  | 5.25d → 4.75d | baseline start 2019-09-24 11:00 → 2019-09-24 16:00; baseline finish 2019-09-26 11:00 → 2019-09-26 16:00 |
| 60 | Install Partitions | 2019-09-26 11:00 → 2019-09-26 16:00 | 2019-09-27 11:00 → 2019-09-27 16:00 |  |  | 5.25d → 4.75d | baseline start 2019-09-26 11:00 → 2019-09-26 16:00; baseline finish 2019-09-27 11:00 → 2019-09-27 16:00 |
| 61 | Prepare Offices | 2019-09-27 11:00 → 2019-09-27 16:00 | 2019-10-04 11:00 → 2019-10-04 16:00 |  |  | 5.25d → 4.75d | baseline start 2019-09-27 11:00 → 2019-09-27 16:00; baseline finish 2019-10-04 11:00 → 2019-10-04 16:00 |
| 62 | Assemble Furniture | 2019-10-04 11:00 → 2019-10-04 16:00 | 2019-10-08 11:00 → 2019-10-08 16:00 |  |  | 5.25d → 4.75d | baseline start 2019-10-04 11:00 → 2019-10-04 16:00; baseline finish 2019-10-08 11:00 → 2019-10-08 16:00 |
| 63 | Hook up Computers | 2019-10-08 11:00 → 2019-10-08 16:00 | 2019-10-09 11:00 → 2019-10-09 16:00 |  |  | 5.25d → 4.75d | baseline start 2019-10-08 11:00 → 2019-10-08 16:00; baseline finish 2019-10-09 11:00 → 2019-10-09 16:00 |
| 64 | Hook up Phones | 2019-10-08 11:00 → 2019-10-08 16:00 | 2019-10-09 11:00 → 2019-10-09 16:00 |  |  | 5.25d → 4.75d | baseline start 2019-10-08 11:00 → 2019-10-08 16:00; baseline finish 2019-10-09 11:00 → 2019-10-09 16:00 |
| 65 | Move in Belongings | 2019-10-09 11:00 → 2019-10-09 16:00 | 2019-10-11 11:00 → 2019-10-11 16:00 |  |  | 5.25d → 4.75d | baseline start 2019-10-09 11:00 → 2019-10-09 16:00; baseline finish 2019-10-11 11:00 → 2019-10-11 16:00 |
| 66 | JT Internet Sales Center Complete | 2019-10-11 11:00 → 2019-10-11 16:00 | 2019-10-11 11:00 → 2019-10-11 16:00 |  |  | 5.25d → 4.75d | baseline start 2019-10-11 11:00 → 2019-10-11 16:00; baseline finish 2019-10-11 11:00 → 2019-10-11 16:00 |
| 67 | **JT Administration Offices Refurbishing New Location** | 2019-09-09 11:00 → 2019-09-09 16:00 | 2019-10-11 11:00 → 2019-10-11 16:00 |  |  | 5.25d → 4.75d | baseline start 2019-09-09 11:00 → 2019-09-09 16:00; baseline finish 2019-10-11 11:00 → 2019-10-11 16:00 |
| 68 | Install Network Cables | 2019-09-09 11:00 → 2019-09-09 16:00 | 2019-09-12 11:00 → 2019-09-12 16:00 |  |  | 5.25d → 4.75d | baseline start 2019-09-09 11:00 → 2019-09-09 16:00; baseline finish 2019-09-12 11:00 → 2019-09-12 16:00 |
| 69 | Install TeleCommunication Lines | 2019-09-12 11:00 → 2019-09-12 16:00 | 2019-09-19 11:00 → 2019-09-19 16:00 |  |  | 5.25d → 4.75d | baseline start 2019-09-12 11:00 → 2019-09-12 16:00; baseline finish 2019-09-19 11:00 → 2019-09-19 16:00 |
| 70 | Paint the walls | 2019-09-19 11:00 → 2019-09-19 16:00 | 2019-09-23 11:00 → 2019-09-23 16:00 |  |  | 5.25d → 4.75d | baseline start 2019-09-19 11:00 → 2019-09-19 16:00; baseline finish 2019-09-23 11:00 → 2019-09-23 16:00 |
| 71 | Lay Carpet | 2019-09-24 11:00 → 2019-09-24 16:00 | 2019-09-26 11:00 → 2019-09-26 16:00 |  |  | 5.25d → 4.75d | baseline start 2019-09-24 11:00 → 2019-09-24 16:00; baseline finish 2019-09-26 11:00 → 2019-09-26 16:00 |
| 72 | Install Partitions | 2019-09-26 11:00 → 2019-09-26 16:00 | 2019-09-27 11:00 → 2019-09-27 16:00 |  |  | 5.25d → 4.75d | baseline start 2019-09-26 11:00 → 2019-09-26 16:00; baseline finish 2019-09-27 11:00 → 2019-09-27 16:00 |
| 73 | Prepare Offices | 2019-09-27 11:00 → 2019-09-27 16:00 | 2019-10-04 11:00 → 2019-10-04 16:00 |  |  | 5.25d → 4.75d | baseline start 2019-09-27 11:00 → 2019-09-27 16:00; baseline finish 2019-10-04 11:00 → 2019-10-04 16:00 |
| 74 | Assemble Furniture | 2019-10-04 11:00 → 2019-10-04 16:00 | 2019-10-08 11:00 → 2019-10-08 16:00 |  |  | 5.25d → 4.75d | baseline start 2019-10-04 11:00 → 2019-10-04 16:00; baseline finish 2019-10-08 11:00 → 2019-10-08 16:00 |
| 75 | Hook up Computers | 2019-10-08 11:00 → 2019-10-08 16:00 | 2019-10-09 11:00 → 2019-10-09 16:00 |  |  | 5.25d → 4.75d | baseline start 2019-10-08 11:00 → 2019-10-08 16:00; baseline finish 2019-10-09 11:00 → 2019-10-09 16:00 |
| 76 | Hook up Phones | 2019-10-08 11:00 → 2019-10-08 16:00 | 2019-10-09 11:00 → 2019-10-09 16:00 |  |  | 5.25d → 4.75d | baseline start 2019-10-08 11:00 → 2019-10-08 16:00; baseline finish 2019-10-09 11:00 → 2019-10-09 16:00 |
| 77 | Move in Belongings | 2019-10-09 11:00 → 2019-10-09 16:00 | 2019-10-11 11:00 → 2019-10-11 16:00 |  |  | 5.25d → 4.75d | baseline start 2019-10-09 11:00 → 2019-10-09 16:00; baseline finish 2019-10-11 11:00 → 2019-10-11 16:00 |
| 78 | JT Administrative Offices Complete | 2019-10-11 11:00 → 2019-10-11 16:00 | 2019-10-11 11:00 → 2019-10-11 16:00 |  |  | 5.25d → 4.75d | baseline start 2019-10-11 11:00 → 2019-10-11 16:00; baseline finish 2019-10-11 11:00 → 2019-10-11 16:00 |
| 79 | JT Offices Refurbishing Complete | 2019-10-11 11:00 → 2019-10-11 16:00 | 2019-10-11 11:00 → 2019-10-11 16:00 |  |  | 5.25d → 4.75d | baseline start 2019-10-11 11:00 → 2019-10-11 16:00; baseline finish 2019-10-11 11:00 → 2019-10-11 16:00 |

## Version 6 (saved 2019-05-31, file JT Corporate Move Updating Tasks Splitting a Task.mpp)

Last finish stays 2019-12-06. Complete tasks 5 → 11.

Changed:

| ID | Task | Start | Finish | Duration | Complete | Total float | Other |
| --- | --- | --- | --- | --- | --- | --- | --- |
| 25 | **Planning the Move** |  | 2019-09-09 16:00 → 2019-09-09 12:00 | 48.88d → 48.5d | 64% → 91% | 4.75d → 5.12d | baseline finish 2019-09-09 16:00 → 2019-09-09 12:00 |
| 31 | Obtain Estimates from Moving Services |  | 2019-08-16 17:00 A |  | 75% → 100% | 4.75d → none |  |
| 32 | Interview and Select Movers | 2019-08-19 08:00 → 2019-08-15 08:00 A (-4d) | 2019-08-23 17:00 → 2019-08-26 12:00 A (+3d) | 1w → 1.5w | 0% → 100% | 4.75d → none | baseline start 2019-08-19 08:00 → 2019-08-15 08:00; baseline finish 2019-08-23 17:00 → 2019-08-26 12:00 |
| 33 | Obtain Estimates from IT Installation Companies | 2019-08-19 08:00 A | 2019-08-23 17:00 A |  | 0% → 100% | 4.75d → none |  |
| 34 | Interview and Select IT Installation Company | 2019-08-26 08:00 A | 2019-08-30 17:00 A |  | 0% → 100% | 4.75d → none |  |
| 35 | Order Boxes and Materials needed for the Move | 2019-09-02 08:00 A | 2019-09-02 11:00 A |  | 0% → 100% | 4.75d → none |  |
| 36 | Planning the Move Complete | 2019-09-02 11:00 → 2019-09-02 08:00 A | 2019-09-02 11:00 → 2019-09-02 08:00 A |  | 0% → 100% | 4.75d → none | baseline start 2019-09-02 11:00 → 2019-09-02 08:00; baseline finish 2019-09-02 11:00 → 2019-09-02 08:00 |
| 37 | **Communications** | 2019-09-02 11:00 → 2019-09-02 08:00 | 2019-09-09 16:00 → 2019-09-09 12:00 |  |  | 4.75d → 5.12d | baseline start 2019-09-02 11:00 → 2019-09-02 08:00; baseline finish 2019-09-09 16:00 → 2019-09-09 12:00 |
| 38 | Communicate Move Plan to Employees | 2019-09-02 11:00 → 2019-09-02 08:00 | 2019-09-05 11:00 → 2019-09-04 17:00 (-1d) |  |  | 4.75d → 5.12d | baseline start 2019-09-02 11:00 → 2019-09-02 08:00; baseline finish 2019-09-05 11:00 → 2019-09-04 17:00 |
| 39 | Gather Feedback From Employees | 2019-09-05 11:00 → 2019-09-05 08:00 | 2019-09-09 11:00 → 2019-09-06 17:00 (-3d) |  |  | 4.75d → 5.12d | baseline start 2019-09-05 11:00 → 2019-09-05 08:00; baseline finish 2019-09-09 11:00 → 2019-09-06 17:00 |
| 40 | Communicate Move Information to Suppliers | 2019-09-09 11:00 → 2019-09-09 08:00 | 2019-09-09 14:00 → 2019-09-09 10:00 |  |  | 4.75d → 5.12d | baseline start 2019-09-09 11:00 → 2019-09-09 08:00; baseline finish 2019-09-09 14:00 → 2019-09-09 10:00 |
| 41 | Communicate Move Information to Customers | 2019-09-09 14:00 → 2019-09-09 10:00 | 2019-09-09 16:00 → 2019-09-09 12:00 |  |  | 4.75d → 5.12d | baseline start 2019-09-09 14:00 → 2019-09-09 10:00; baseline finish 2019-09-09 16:00 → 2019-09-09 12:00 |
| 42 | Communications Complete | 2019-09-09 16:00 → 2019-09-09 12:00 | 2019-09-09 16:00 → 2019-09-09 12:00 |  |  | 4.75d → 5.12d | baseline start 2019-09-09 16:00 → 2019-09-09 12:00; baseline finish 2019-09-09 16:00 → 2019-09-09 12:00 |
| 43 | **JT Corporate Center Preparation** | 2019-09-09 16:00 → 2019-09-09 13:00 | 2019-10-11 16:00 → 2019-10-11 12:00 |  |  | 4.75d → 5.12d | baseline start 2019-09-09 16:00 → 2019-09-09 13:00; baseline finish 2019-10-11 16:00 → 2019-10-11 12:00 |
| 44 | **JT Call Center Refurbishing New Location** | 2019-09-09 16:00 → 2019-09-09 13:00 | 2019-10-09 16:00 → 2019-10-09 12:00 |  |  | 4.75d → 5.12d | baseline start 2019-09-09 16:00 → 2019-09-09 13:00; baseline finish 2019-10-09 16:00 → 2019-10-09 12:00 |
| 45 | Install Network Cables | 2019-09-09 16:00 → 2019-09-09 13:00 | 2019-09-12 16:00 → 2019-09-12 12:00 |  |  | 4.75d → 5.12d | baseline start 2019-09-09 16:00 → 2019-09-09 13:00; baseline finish 2019-09-12 16:00 → 2019-09-12 12:00 |
| 46 | Install TeleCommunication Lines | 2019-09-12 16:00 → 2019-09-12 13:00 | 2019-09-19 16:00 → 2019-09-19 12:00 |  |  | 6.75d → 7.12d | baseline start 2019-09-12 16:00 → 2019-09-12 13:00; baseline finish 2019-09-19 16:00 → 2019-09-19 12:00 |
| 47 | Paint the walls | 2019-09-19 16:00 → 2019-09-19 13:00 | 2019-09-23 16:00 → 2019-09-23 12:00 |  |  | 6.75d → 7.12d | baseline start 2019-09-19 16:00 → 2019-09-19 13:00; baseline finish 2019-09-23 16:00 → 2019-09-23 12:00 |
| 48 | Lay Carpet | 2019-09-24 16:00 → 2019-09-24 13:00 | 2019-09-26 16:00 → 2019-09-26 12:00 |  |  | 6.75d → 7.12d | baseline start 2019-09-24 16:00 → 2019-09-24 13:00; baseline finish 2019-09-26 16:00 → 2019-09-26 12:00 |
| 49 | Install Partitions | 2019-09-26 16:00 → 2019-09-26 13:00 | 2019-09-27 16:00 → 2019-09-27 12:00 |  |  | 6.75d → 7.12d | baseline start 2019-09-26 16:00 → 2019-09-26 13:00; baseline finish 2019-09-27 16:00 → 2019-09-27 12:00 |
| 50 | Prepare Offices | 2019-09-27 16:00 → 2019-09-27 13:00 | 2019-10-04 16:00 → 2019-10-04 12:00 |  |  | 6.75d → 7.12d | baseline start 2019-09-27 16:00 → 2019-09-27 13:00; baseline finish 2019-10-04 16:00 → 2019-10-04 12:00 |
| 51 | Assemble Furniture | 2019-10-04 16:00 → 2019-10-04 13:00 | 2019-10-08 16:00 → 2019-10-08 12:00 |  |  | 6.75d → 7.12d | baseline start 2019-10-04 16:00 → 2019-10-04 13:00; baseline finish 2019-10-08 16:00 → 2019-10-08 12:00 |
| 52 | Hook up Computers | 2019-10-08 16:00 → 2019-10-08 13:00 | 2019-10-09 16:00 → 2019-10-09 12:00 |  |  | 6.75d → 7.12d | baseline start 2019-10-08 16:00 → 2019-10-08 13:00; baseline finish 2019-10-09 16:00 → 2019-10-09 12:00 |
| 53 | Hook up Phones | 2019-10-08 16:00 → 2019-10-08 13:00 | 2019-10-09 16:00 → 2019-10-09 12:00 |  |  | 6.75d → 7.12d | baseline start 2019-10-08 16:00 → 2019-10-08 13:00; baseline finish 2019-10-09 16:00 → 2019-10-09 12:00 |
| 54 | JT Call Center Complete | 2019-10-09 16:00 → 2019-10-09 12:00 | 2019-10-09 16:00 → 2019-10-09 12:00 |  |  | 6.75d → 7.12d | baseline start 2019-10-09 16:00 → 2019-10-09 12:00; baseline finish 2019-10-09 16:00 → 2019-10-09 12:00 |
| 55 | **JT Internet Sales Center Refurbishing New Location** | 2019-09-09 16:00 → 2019-09-09 13:00 | 2019-10-11 16:00 → 2019-10-11 12:00 |  |  | 4.75d → 5.12d | baseline start 2019-09-09 16:00 → 2019-09-09 13:00; baseline finish 2019-10-11 16:00 → 2019-10-11 12:00 |
| 56 | Install Network Cables | 2019-09-09 16:00 → 2019-09-09 13:00 | 2019-09-12 16:00 → 2019-09-12 12:00 |  |  | 4.75d → 5.12d | baseline start 2019-09-09 16:00 → 2019-09-09 13:00; baseline finish 2019-09-12 16:00 → 2019-09-12 12:00 |
| 57 | Install TeleCommunication Lines | 2019-09-12 16:00 → 2019-09-12 13:00 | 2019-09-19 16:00 → 2019-09-19 12:00 |  |  | 4.75d → 5.12d | baseline start 2019-09-12 16:00 → 2019-09-12 13:00; baseline finish 2019-09-19 16:00 → 2019-09-19 12:00 |
| 58 | Paint the walls | 2019-09-19 16:00 → 2019-09-19 13:00 | 2019-09-23 16:00 → 2019-09-23 12:00 |  |  | 4.75d → 5.12d | baseline start 2019-09-19 16:00 → 2019-09-19 13:00; baseline finish 2019-09-23 16:00 → 2019-09-23 12:00 |
| 59 | Lay Carpet | 2019-09-24 16:00 → 2019-09-24 13:00 | 2019-09-26 16:00 → 2019-09-26 12:00 |  |  | 4.75d → 5.12d | baseline start 2019-09-24 16:00 → 2019-09-24 13:00; baseline finish 2019-09-26 16:00 → 2019-09-26 12:00 |
| 60 | Install Partitions | 2019-09-26 16:00 → 2019-09-26 13:00 | 2019-09-27 16:00 → 2019-09-27 12:00 |  |  | 4.75d → 5.12d | baseline start 2019-09-26 16:00 → 2019-09-26 13:00; baseline finish 2019-09-27 16:00 → 2019-09-27 12:00 |
| 61 | Prepare Offices | 2019-09-27 16:00 → 2019-09-27 13:00 | 2019-10-04 16:00 → 2019-10-04 12:00 |  |  | 4.75d → 5.12d | baseline start 2019-09-27 16:00 → 2019-09-27 13:00; baseline finish 2019-10-04 16:00 → 2019-10-04 12:00 |
| 62 | Assemble Furniture | 2019-10-04 16:00 → 2019-10-04 13:00 | 2019-10-08 16:00 → 2019-10-08 12:00 |  |  | 4.75d → 5.12d | baseline start 2019-10-04 16:00 → 2019-10-04 13:00; baseline finish 2019-10-08 16:00 → 2019-10-08 12:00 |
| 63 | Hook up Computers | 2019-10-08 16:00 → 2019-10-08 13:00 | 2019-10-09 16:00 → 2019-10-09 12:00 |  |  | 4.75d → 5.12d | baseline start 2019-10-08 16:00 → 2019-10-08 13:00; baseline finish 2019-10-09 16:00 → 2019-10-09 12:00 |
| 64 | Hook up Phones | 2019-10-08 16:00 → 2019-10-08 13:00 | 2019-10-09 16:00 → 2019-10-09 12:00 |  |  | 4.75d → 5.12d | baseline start 2019-10-08 16:00 → 2019-10-08 13:00; baseline finish 2019-10-09 16:00 → 2019-10-09 12:00 |
| 65 | Move in Belongings | 2019-10-09 16:00 → 2019-10-09 13:00 | 2019-10-11 16:00 → 2019-10-11 12:00 |  |  | 4.75d → 5.12d | baseline start 2019-10-09 16:00 → 2019-10-09 13:00; baseline finish 2019-10-11 16:00 → 2019-10-11 12:00 |
| 66 | JT Internet Sales Center Complete | 2019-10-11 16:00 → 2019-10-11 12:00 | 2019-10-11 16:00 → 2019-10-11 12:00 |  |  | 4.75d → 5.12d | baseline start 2019-10-11 16:00 → 2019-10-11 12:00; baseline finish 2019-10-11 16:00 → 2019-10-11 12:00 |
| 67 | **JT Administration Offices Refurbishing New Location** | 2019-09-09 16:00 → 2019-09-09 13:00 | 2019-10-11 16:00 → 2019-10-11 12:00 |  |  | 4.75d → 5.12d | baseline start 2019-09-09 16:00 → 2019-09-09 13:00; baseline finish 2019-10-11 16:00 → 2019-10-11 12:00 |
| 68 | Install Network Cables | 2019-09-09 16:00 → 2019-09-09 13:00 | 2019-09-12 16:00 → 2019-09-12 12:00 |  |  | 4.75d → 5.12d | baseline start 2019-09-09 16:00 → 2019-09-09 13:00; baseline finish 2019-09-12 16:00 → 2019-09-12 12:00 |
| 69 | Install TeleCommunication Lines | 2019-09-12 16:00 → 2019-09-12 13:00 | 2019-09-19 16:00 → 2019-09-19 12:00 |  |  | 4.75d → 5.12d | baseline start 2019-09-12 16:00 → 2019-09-12 13:00; baseline finish 2019-09-19 16:00 → 2019-09-19 12:00 |
| 70 | Paint the walls | 2019-09-19 16:00 → 2019-09-19 13:00 | 2019-09-23 16:00 → 2019-09-23 12:00 |  |  | 4.75d → 5.12d | baseline start 2019-09-19 16:00 → 2019-09-19 13:00; baseline finish 2019-09-23 16:00 → 2019-09-23 12:00 |
| 71 | Lay Carpet | 2019-09-24 16:00 → 2019-09-24 13:00 | 2019-09-26 16:00 → 2019-09-26 12:00 |  |  | 4.75d → 5.12d | baseline start 2019-09-24 16:00 → 2019-09-24 13:00; baseline finish 2019-09-26 16:00 → 2019-09-26 12:00 |
| 72 | Install Partitions | 2019-09-26 16:00 → 2019-09-26 13:00 | 2019-09-27 16:00 → 2019-09-27 12:00 |  |  | 4.75d → 5.12d | baseline start 2019-09-26 16:00 → 2019-09-26 13:00; baseline finish 2019-09-27 16:00 → 2019-09-27 12:00 |
| 73 | Prepare Offices | 2019-09-27 16:00 → 2019-09-27 13:00 | 2019-10-04 16:00 → 2019-10-04 12:00 |  |  | 4.75d → 5.12d | baseline start 2019-09-27 16:00 → 2019-09-27 13:00; baseline finish 2019-10-04 16:00 → 2019-10-04 12:00 |
| 74 | Assemble Furniture | 2019-10-04 16:00 → 2019-10-04 13:00 | 2019-10-08 16:00 → 2019-10-08 12:00 |  |  | 4.75d → 5.12d | baseline start 2019-10-04 16:00 → 2019-10-04 13:00; baseline finish 2019-10-08 16:00 → 2019-10-08 12:00 |
| 75 | Hook up Computers | 2019-10-08 16:00 → 2019-10-08 13:00 | 2019-10-09 16:00 → 2019-10-09 12:00 |  |  | 4.75d → 5.12d | baseline start 2019-10-08 16:00 → 2019-10-08 13:00; baseline finish 2019-10-09 16:00 → 2019-10-09 12:00 |
| 76 | Hook up Phones | 2019-10-08 16:00 → 2019-10-08 13:00 | 2019-10-09 16:00 → 2019-10-09 12:00 |  |  | 4.75d → 5.12d | baseline start 2019-10-08 16:00 → 2019-10-08 13:00; baseline finish 2019-10-09 16:00 → 2019-10-09 12:00 |
| 77 | Move in Belongings | 2019-10-09 16:00 → 2019-10-09 13:00 | 2019-10-11 16:00 → 2019-10-11 12:00 |  |  | 4.75d → 5.12d | baseline start 2019-10-09 16:00 → 2019-10-09 13:00; baseline finish 2019-10-11 16:00 → 2019-10-11 12:00 |
| 78 | JT Administrative Offices Complete | 2019-10-11 16:00 → 2019-10-11 12:00 | 2019-10-11 16:00 → 2019-10-11 12:00 |  |  | 4.75d → 5.12d | baseline start 2019-10-11 16:00 → 2019-10-11 12:00; baseline finish 2019-10-11 16:00 → 2019-10-11 12:00 |
| 79 | JT Offices Refurbishing Complete | 2019-10-11 16:00 → 2019-10-11 12:00 | 2019-10-11 16:00 → 2019-10-11 12:00 |  |  | 4.75d → 5.12d | baseline start 2019-10-11 16:00 → 2019-10-11 12:00; baseline finish 2019-10-11 16:00 → 2019-10-11 12:00 |

## Version 7 (saved 2019-06-28, file JT Corporate Move Set Two Baselines .mpp)

Last finish 2019-12-06 → 2019-12-03 (-3d). Complete tasks 11 → 0.

Removed: 5 JT Move Status Meetings 4; 6 JT Move Status Meetings 5; 7 JT Move Status Meetings 6; 8 JT Move Status Meetings 7; 9 JT Move Status Meetings 8; 10 JT Move Status Meetings 9; 11 JT Move Status Meetings 10; 12 JT Move Status Meetings 11; 13 JT Move Status Meetings 12; 14 JT Move Status Meetings 13; 15 JT Move Status Meetings 14; 16 JT Move Status Meetings 15; 17 JT Move Status Meetings 16; 18 JT Move Status Meetings 17; 19 JT Move Status Meetings 18; 20 JT Move Status Meetings 19; 21 JT Move Status Meetings 20; 22 JT Move Status Meetings 21; 23 JT Move Status Meetings 22; 24 JT Move Status Meetings 23

Changed:

| ID | Task | Start | Finish | Duration | Complete | Total float | Other |
| --- | --- | --- | --- | --- | --- | --- | --- |
| 1 | **JT Move Status Meetings** | 2019-07-05 08:00 → 2019-07-05 | 2019-12-06 09:00 → 2019-07-19 (-140d) | 110.12d → 10.12d |  | 0d → 97.38d | baseline start 2019-07-05 08:00 → none; baseline finish 2019-12-06 09:00 → none |
| 2 | JT Move Status Meetings 1 | 2019-07-05 08:00 → 2019-07-05 | 2019-07-05 09:00 → 2019-07-05 |  |  | 110d → 107.38d | constraint start no earlier than 2019-07-05 08:00 → start no earlier than 2019-07-05; baseline start 2019-07-05 08:00 → none; baseline finish 2019-07-05 09:00 → none |
| 3 | JT Move Status Meetings 2 | 2019-07-12 08:00 → 2019-07-12 | 2019-07-12 09:00 → 2019-07-12 |  |  | 105d → 102.38d | constraint start no earlier than 2019-07-12 08:00 → start no earlier than 2019-07-12; baseline start 2019-07-12 08:00 → none; baseline finish 2019-07-12 09:00 → none |
| 4 | JT Move Status Meetings 3 | 2019-07-19 08:00 → 2019-07-19 | 2019-07-19 09:00 → 2019-07-19 |  |  | 100d → 97.38d | constraint start no earlier than 2019-07-19 08:00 → start no earlier than 2019-07-19; baseline start 2019-07-19 08:00 → none; baseline finish 2019-07-19 09:00 → none |
| 5 | **Planning the Move** | 2019-07-02 08:00 A → 2019-07-01 (-1d) | 2019-09-09 12:00 → 2019-09-09 | 48.5d → 49.38d | 91% → 0% | 5.12d → 2.62d | baseline start 2019-07-02 08:00 → none; baseline finish 2019-09-09 12:00 → none |
| 6 | Identify Move Team Members | 2019-07-02 08:00 A → 2019-07-01 (-1d) | 2019-07-03 17:00 A → 2019-07-02 (-1d) |  | 100% → 0% | none → 2.62d | baseline start 2019-07-02 08:00 → none; baseline finish 2019-07-03 17:00 → none |
| 7 | Plan Infastructure Upgrades | 2019-07-05 08:00 A → 2019-07-03 (-2d) | 2019-07-18 17:00 A → 2019-07-17 (-1d) |  | 100% → 0% | none → 2.62d | baseline start 2019-07-05 08:00 → none; baseline finish 2019-07-18 17:00 → none |
| 8 | Plan IT Move | 2019-07-19 08:00 A → 2019-07-18 (-1d) | 2019-08-01 17:00 A → 2019-07-31 (-1d) |  | 100% → 0% | none → 2.62d | baseline start 2019-07-19 08:00 → none; baseline finish 2019-08-01 17:00 → none |
| 9 | Plan Physical Move | 2019-07-23 13:00 A → 2019-07-22 (-1d) | 2019-08-06 12:00 A → 2019-08-05 (-1d) |  | 100% → 0% | none → 2.62d | baseline start 2019-07-23 13:00 → none; baseline finish 2019-08-06 12:00 → none |
| 10 | Plan for Continous Operations During the Move | 2019-08-06 13:00 A → 2019-08-05 (-1d) | 2019-08-12 12:00 A → 2019-08-09 (-3d) |  | 100% → 0% | none → 2.62d | baseline start 2019-08-06 13:00 → none; baseline finish 2019-08-12 12:00 → none |
| 11 | Obtain Estimates from Moving Services | 2019-08-12 08:00 A → 2019-08-09 (-3d) | 2019-08-16 17:00 A → 2019-08-16 |  | 100% → 0% | none → 2.62d | baseline start 2019-08-12 08:00 → none; baseline finish 2019-08-16 17:00 → none |
| 12 | Interview and Select Movers | 2019-08-15 08:00 A → 2019-08-16 (+1d) | 2019-08-26 12:00 A → 2019-08-23 (-3d) | 1.5w → 1w | 100% → 0% | none → 2.62d | baseline start 2019-08-15 08:00 → none; baseline finish 2019-08-26 12:00 → none |
| 13 | Obtain Estimates from IT Installation Companies | 2019-08-19 08:00 A → 2019-08-16 (-3d) | 2019-08-23 17:00 A → 2019-08-23 |  | 100% → 0% | none → 2.62d | baseline start 2019-08-19 08:00 → none; baseline finish 2019-08-23 17:00 → none |
| 14 | Interview and Select IT Installation Company | 2019-08-26 08:00 A → 2019-08-23 (-3d) | 2019-08-30 17:00 A → 2019-08-30 |  | 100% → 0% | none → 2.62d | baseline start 2019-08-26 08:00 → none; baseline finish 2019-08-30 17:00 → none |
| 15 | Order Boxes and Materials needed for the Move | 2019-09-02 08:00 A → 2019-08-30 (-3d) | 2019-09-02 11:00 A → 2019-08-30 (-3d) |  | 100% → 0% | none → 2.62d | baseline start 2019-09-02 08:00 → none; baseline finish 2019-09-02 11:00 → none |
| 16 | Planning the Move Complete | 2019-09-02 08:00 A → 2019-08-30 (-3d) | 2019-09-02 08:00 A → 2019-08-30 (-3d) |  | 100% → 0% | none → 2.62d | baseline start 2019-09-02 08:00 → none; baseline finish 2019-09-02 08:00 → none |
| 17 | **Communications** | 2019-09-02 08:00 → 2019-08-30 (-3d) | 2019-09-09 12:00 → 2019-09-09 |  |  | 5.12d → 2.62d | baseline start 2019-09-02 08:00 → none; baseline finish 2019-09-09 12:00 → none |
| 18 | Communicate Move Plan to Employees | 2019-09-02 08:00 → 2019-08-30 (-3d) | 2019-09-04 17:00 → 2019-09-04 |  |  | 5.12d → 2.62d | baseline start 2019-09-02 08:00 → none; baseline finish 2019-09-04 17:00 → none |
| 19 | Gather Feedback From Employees | 2019-09-05 08:00 → 2019-09-04 (-1d) | 2019-09-06 17:00 → 2019-09-06 |  |  | 5.12d → 2.62d | baseline start 2019-09-05 08:00 → none; baseline finish 2019-09-06 17:00 → none |
| 20 | Communicate Move Information to Suppliers | 2019-09-09 08:00 → 2019-09-06 (-3d) | 2019-09-09 10:00 → 2019-09-09 |  |  | 5.12d → 2.62d | baseline start 2019-09-09 08:00 → none; baseline finish 2019-09-09 10:00 → none |
| 21 | Communicate Move Information to Customers | 2019-09-09 10:00 → 2019-09-09 | 2019-09-09 12:00 → 2019-09-09 |  |  | 5.12d → 2.62d | baseline start 2019-09-09 10:00 → none; baseline finish 2019-09-09 12:00 → none |
| 22 | Communications Complete | 2019-09-09 12:00 → 2019-09-09 | 2019-09-09 12:00 → 2019-09-09 |  |  | 5.12d → 2.62d | baseline start 2019-09-09 12:00 → none; baseline finish 2019-09-09 12:00 → none |
| 23 | **JT Corporate Center Preparation** | 2019-09-09 13:00 → 2019-09-09 | 2019-10-11 12:00 → 2019-10-11 |  |  | 5.12d → 2.62d | baseline start 2019-09-09 13:00 → none; baseline finish 2019-10-11 12:00 → none |
| 24 | **JT Call Center Refurbishing New Location** | 2019-09-09 13:00 → 2019-09-09 | 2019-10-09 12:00 → 2019-10-09 |  |  | 5.12d → 2.62d | baseline start 2019-09-09 13:00 → none; baseline finish 2019-10-09 12:00 → none |
| 25 | Install Network Cables | 2019-09-09 13:00 → 2019-09-09 | 2019-09-12 12:00 → 2019-09-12 |  |  | 5.12d → 2.62d | baseline start 2019-09-09 13:00 → none; baseline finish 2019-09-12 12:00 → none |
| 26 | Install TeleCommunication Lines | 2019-09-12 13:00 → 2019-09-12 | 2019-09-19 12:00 → 2019-09-19 |  |  | 7.12d → 4.62d | baseline start 2019-09-12 13:00 → none; baseline finish 2019-09-19 12:00 → none |
| 27 | Paint the walls | 2019-09-19 13:00 → 2019-09-19 | 2019-09-23 12:00 → 2019-09-23 |  |  | 7.12d → 4.62d | baseline start 2019-09-19 13:00 → none; baseline finish 2019-09-23 12:00 → none |
| 28 | Lay Carpet | 2019-09-24 13:00 → 2019-09-24 | 2019-09-26 12:00 → 2019-09-26 |  |  | 7.12d → 4.62d | baseline start 2019-09-24 13:00 → none; baseline finish 2019-09-26 12:00 → none |
| 29 | Install Partitions | 2019-09-26 13:00 → 2019-09-26 | 2019-09-27 12:00 → 2019-09-27 |  |  | 7.12d → 4.62d | baseline start 2019-09-26 13:00 → none; baseline finish 2019-09-27 12:00 → none |
| 30 | Prepare Offices | 2019-09-27 13:00 → 2019-09-27 | 2019-10-04 12:00 → 2019-10-04 |  |  | 7.12d → 4.62d | baseline start 2019-09-27 13:00 → none; baseline finish 2019-10-04 12:00 → none |
| 31 | Assemble Furniture | 2019-10-04 13:00 → 2019-10-04 | 2019-10-08 12:00 → 2019-10-08 |  |  | 7.12d → 4.62d | baseline start 2019-10-04 13:00 → none; baseline finish 2019-10-08 12:00 → none |
| 32 | Hook up Computers | 2019-10-08 13:00 → 2019-10-08 | 2019-10-09 12:00 → 2019-10-09 |  |  | 7.12d → 4.62d | baseline start 2019-10-08 13:00 → none; baseline finish 2019-10-09 12:00 → none |
| 33 | Hook up Phones | 2019-10-08 13:00 → 2019-10-08 | 2019-10-09 12:00 → 2019-10-09 |  |  | 7.12d → 4.62d | baseline start 2019-10-08 13:00 → none; baseline finish 2019-10-09 12:00 → none |
| 34 | JT Call Center Complete | 2019-10-09 12:00 → 2019-10-09 | 2019-10-09 12:00 → 2019-10-09 |  |  | 7.12d → 4.62d | baseline start 2019-10-09 12:00 → none; baseline finish 2019-10-09 12:00 → none |
| 35 | **JT Internet Sales Center Refurbishing New Location** | 2019-09-09 13:00 → 2019-09-09 | 2019-10-11 12:00 → 2019-10-11 |  |  | 5.12d → 2.62d | baseline start 2019-09-09 13:00 → none; baseline finish 2019-10-11 12:00 → none |
| 36 | Install Network Cables | 2019-09-09 13:00 → 2019-09-09 | 2019-09-12 12:00 → 2019-09-12 |  |  | 5.12d → 2.62d | baseline start 2019-09-09 13:00 → none; baseline finish 2019-09-12 12:00 → none |
| 37 | Install TeleCommunication Lines | 2019-09-12 13:00 → 2019-09-12 | 2019-09-19 12:00 → 2019-09-19 |  |  | 5.12d → 2.62d | baseline start 2019-09-12 13:00 → none; baseline finish 2019-09-19 12:00 → none |
| 38 | Paint the walls | 2019-09-19 13:00 → 2019-09-19 | 2019-09-23 12:00 → 2019-09-23 |  |  | 5.12d → 2.62d | baseline start 2019-09-19 13:00 → none; baseline finish 2019-09-23 12:00 → none |
| 39 | Lay Carpet | 2019-09-24 13:00 → 2019-09-24 | 2019-09-26 12:00 → 2019-09-26 |  |  | 5.12d → 2.62d | baseline start 2019-09-24 13:00 → none; baseline finish 2019-09-26 12:00 → none |
| 40 | Install Partitions | 2019-09-26 13:00 → 2019-09-26 | 2019-09-27 12:00 → 2019-09-27 |  |  | 5.12d → 2.62d | baseline start 2019-09-26 13:00 → none; baseline finish 2019-09-27 12:00 → none |
| 41 | Prepare Offices | 2019-09-27 13:00 → 2019-09-27 | 2019-10-04 12:00 → 2019-10-04 |  |  | 5.12d → 2.62d | baseline start 2019-09-27 13:00 → none; baseline finish 2019-10-04 12:00 → none |
| 42 | Assemble Furniture | 2019-10-04 13:00 → 2019-10-04 | 2019-10-08 12:00 → 2019-10-08 |  |  | 5.12d → 2.62d | baseline start 2019-10-04 13:00 → none; baseline finish 2019-10-08 12:00 → none |
| 43 | Hook up Computers | 2019-10-08 13:00 → 2019-10-08 | 2019-10-09 12:00 → 2019-10-09 |  |  | 5.12d → 2.62d | baseline start 2019-10-08 13:00 → none; baseline finish 2019-10-09 12:00 → none |
| 44 | Hook up Phones | 2019-10-08 13:00 → 2019-10-08 | 2019-10-09 12:00 → 2019-10-09 |  |  | 5.12d → 2.62d | baseline start 2019-10-08 13:00 → none; baseline finish 2019-10-09 12:00 → none |
| 45 | Move in Belongings | 2019-10-09 13:00 → 2019-10-09 | 2019-10-11 12:00 → 2019-10-11 |  |  | 5.12d → 2.62d | baseline start 2019-10-09 13:00 → none; baseline finish 2019-10-11 12:00 → none |
| 46 | JT Internet Sales Center Complete | 2019-10-11 12:00 → 2019-10-11 | 2019-10-11 12:00 → 2019-10-11 |  |  | 5.12d → 2.62d | baseline start 2019-10-11 12:00 → none; baseline finish 2019-10-11 12:00 → none |
| 47 | **JT Administration Offices Refurbishing New Location** | 2019-09-09 13:00 → 2019-09-09 | 2019-10-11 12:00 → 2019-10-11 |  |  | 5.12d → 2.62d | baseline start 2019-09-09 13:00 → none; baseline finish 2019-10-11 12:00 → none |
| 48 | Install Network Cables | 2019-09-09 13:00 → 2019-09-09 | 2019-09-12 12:00 → 2019-09-12 |  |  | 5.12d → 2.62d | baseline start 2019-09-09 13:00 → none; baseline finish 2019-09-12 12:00 → none |
| 49 | Install TeleCommunication Lines | 2019-09-12 13:00 → 2019-09-12 | 2019-09-19 12:00 → 2019-09-19 |  |  | 5.12d → 2.62d | baseline start 2019-09-12 13:00 → none; baseline finish 2019-09-19 12:00 → none |
| 50 | Paint the walls | 2019-09-19 13:00 → 2019-09-19 | 2019-09-23 12:00 → 2019-09-23 |  |  | 5.12d → 2.62d | baseline start 2019-09-19 13:00 → none; baseline finish 2019-09-23 12:00 → none |
| 51 | Lay Carpet | 2019-09-24 13:00 → 2019-09-24 | 2019-09-26 12:00 → 2019-09-26 |  |  | 5.12d → 2.62d | baseline start 2019-09-24 13:00 → none; baseline finish 2019-09-26 12:00 → none |
| 52 | Install Partitions | 2019-09-26 13:00 → 2019-09-26 | 2019-09-27 12:00 → 2019-09-27 |  |  | 5.12d → 2.62d | baseline start 2019-09-26 13:00 → none; baseline finish 2019-09-27 12:00 → none |
| 53 | Prepare Offices | 2019-09-27 13:00 → 2019-09-27 | 2019-10-04 12:00 → 2019-10-04 |  |  | 5.12d → 2.62d | baseline start 2019-09-27 13:00 → none; baseline finish 2019-10-04 12:00 → none |
| 54 | Assemble Furniture | 2019-10-04 13:00 → 2019-10-04 | 2019-10-08 12:00 → 2019-10-08 |  |  | 5.12d → 2.62d | baseline start 2019-10-04 13:00 → none; baseline finish 2019-10-08 12:00 → none |
| 55 | Hook up Computers | 2019-10-08 13:00 → 2019-10-08 | 2019-10-09 12:00 → 2019-10-09 |  |  | 5.12d → 2.62d | baseline start 2019-10-08 13:00 → none; baseline finish 2019-10-09 12:00 → none |
| 56 | Hook up Phones | 2019-10-08 13:00 → 2019-10-08 | 2019-10-09 12:00 → 2019-10-09 |  |  | 5.12d → 2.62d | baseline start 2019-10-08 13:00 → none; baseline finish 2019-10-09 12:00 → none |
| 57 | Move in Belongings | 2019-10-09 13:00 → 2019-10-09 | 2019-10-11 12:00 → 2019-10-11 |  |  | 5.12d → 2.62d | baseline start 2019-10-09 13:00 → none; baseline finish 2019-10-11 12:00 → none |
| 58 | JT Administrative Offices Complete | 2019-10-11 12:00 → 2019-10-11 | 2019-10-11 12:00 → 2019-10-11 |  |  | 5.12d → 2.62d | baseline start 2019-10-11 12:00 → none; baseline finish 2019-10-11 12:00 → none |
| 59 | JT Offices Refurbishing Complete | 2019-10-11 12:00 → 2019-10-11 | 2019-10-11 12:00 → 2019-10-11 |  |  | 5.12d → 2.62d | baseline start 2019-10-11 12:00 → none; baseline finish 2019-10-11 12:00 → none |
| 60 | **Moving** | 2019-10-16 08:00 → 2019-10-16 | 2019-11-29 10:00 → 2019-11-29 |  |  | 2.62d → 0d | baseline start 2019-10-16 08:00 → none; baseline finish 2019-11-29 10:00 → none |
| 61 | **Packing** | 2019-10-16 08:00 → 2019-10-16 | 2019-11-20 10:00 → 2019-11-20 |  |  | 2.62d → 0d | baseline start 2019-10-16 08:00 → none; baseline finish 2019-11-20 10:00 → none |
| 62 | Distribute Boxes to Employees | 2019-10-16 08:00 → 2019-10-16 | 2019-10-18 17:00 → 2019-10-18 |  |  | 2.62d → 0d | constraint start no earlier than 2019-10-16 08:00 → start no earlier than 2019-10-16; baseline start 2019-10-16 08:00 → none; baseline finish 2019-10-18 17:00 → none |
| 63 | Communicate Timetable and Packing Requirements to Employees | 2019-10-21 08:00 → 2019-10-21 | 2019-10-21 17:00 → 2019-10-21 |  |  | 2.62d → 0d | baseline start 2019-10-21 08:00 → none; baseline finish 2019-10-21 17:00 → none |
| 64 | Tag Furniture and Equipment to Identify New Area Staging | 2019-10-22 08:00 → 2019-10-22 | 2019-11-04 17:00 → 2019-11-04 |  |  | 2.62d → 0d | baseline start 2019-10-22 08:00 → none; baseline finish 2019-11-04 17:00 → none |
| 65 | Tag Computer Equipment to Identify New Are Staging | 2019-11-05 08:00 → 2019-11-05 | 2019-11-18 17:00 → 2019-11-18 |  |  | 2.62d → 0d | baseline start 2019-11-05 08:00 → none; baseline finish 2019-11-18 17:00 → none |
| 66 | Packing Complete | 2019-11-18 17:00 → 2019-11-18 | 2019-11-18 17:00 → 2019-11-18 |  |  | 2.62d → 0d | baseline start 2019-11-18 17:00 → none; baseline finish 2019-11-18 17:00 → none |
| 67 | **Final Moving Preperations** | 2019-11-19 08:00 → 2019-11-19 | 2019-11-20 10:00 → 2019-11-20 |  |  | 2.62d → 0d | baseline start 2019-11-19 08:00 → none; baseline finish 2019-11-20 10:00 → none |
| 68 | Communicate Rotation Schedule to Insure Continous Operations | 2019-11-19 08:00 → 2019-11-19 | 2019-11-19 11:00 → 2019-11-19 |  |  | 2.62d → 0d | baseline start 2019-11-19 08:00 → none; baseline finish 2019-11-19 11:00 → none |
| 69 | Walk-through to Double Chjeck Tagging of All Furniture and Equipment | 2019-11-19 11:00 → 2019-11-19 | 2019-11-19 14:00 → 2019-11-19 |  |  | 2.62d → 0d | baseline start 2019-11-19 11:00 → none; baseline finish 2019-11-19 14:00 → none |
| 70 | Review Move Schedule with Team Leaders | 2019-11-19 14:00 → 2019-11-19 | 2019-11-19 17:00 → 2019-11-19 |  |  | 2.62d → 0d | baseline start 2019-11-19 14:00 → none; baseline finish 2019-11-19 17:00 → none |

| ID | Task | Start | Finish | Total float | Other |
| --- | --- | --- | --- | --- | --- |
| 71 | Review Move Schedule with Movers | 2019-11-20 08:00 → 2019-11-20 | 2019-11-20 10:00 → 2019-11-20 | 2.62d → 0d | baseline start 2019-11-20 08:00 → none; baseline finish 2019-11-20 10:00 → none |
| 72 | Final Moving Preperations Complete | 2019-11-20 10:00 → 2019-11-20 | 2019-11-20 10:00 → 2019-11-20 | 2.62d → 0d | baseline start 2019-11-20 10:00 → none; baseline finish 2019-11-20 10:00 → none |
| 73 | **Move Furniture and Equipment** | 2019-11-20 10:00 → 2019-11-20 | 2019-11-29 10:00 → 2019-11-29 | 2.62d → 0d | baseline start 2019-11-20 10:00 → none; baseline finish 2019-11-29 10:00 → none |
| 74 | Move JT Administrative Offices | 2019-11-20 10:00 → 2019-11-20 | 2019-11-22 10:00 → 2019-11-22 | 2.62d → 0d | baseline start 2019-11-20 10:00 → none; baseline finish 2019-11-22 10:00 → none |
| 75 | Move First Wave JT Call Center | 2019-11-22 10:00 → 2019-11-22 | 2019-11-25 10:00 → 2019-11-25 | 2.62d → 0d | baseline start 2019-11-22 10:00 → none; baseline finish 2019-11-25 10:00 → none |
| 76 | Move First Wave JT Internet Sales Center | 2019-11-25 10:00 → 2019-11-25 | 2019-11-26 10:00 → 2019-11-26 | 2.62d → 0d | baseline start 2019-11-25 10:00 → none; baseline finish 2019-11-26 10:00 → none |
| 77 | Setup New JT Call Center for Operations | 2019-11-26 10:00 → 2019-11-26 | 2019-11-26 15:00 → 2019-11-26 | 2.62d → 0d | baseline start 2019-11-26 10:00 → none; baseline finish 2019-11-26 15:00 → none |
| 78 | Setup New JT Internet Sales Center for Operations | 2019-11-26 15:00 → 2019-11-26 | 2019-11-27 10:00 → 2019-11-27 | 2.62d → 0d | baseline start 2019-11-26 15:00 → none; baseline finish 2019-11-27 10:00 → none |
| 79 | New JT Call Center Operational | 2019-11-27 10:00 → 2019-11-27 | 2019-11-27 10:00 → 2019-11-27 | 2.62d → 0d | baseline start 2019-11-27 10:00 → none; baseline finish 2019-11-27 10:00 → none |
| 80 | New JT Internet Sales Center Operational | 2019-11-27 10:00 → 2019-11-27 | 2019-11-27 10:00 → 2019-11-27 | 2.62d → 0d | baseline start 2019-11-27 10:00 → none; baseline finish 2019-11-27 10:00 → none |
| 81 | Move Final Group JT Call Center | 2019-11-27 10:00 → 2019-11-27 | 2019-11-28 10:00 → 2019-11-28 | 2.62d → 0d | baseline start 2019-11-27 10:00 → none; baseline finish 2019-11-28 10:00 → none |
| 82 | Move Final Group JT Internet Sales Center | 2019-11-28 10:00 → 2019-11-28 | 2019-11-29 10:00 → 2019-11-29 | 2.62d → 0d | baseline start 2019-11-28 10:00 → none; baseline finish 2019-11-29 10:00 → none |
| 83 | Move Furniture and Equipment Complete | 2019-11-29 10:00 → 2019-11-29 | 2019-11-29 10:00 → 2019-11-29 | 2.62d → 0d | baseline start 2019-11-29 10:00 → none; baseline finish 2019-11-29 10:00 → none |
| 84 | Move Complete | 2019-11-29 10:00 → 2019-11-29 | 2019-11-29 10:00 → 2019-11-29 | 2.62d → 0d | baseline start 2019-11-29 10:00 → none; baseline finish 2019-11-29 10:00 → none |
| 85 | **JT Corporate Move Closeout** | 2019-11-29 10:00 → 2019-11-29 | 2019-12-03 12:00 → 2019-12-03 | 2.62d → 0d | baseline start 2019-11-29 10:00 → none; baseline finish 2019-12-03 12:00 → none |
| 86 | Unpacking all areas | 2019-11-29 10:00 → 2019-11-29 | 2019-12-03 10:00 → 2019-12-03 | 2.62d → 0d | baseline start 2019-11-29 10:00 → none; baseline finish 2019-12-03 10:00 → none |
| 87 | Company-Wide Meeting | 2019-12-03 10:00 → 2019-12-03 | 2019-12-03 12:00 → 2019-12-03 | 2.62d → 0d | baseline start 2019-12-03 10:00 → none; baseline finish 2019-12-03 12:00 → none |
| 88 | Move Evaluation | 2019-12-02 15:00 → 2019-12-02 | 2019-12-03 10:00 → 2019-12-03 | 2.62d → 0.12d | baseline start 2019-12-02 15:00 → none; baseline finish 2019-12-03 10:00 → none |
| 89 | Pay Movers | 2019-12-03 10:00 → 2019-12-03 | 2019-12-03 11:00 → 2019-12-03 | 2.62d → 0.12d | baseline start 2019-12-03 10:00 → none; baseline finish 2019-12-03 11:00 → none |
| 90 | JT Corporate Move Closeout Complete | 2019-12-03 11:00 → 2019-12-03 | 2019-12-03 11:00 → 2019-12-03 | 2.62d → 0.12d | baseline start 2019-12-03 11:00 → none; baseline finish 2019-12-03 11:00 → none |
| 91 | JT Corporate Move Complete | 2019-12-03 11:00 → 2019-12-03 | 2019-12-03 11:00 → 2019-12-03 | 2.62d → 0.12d | constraint finish no later than 2019-12-05 17:00 → finish no later than 2019-12-05; baseline start 2019-12-03 11:00 → none; baseline finish 2019-12-03 11:00 → none |

## Version 8 (saved 2019-06-28, file JT Corporate Move Status Date.mpp)

Last finish stays 2019-12-03.

Changed:

| ID | Task | Other |
| --- | --- | --- |
| 6 | Identify Move Team Members | resources none → Laura Lynn |
| 7 | Plan Infastructure Upgrades | resources none → Juan Silva |
| 8 | Plan IT Move | resources none → Charlie Mejia; Rick Herrera |
| 9 | Plan Physical Move | resources none → Charlie Mejia; Rick Herrera |
| 10 | Plan for Continous Operations During the Move | resources none → Dorothy Windle [50%]; Juan Silva [50%] |
| 11 | Obtain Estimates from Moving Services | resources none → Administration Services [200%] |
| 12 | Interview and Select Movers | resources none → Administration Services [200%] |
| 13 | Obtain Estimates from IT Installation Companies | resources none → Administration Services [200%] |
| 14 | Interview and Select IT Installation Company | resources none → Administration Services [200%] |
| 15 | Order Boxes and Materials needed for the Move | resources none → Administration Services [200%] |
| 18 | Communicate Move Plan to Employees | resources none → Ron Sova [50%] |
| 19 | Gather Feedback From Employees | resources none → Ron Sova [50%] |
| 20 | Communicate Move Information to Suppliers | resources none → Ron Sova [50%] |
| 21 | Communicate Move Information to Customers | resources none → Ron Sova [50%] |
| 25 | Install Network Cables | resources none → Network Heroes |
| 26 | Install TeleCommunication Lines | resources none → Network Heroes |
| 27 | Paint the walls | resources none → Extreme Designs |
| 28 | Lay Carpet | resources none → Extreme Designs |
| 29 | Install Partitions | resources none → Extreme Designs |
| 30 | Prepare Offices | resources none → Extreme Designs |
| 31 | Assemble Furniture | resources none → Extreme Designs |
| 32 | Hook up Computers | resources none → Network Heroes |
| 33 | Hook up Phones | resources none → Network Heroes |
| 36 | Install Network Cables | resources none → Network Heroes |
| 37 | Install TeleCommunication Lines | resources none → Network Heroes |
| 38 | Paint the walls | resources none → Extreme Designs |
| 39 | Lay Carpet | resources none → Extreme Designs |
| 40 | Install Partitions | resources none → Extreme Designs |
| 41 | Prepare Offices | resources none → Extreme Designs |
| 42 | Assemble Furniture | resources none → Extreme Designs |
| 43 | Hook up Computers | resources none → Network Heroes |
| 44 | Hook up Phones | resources none → Network Heroes |
| 48 | Install Network Cables | resources none → Network Heroes |
| 49 | Install TeleCommunication Lines | resources none → Network Heroes |
| 50 | Paint the walls | resources none → Extreme Designs |
| 51 | Lay Carpet | resources none → Extreme Designs |
| 52 | Install Partitions | resources none → Extreme Designs |
| 53 | Prepare Offices | resources none → Extreme Designs |
| 54 | Assemble Furniture | resources none → Extreme Designs |
| 55 | Hook up Computers | resources none → Network Heroes |
| 56 | Hook up Phones | resources none → Network Heroes |
| 62 | Distribute Boxes to Employees | resources none → Maintenance |
| 63 | Communicate Timetable and Packing Requirements to Employees | resources none → Ron Sova |
| 64 | Tag Furniture and Equipment to Identify New Area Staging | resources none → Internet Sales Day Operators [700%]; Call Center Day Analysts [600%] |
| 65 | Tag Computer Equipment to Identify New Are Staging | resources none → Informations Technology Systems [300%] |
| 68 | Communicate Rotation Schedule to Insure Continous Operations | resources none → Ron Sova |
| 69 | Walk-through to Double Chjeck Tagging of All Furniture and Equipment | resources none → Charlie Mejia |
| 70 | Review Move Schedule with Team Leaders | resources none → Charlie Mejia [20%] |
| 71 | Review Move Schedule with Movers | resources none → Charlie Mejia [20%] |
| 74 | Move JT Administrative Offices | resources none → Maintenance [200%] |
| 75 | Move First Wave JT Call Center | resources none → Maintenance [200%] |
| 76 | Move First Wave JT Internet Sales Center | resources none → Maintenance [200%] |
| 77 | Setup New JT Call Center for Operations | resources none → Network Heroes |
| 78 | Setup New JT Internet Sales Center for Operations | resources none → Network Heroes |

## Version 9 (saved 2019-06-28, file JT Corporate Move Delaying Tasks.mpp)

Last finish 2019-12-03 → 2019-12-10 (+7d).

Changed:

| ID | Task | Start | Finish | Duration | Total float | Other |
| --- | --- | --- | --- | --- | --- | --- |
| 5 | **Planning the Move** |  | 2019-09-09 → 2019-09-18 (+9d) | 49.38d → 56.88d | 2.62d → -2.25d |  |
| 9 | Plan Physical Move | 2019-07-22 → 2019-08-01 (+10d) | 2019-08-05 → 2019-08-14 (+9d) |  | 2.62d → -2.25d |  |
| 10 | Plan for Continous Operations During the Move | 2019-08-05 → 2019-08-15 (+10d) | 2019-08-09 → 2019-08-20 (+11d) |  | 2.62d → -2.25d |  |
| 11 | Obtain Estimates from Moving Services | 2019-08-09 → 2019-08-21 (+12d) | 2019-08-16 → 2019-08-27 (+11d) |  | 2.62d → -2.25d |  |
| 12 | Interview and Select Movers | 2019-08-16 → 2019-08-28 (+12d) | 2019-08-23 → 2019-09-03 (+11d) |  | 2.62d → -2.25d |  |
| 13 | Obtain Estimates from IT Installation Companies | 2019-08-16 → 2019-08-28 (+12d) | 2019-08-23 → 2019-09-03 (+11d) |  | 2.62d → -2.25d |  |
| 14 | Interview and Select IT Installation Company | 2019-08-23 → 2019-09-04 (+12d) | 2019-08-30 → 2019-09-10 (+11d) |  | 2.62d → -2.25d |  |
| 15 | Order Boxes and Materials needed for the Move | 2019-08-30 → 2019-09-11 (+12d) | 2019-08-30 → 2019-09-11 (+12d) |  | 2.62d → -2.25d |  |
| 16 | Planning the Move Complete | 2019-08-30 → 2019-09-11 (+12d) | 2019-08-30 → 2019-09-11 (+12d) |  | 2.62d → -2.25d |  |
| 17 | **Communications** | 2019-08-30 → 2019-09-11 (+12d) | 2019-09-09 → 2019-09-18 (+9d) |  | 2.62d → -2.25d |  |
| 18 | Communicate Move Plan to Employees | 2019-08-30 → 2019-09-11 (+12d) | 2019-09-04 → 2019-09-16 (+12d) |  | 2.62d → -2.25d |  |
| 19 | Gather Feedback From Employees | 2019-09-04 → 2019-09-16 (+12d) | 2019-09-06 → 2019-09-18 (+12d) |  | 2.62d → -2.25d |  |
| 20 | Communicate Move Information to Suppliers | 2019-09-06 → 2019-09-18 (+12d) | 2019-09-09 → 2019-09-18 (+9d) |  | 2.62d → -2.25d |  |
| 21 | Communicate Move Information to Customers | 2019-09-09 → 2019-09-18 (+9d) | 2019-09-09 → 2019-09-18 (+9d) |  | 2.62d → -2.25d |  |
| 22 | Communications Complete | 2019-09-09 → 2019-09-18 (+9d) | 2019-09-09 → 2019-09-18 (+9d) |  | 2.62d → -2.25d |  |
| 23 | **JT Corporate Center Preparation** | 2019-09-09 → 2019-09-18 (+9d) | 2019-10-11 → 2019-10-22 (+11d) |  | 2.62d → -2.25d |  |
| 24 | **JT Call Center Refurbishing New Location** | 2019-09-09 → 2019-09-18 (+9d) | 2019-10-09 → 2019-10-18 (+9d) |  | 2.62d → -2.25d |  |
| 25 | Install Network Cables | 2019-09-09 → 2019-09-18 (+9d) | 2019-09-12 → 2019-09-23 (+11d) |  | 2.62d → -2.25d |  |
| 26 | Install TeleCommunication Lines | 2019-09-12 → 2019-09-23 (+11d) | 2019-09-19 → 2019-09-30 (+11d) |  | 4.62d → -0.25d |  |
| 27 | Paint the walls | 2019-09-19 → 2019-09-30 (+11d) | 2019-09-23 → 2019-10-02 (+9d) |  | 4.62d → -0.25d |  |
| 28 | Lay Carpet | 2019-09-24 → 2019-10-03 (+9d) | 2019-09-26 → 2019-10-07 (+11d) |  | 4.62d → -0.25d |  |
| 29 | Install Partitions | 2019-09-26 → 2019-10-07 (+11d) | 2019-09-27 → 2019-10-08 (+11d) |  | 4.62d → -0.25d |  |
| 30 | Prepare Offices | 2019-09-27 → 2019-10-08 (+11d) | 2019-10-04 → 2019-10-15 (+11d) |  | 4.62d → -0.25d |  |
| 31 | Assemble Furniture | 2019-10-04 → 2019-10-15 (+11d) | 2019-10-08 → 2019-10-17 (+9d) |  | 4.62d → -0.25d |  |
| 32 | Hook up Computers | 2019-10-08 → 2019-10-17 (+9d) | 2019-10-09 → 2019-10-18 (+9d) |  | 4.62d → -0.25d |  |
| 33 | Hook up Phones | 2019-10-08 → 2019-10-17 (+9d) | 2019-10-09 → 2019-10-18 (+9d) |  | 4.62d → -0.25d |  |
| 34 | JT Call Center Complete | 2019-10-09 → 2019-10-18 (+9d) | 2019-10-09 → 2019-10-18 (+9d) |  | 4.62d → -0.25d |  |
| 35 | **JT Internet Sales Center Refurbishing New Location** | 2019-09-09 → 2019-09-18 (+9d) | 2019-10-11 → 2019-10-22 (+11d) |  | 2.62d → -2.25d |  |
| 36 | Install Network Cables | 2019-09-09 → 2019-09-18 (+9d) | 2019-09-12 → 2019-09-23 (+11d) |  | 2.62d → -2.25d |  |
| 37 | Install TeleCommunication Lines | 2019-09-12 → 2019-09-23 (+11d) | 2019-09-19 → 2019-09-30 (+11d) |  | 2.62d → -2.25d |  |
| 38 | Paint the walls | 2019-09-19 → 2019-09-30 (+11d) | 2019-09-23 → 2019-10-02 (+9d) |  | 2.62d → -2.25d |  |
| 39 | Lay Carpet | 2019-09-24 → 2019-10-03 (+9d) | 2019-09-26 → 2019-10-07 (+11d) |  | 2.62d → -2.25d |  |
| 40 | Install Partitions | 2019-09-26 → 2019-10-07 (+11d) | 2019-09-27 → 2019-10-08 (+11d) |  | 2.62d → -2.25d |  |
| 41 | Prepare Offices | 2019-09-27 → 2019-10-08 (+11d) | 2019-10-04 → 2019-10-15 (+11d) |  | 2.62d → -2.25d |  |
| 42 | Assemble Furniture | 2019-10-04 → 2019-10-15 (+11d) | 2019-10-08 → 2019-10-17 (+9d) |  | 2.62d → -2.25d |  |
| 43 | Hook up Computers | 2019-10-08 → 2019-10-17 (+9d) | 2019-10-09 → 2019-10-18 (+9d) |  | 2.62d → -2.25d |  |
| 44 | Hook up Phones | 2019-10-08 → 2019-10-17 (+9d) | 2019-10-09 → 2019-10-18 (+9d) |  | 2.62d → -2.25d |  |
| 45 | Move in Belongings | 2019-10-09 → 2019-10-18 (+9d) | 2019-10-11 → 2019-10-22 (+11d) |  | 2.62d → -2.25d |  |
| 46 | JT Internet Sales Center Complete | 2019-10-11 → 2019-10-22 (+11d) | 2019-10-11 → 2019-10-22 (+11d) |  | 2.62d → -2.25d |  |
| 47 | **JT Administration Offices Refurbishing New Location** | 2019-09-09 → 2019-09-18 (+9d) | 2019-10-11 → 2019-10-22 (+11d) |  | 2.62d → -2.25d |  |
| 48 | Install Network Cables | 2019-09-09 → 2019-09-18 (+9d) | 2019-09-12 → 2019-09-23 (+11d) |  | 2.62d → -2.25d |  |
| 49 | Install TeleCommunication Lines | 2019-09-12 → 2019-09-23 (+11d) | 2019-09-19 → 2019-09-30 (+11d) |  | 2.62d → -2.25d |  |
| 50 | Paint the walls | 2019-09-19 → 2019-09-30 (+11d) | 2019-09-23 → 2019-10-02 (+9d) |  | 2.62d → -2.25d |  |
| 51 | Lay Carpet | 2019-09-24 → 2019-10-03 (+9d) | 2019-09-26 → 2019-10-07 (+11d) |  | 2.62d → -2.25d |  |
| 52 | Install Partitions | 2019-09-26 → 2019-10-07 (+11d) | 2019-09-27 → 2019-10-08 (+11d) |  | 2.62d → -2.25d |  |
| 53 | Prepare Offices | 2019-09-27 → 2019-10-08 (+11d) | 2019-10-04 → 2019-10-15 (+11d) |  | 2.62d → -2.25d |  |
| 54 | Assemble Furniture | 2019-10-04 → 2019-10-15 (+11d) | 2019-10-08 → 2019-10-17 (+9d) |  | 2.62d → -2.25d |  |
| 55 | Hook up Computers | 2019-10-08 → 2019-10-17 (+9d) | 2019-10-09 → 2019-10-18 (+9d) |  | 2.62d → -2.25d |  |
| 56 | Hook up Phones | 2019-10-08 → 2019-10-17 (+9d) | 2019-10-09 → 2019-10-18 (+9d) |  | 2.62d → -2.25d |  |
| 57 | Move in Belongings | 2019-10-09 → 2019-10-18 (+9d) | 2019-10-11 → 2019-10-22 (+11d) |  | 2.62d → -2.25d |  |
| 58 | JT Administrative Offices Complete | 2019-10-11 → 2019-10-22 (+11d) | 2019-10-11 → 2019-10-22 (+11d) |  | 2.62d → -2.25d |  |
| 59 | JT Offices Refurbishing Complete | 2019-10-11 → 2019-10-22 (+11d) | 2019-10-11 → 2019-10-22 (+11d) |  | 2.62d → -2.25d |  |
| 60 | **Moving** | 2019-10-16 → 2019-10-22 (+6d) | 2019-11-29 → 2019-12-06 (+7d) |  | 0d → -2.25d |  |
| 61 | **Packing** | 2019-10-16 → 2019-10-22 (+6d) | 2019-11-20 → 2019-11-27 (+7d) |  | 0d → -2.25d |  |
| 62 | Distribute Boxes to Employees | 2019-10-16 → 2019-10-22 (+6d) | 2019-10-18 → 2019-10-25 (+7d) |  | 0d → -2.25d | constraint start no earlier than 2019-10-16 → start no earlier than 2019-10-18 |
| 63 | Communicate Timetable and Packing Requirements to Employees | 2019-10-21 → 2019-10-25 (+4d) | 2019-10-21 → 2019-10-28 (+7d) |  | 0d → -2.25d |  |
| 64 | Tag Furniture and Equipment to Identify New Area Staging | 2019-10-22 → 2019-10-28 (+6d) | 2019-11-04 → 2019-11-11 (+7d) |  | 0d → -2.25d |  |
| 65 | Tag Computer Equipment to Identify New Are Staging | 2019-11-05 → 2019-11-11 (+6d) | 2019-11-18 → 2019-11-25 (+7d) |  | 0d → -2.25d |  |
| 66 | Packing Complete | 2019-11-18 → 2019-11-25 (+7d) | 2019-11-18 → 2019-11-25 (+7d) |  | 0d → -2.25d |  |
| 67 | **Final Moving Preperations** | 2019-11-19 → 2019-11-25 (+6d) | 2019-11-20 → 2019-11-27 (+7d) |  | 0d → -2.25d |  |
| 68 | Communicate Rotation Schedule to Insure Continous Operations | 2019-11-19 → 2019-11-25 (+6d) | 2019-11-19 → 2019-11-26 (+7d) |  | 0d → -2.25d |  |
| 69 | Walk-through to Double Chjeck Tagging of All Furniture and Equipment | 2019-11-19 → 2019-11-26 (+7d) | 2019-11-19 → 2019-11-26 (+7d) |  | 0d → -2.25d |  |
| 70 | Review Move Schedule with Team Leaders | 2019-11-19 → 2019-11-26 (+7d) | 2019-11-19 → 2019-11-26 (+7d) |  | 0d → -2.25d |  |
| 71 | Review Move Schedule with Movers | 2019-11-20 → 2019-11-26 (+6d) | 2019-11-20 → 2019-11-27 (+7d) |  | 0d → -2.25d |  |
| 72 | Final Moving Preperations Complete | 2019-11-20 → 2019-11-27 (+7d) | 2019-11-20 → 2019-11-27 (+7d) |  | 0d → -2.25d |  |
| 73 | **Move Furniture and Equipment** | 2019-11-20 → 2019-11-27 (+7d) | 2019-11-29 → 2019-12-06 (+7d) |  | 0d → -2.25d |  |
| 74 | Move JT Administrative Offices | 2019-11-20 → 2019-11-27 (+7d) | 2019-11-22 → 2019-11-29 (+7d) |  | 0d → -2.25d |  |
| 75 | Move First Wave JT Call Center | 2019-11-22 → 2019-11-29 (+7d) | 2019-11-25 → 2019-12-02 (+7d) |  | 0d → -2.25d |  |
| 76 | Move First Wave JT Internet Sales Center | 2019-11-25 → 2019-12-02 (+7d) | 2019-11-26 → 2019-12-03 (+7d) |  | 0d → -2.25d |  |
| 77 | Setup New JT Call Center for Operations | 2019-11-26 → 2019-12-03 (+7d) | 2019-11-26 → 2019-12-03 (+7d) |  | 0d → -2.25d |  |

| ID | Task | Start | Finish | Total float | Other |
| --- | --- | --- | --- | --- | --- |
| 78 | Setup New JT Internet Sales Center for Operations | 2019-11-26 → 2019-12-03 (+7d) | 2019-11-27 → 2019-12-04 (+7d) | 0d → -2.25d |  |
| 79 | New JT Call Center Operational | 2019-11-27 → 2019-12-04 (+7d) | 2019-11-27 → 2019-12-04 (+7d) | 0d → -2.25d |  |
| 80 | New JT Internet Sales Center Operational | 2019-11-27 → 2019-12-04 (+7d) | 2019-11-27 → 2019-12-04 (+7d) | 0d → -2.25d |  |
| 81 | Move Final Group JT Call Center | 2019-11-27 → 2019-12-04 (+7d) | 2019-11-28 → 2019-12-05 (+7d) | 0d → -2.25d |  |
| 82 | Move Final Group JT Internet Sales Center | 2019-11-28 → 2019-12-05 (+7d) | 2019-11-29 → 2019-12-06 (+7d) | 0d → -2.25d |  |
| 83 | Move Furniture and Equipment Complete | 2019-11-29 → 2019-12-06 (+7d) | 2019-11-29 → 2019-12-06 (+7d) | 0d → -2.25d |  |
| 84 | Move Complete | 2019-11-29 → 2019-12-06 (+7d) | 2019-11-29 → 2019-12-06 (+7d) | 0d → -2.25d |  |
| 85 | **JT Corporate Move Closeout** | 2019-11-29 → 2019-12-06 (+7d) | 2019-12-03 → 2019-12-10 (+7d) | 0d → -2.25d |  |
| 86 | Unpacking all areas | 2019-11-29 → 2019-12-06 (+7d) | 2019-12-03 → 2019-12-10 (+7d) | 0d → -2.25d |  |
| 87 | Company-Wide Meeting | 2019-12-03 → 2019-12-10 (+7d) | 2019-12-03 → 2019-12-10 (+7d) | 0d → -2.25d |  |
| 88 | Move Evaluation | 2019-12-02 → 2019-12-09 (+7d) | 2019-12-03 → 2019-12-10 (+7d) | 0.12d → -2.25d |  |
| 89 | Pay Movers | 2019-12-03 → 2019-12-10 (+7d) | 2019-12-03 → 2019-12-10 (+7d) | 0.12d → -2.25d |  |
| 90 | JT Corporate Move Closeout Complete | 2019-12-03 → 2019-12-10 (+7d) | 2019-12-03 → 2019-12-10 (+7d) | 0.12d → -2.25d |  |
| 91 | JT Corporate Move Complete | 2019-12-03 → 2019-12-06 (+3d) | 2019-12-03 → 2019-12-06 (+3d) | 0.12d → -2.25d | constraint finish no later than 2019-12-05 → finish no later than 2019-12-06 |
