# JT Corporate Move

How a schedule from MS Project changed from version to version. A marks actual dates.

## Version 1 (saved 2019-05-31, file JT Corporate Move Printing the Tracking Gantt.mpp)

| ID | WBS | Task | Duration | Start | Finish | Predecessors | Total float | Constraint |
| --- | --- | --- | --- | --- | --- | --- | --- | --- |
| 1 | 1 | **JT Move Status Meetings** | 10.12d | 2019-07-05 | 2019-07-19 |  | 97.38d |  |
| 2 |  | JT Move Status Meetings 1 | 1h | 2019-07-05 | 2019-07-05 |  | 107.38d | start no earlier than 2019-07-05 |
| 3 |  | JT Move Status Meetings 2 | 1h | 2019-07-12 | 2019-07-12 |  | 102.38d | start no earlier than 2019-07-12 |
| 4 |  | JT Move Status Meetings 3 | 1h | 2019-07-19 | 2019-07-19 |  | 97.38d | start no earlier than 2019-07-19 |
| 5 | 2 | **Planning the Move** | 49.38d | 2019-07-01 | 2019-09-09 |  | 2.62d |  |
| 6 |  | Identify Move Team Members | 2d | 2019-07-01 | 2019-07-02 |  | 2.62d |  |
| 7 |  | Plan Infastructure Upgrades | 2w | 2019-07-03 | 2019-07-17 | 6 | 2.62d |  |
| 8 |  | Plan IT Move | 2w | 2019-07-18 | 2019-07-31 | 7 | 2.62d |  |
| 9 |  | Plan Physical Move | 2w | 2019-07-22 | 2019-08-05 | 8FS-7.5% | 2.62d |  |
| 10 |  | Plan for Continous Operations During the Move | 4d | 2019-08-05 | 2019-08-09 | 9 | 2.62d |  |
| 11 |  | Obtain Estimates from Moving Services | 1w | 2019-08-09 | 2019-08-16 | 10 | 2.62d |  |
| 12 |  | Interview and Select Movers | 1w | 2019-08-16 | 2019-08-23 | 11 | 2.62d |  |
| 13 |  | Obtain Estimates from IT Installation Companies | 1w | 2019-08-16 | 2019-08-23 | 11 | 2.62d |  |
| 14 |  | Interview and Select IT Installation Company | 1w | 2019-08-23 | 2019-08-30 | 13, 12 | 2.62d |  |
| 15 |  | Order Boxes and Materials needed for the Move | 3h | 2019-08-30 | 2019-08-30 | 14 | 2.62d |  |
| 16 |  | Planning the Move Complete | 0d | 2019-08-30 | 2019-08-30 | 15 | 2.62d |  |
| 17 | 2.12 | **Communications** | 5.5d | 2019-08-30 | 2019-09-09 |  | 2.62d |  |
| 18 |  | Communicate Move Plan to Employees | 3d | 2019-08-30 | 2019-09-04 | 16 | 2.62d |  |
| 19 |  | Gather Feedback From Employees | 2d | 2019-09-04 | 2019-09-06 | 18 | 2.62d |  |
| 20 |  | Communicate Move Information to Suppliers | 2h | 2019-09-06 | 2019-09-09 | 19 | 2.62d |  |
| 21 |  | Communicate Move Information to Customers | 2h | 2019-09-09 | 2019-09-09 | 20 | 2.62d |  |
| 22 |  | Communications Complete | 0d | 2019-09-09 | 2019-09-09 | 21 | 2.62d |  |
| 23 | 3 | **JT Corporate Center Preparation** | 24d | 2019-09-09 | 2019-10-11 |  | 2.62d |  |
| 24 | 3.1 | **JT Call Center Refurbishing New Location** | 22d | 2019-09-09 | 2019-10-09 |  | 2.62d |  |
| 25 |  | Install Network Cables | 3d | 2019-09-09 | 2019-09-12 | 22 | 2.62d |  |
| 26 |  | Install TeleCommunication Lines | 1w | 2019-09-12 | 2019-09-19 | 25 | 4.62d |  |
| 27 |  | Paint the walls | 2d | 2019-09-19 | 2019-09-23 | 26 | 4.62d |  |
| 28 |  | Lay Carpet | 2d | 2019-09-24 | 2019-09-26 | 27FS+1ed | 4.62d |  |
| 29 |  | Install Partitions | 1d | 2019-09-26 | 2019-09-27 | 28 | 4.62d |  |
| 30 |  | Prepare Offices | 5d | 2019-09-27 | 2019-10-04 | 29 | 4.62d |  |
| 31 |  | Assemble Furniture | 2d | 2019-10-04 | 2019-10-08 | 30 | 4.62d |  |
| 32 |  | Hook up Computers | 1d | 2019-10-08 | 2019-10-09 | 31 | 4.62d |  |
| 33 |  | Hook up Phones | 1d | 2019-10-08 | 2019-10-09 | 32FF | 4.62d |  |
| 34 |  | JT Call Center Complete | 0d | 2019-10-09 | 2019-10-09 | 33 | 4.62d |  |
| 35 | 3.2 | **JT Internet Sales Center Refurbishing New Location** | 24d | 2019-09-09 | 2019-10-11 |  | 2.62d |  |
| 36 |  | Install Network Cables | 3d | 2019-09-09 | 2019-09-12 | 25SS | 2.62d |  |
| 37 |  | Install TeleCommunication Lines | 1w | 2019-09-12 | 2019-09-19 | 36 | 2.62d |  |
| 38 |  | Paint the walls | 2d | 2019-09-19 | 2019-09-23 | 37 | 2.62d |  |
| 39 |  | Lay Carpet | 2d | 2019-09-24 | 2019-09-26 | 38FS+1ed | 2.62d |  |
| 40 |  | Install Partitions | 1d | 2019-09-26 | 2019-09-27 | 39 | 2.62d |  |
| 41 |  | Prepare Offices | 5d | 2019-09-27 | 2019-10-04 | 40 | 2.62d |  |
| 42 |  | Assemble Furniture | 2d | 2019-10-04 | 2019-10-08 | 41 | 2.62d |  |
| 43 |  | Hook up Computers | 1d | 2019-10-08 | 2019-10-09 | 42 | 2.62d |  |
| 44 |  | Hook up Phones | 1d | 2019-10-08 | 2019-10-09 | 43FF | 2.62d |  |
| 45 |  | Move in Belongings | 2d | 2019-10-09 | 2019-10-11 | 44 | 2.62d |  |
| 46 |  | JT Internet Sales Center Complete | 0d | 2019-10-11 | 2019-10-11 | 45 | 2.62d |  |
| 47 | 3.3 | **JT Administration Offices Refurbishing New Location** | 24d | 2019-09-09 | 2019-10-11 |  | 2.62d |  |
| 48 |  | Install Network Cables | 3d | 2019-09-09 | 2019-09-12 | 36SS | 2.62d |  |
| 49 |  | Install TeleCommunication Lines | 1w | 2019-09-12 | 2019-09-19 | 48 | 2.62d |  |
| 50 |  | Paint the walls | 2d | 2019-09-19 | 2019-09-23 | 49 | 2.62d |  |
| 51 |  | Lay Carpet | 2d | 2019-09-24 | 2019-09-26 | 50FS+1ed | 2.62d |  |
| 52 |  | Install Partitions | 1d | 2019-09-26 | 2019-09-27 | 51 | 2.62d |  |
| 53 |  | Prepare Offices | 5d | 2019-09-27 | 2019-10-04 | 52 | 2.62d |  |
| 54 |  | Assemble Furniture | 2d | 2019-10-04 | 2019-10-08 | 53 | 2.62d |  |
| 55 |  | Hook up Computers | 1d | 2019-10-08 | 2019-10-09 | 54 | 2.62d |  |
| 56 |  | Hook up Phones | 1d | 2019-10-08 | 2019-10-09 | 55FF | 2.62d |  |
| 57 |  | Move in Belongings | 2d | 2019-10-09 | 2019-10-11 | 56 | 2.62d |  |
| 58 |  | JT Administrative Offices Complete | 0d | 2019-10-11 | 2019-10-11 | 57 | 2.62d |  |
| 59 |  | JT Offices Refurbishing Complete | 0d | 2019-10-11 | 2019-10-11 | 34, 46, 58 | 2.62d |  |
| 60 | 4 | **Moving** | 32.25d | 2019-10-16 | 2019-11-29 |  | 0d |  |
| 61 | 4.1 | **Packing** | 25.25d | 2019-10-16 | 2019-11-20 |  | 0d |  |
| 62 |  | Distribute Boxes to Employees | 3d | 2019-10-16 | 2019-10-18 | 59 | 0d | start no earlier than 2019-10-16 |
| 63 |  | Communicate Timetable and Packing Requirements to Employees | 1d | 2019-10-21 | 2019-10-21 | 62 | 0d |  |
| 64 |  | Tag Furniture and Equipment to Identify New Area Staging | 2w | 2019-10-22 | 2019-11-04 | 63 | 0d |  |
| 65 |  | Tag Computer Equipment to Identify New Are Staging | 2w | 2019-11-05 | 2019-11-18 | 64 | 0d |  |
| 66 |  | Packing Complete | 0d | 2019-11-18 | 2019-11-18 | 65 | 0d |  |
| 67 | 4.1.6 | **Final Moving Preperations** | 1.25d | 2019-11-19 | 2019-11-20 |  | 0d |  |
| 68 |  | Communicate Rotation Schedule to Insure Continous Operations | 3h | 2019-11-19 | 2019-11-19 | 66 | 0d |  |
| 69 |  | Walk-through to Double Chjeck Tagging of All Furniture and Equipment | 2h | 2019-11-19 | 2019-11-19 | 68 | 0d |  |
| 70 |  | Review Move Schedule with Team Leaders | 3h | 2019-11-19 | 2019-11-19 | 69 | 0d |  |

| ID | WBS | Task | Duration | Start | Finish | Predecessors | Total float | Constraint |
| --- | --- | --- | --- | --- | --- | --- | --- | --- |
| 71 |  | Review Move Schedule with Movers | 2h | 2019-11-20 | 2019-11-20 | 70 | 0d |  |
| 72 |  | Final Moving Preperations Complete | 0d | 2019-11-20 | 2019-11-20 | 71 | 0d |  |
| 73 | 4.2 | **Move Furniture and Equipment** | 7d | 2019-11-20 | 2019-11-29 |  | 0d |  |
| 74 |  | Move JT Administrative Offices | 2d | 2019-11-20 | 2019-11-22 | 72 | 0d |  |
| 75 |  | Move First Wave JT Call Center | 1d | 2019-11-22 | 2019-11-25 | 74 | 0d |  |
| 76 |  | Move First Wave JT Internet Sales Center | 1d | 2019-11-25 | 2019-11-26 | 75 | 0d |  |
| 77 |  | Setup New JT Call Center for Operations | 0.5d | 2019-11-26 | 2019-11-26 | 76 | 0d |  |
| 78 |  | Setup New JT Internet Sales Center for Operations | 0.5d | 2019-11-26 | 2019-11-27 | 77 | 0d |  |
| 79 |  | New JT Call Center Operational | 0d | 2019-11-27 | 2019-11-27 | 78 | 0d |  |
| 80 |  | New JT Internet Sales Center Operational | 0d | 2019-11-27 | 2019-11-27 | 79 | 0d |  |
| 81 |  | Move Final Group JT Call Center | 1d | 2019-11-27 | 2019-11-28 | 80 | 0d |  |
| 82 |  | Move Final Group JT Internet Sales Center | 1d | 2019-11-28 | 2019-11-29 | 81 | 0d |  |
| 83 |  | Move Furniture and Equipment Complete | 0d | 2019-11-29 | 2019-11-29 | 82 | 0d |  |
| 84 |  | Move Complete | 0d | 2019-11-29 | 2019-11-29 | 83 | 0d |  |
| 85 | 5 | **JT Corporate Move Closeout** | 2.25d | 2019-11-29 | 2019-12-03 |  | 0d |  |
| 86 |  | Unpacking all areas | 2d | 2019-11-29 | 2019-12-03 | 84 | 0d |  |
| 87 |  | Company-Wide Meeting | 2h | 2019-12-03 | 2019-12-03 | 86 | 0d |  |
| 88 |  | Move Evaluation | 0.5d | 2019-12-02 | 2019-12-03 | 87SF | 0.12d |  |
| 89 |  | Pay Movers | 1h | 2019-12-03 | 2019-12-03 | 88 | 0.12d |  |
| 90 |  | JT Corporate Move Closeout Complete | 0d | 2019-12-03 | 2019-12-03 | 89 | 0.12d |  |
| 91 |  | JT Corporate Move Complete | 0d | 2019-12-03 | 2019-12-03 | 90 | 0.12d | finish no later than 2019-12-05 |

## Version 2 (saved 2019-05-31, file JT Corporate Move Printing Dashboard Reports.mpp)

Last finish stays 2019-12-03. Complete tasks 0 → 16.

Changed:

| ID | Task | Start | Finish | Duration | Complete | Total float | Other |
| --- | --- | --- | --- | --- | --- | --- | --- |
| 5 | **Planning the Move** | 2019-07-01 → 2019-07-02 A (+1d) | 2019-09-09 → 2019-09-10 A (+1d) |  | 0% → 100% | 2.62d → none | baseline start 2019-07-01 → 2019-07-02; baseline finish 2019-09-09 → 2019-09-10 |
| 6 | Identify Move Team Members | 2019-07-01 → 2019-07-02 A (+1d) | 2019-07-02 → 2019-07-03 A (+1d) |  | 0% → 100% | 2.62d → none | baseline start 2019-07-01 → 2019-07-02; baseline finish 2019-07-02 → 2019-07-03 |
| 7 | Plan Infastructure Upgrades | 2019-07-03 → 2019-07-05 A (+2d) | 2019-07-17 → 2019-07-18 A (+1d) |  | 0% → 100% | 2.62d → none | baseline start 2019-07-03 → 2019-07-05; baseline finish 2019-07-17 → 2019-07-18 |
| 8 | Plan IT Move | 2019-07-18 → 2019-07-19 A (+1d) | 2019-07-31 → 2019-08-01 A (+1d) |  | 0% → 100% | 2.62d → none | baseline start 2019-07-18 → 2019-07-19; baseline finish 2019-07-31 → 2019-08-01 |
| 9 | Plan Physical Move | 2019-07-22 → 2019-07-23 A (+1d) | 2019-08-05 → 2019-08-06 A (+1d) |  | 0% → 100% | 2.62d → none | baseline start 2019-07-22 → 2019-07-23; baseline finish 2019-08-05 → 2019-08-06 |
| 10 | Plan for Continous Operations During the Move | 2019-08-05 → 2019-08-06 A (+1d) | 2019-08-09 → 2019-08-12 A (+3d) |  | 0% → 100% | 2.62d → none | baseline start 2019-08-05 → 2019-08-06; baseline finish 2019-08-09 → 2019-08-12 |
| 11 | Obtain Estimates from Moving Services | 2019-08-09 → 2019-08-12 A (+3d) | 2019-08-16 A |  | 0% → 100% | 2.62d → none | baseline start 2019-08-09 → 2019-08-12 |
| 12 | Interview and Select Movers | 2019-08-16 → 2019-08-19 A (+3d) | 2019-08-23 A |  | 0% → 100% | 2.62d → none | baseline start 2019-08-16 → 2019-08-19 |
| 13 | Obtain Estimates from IT Installation Companies | 2019-08-16 → 2019-08-19 A (+3d) | 2019-08-23 A |  | 0% → 100% | 2.62d → none | baseline start 2019-08-16 → 2019-08-19 |
| 14 | Interview and Select IT Installation Company | 2019-08-23 → 2019-08-26 A (+3d) | 2019-08-30 A |  | 0% → 100% | 2.62d → none | baseline start 2019-08-23 → 2019-08-26 |
| 15 | Order Boxes and Materials needed for the Move | 2019-08-30 → 2019-09-02 A (+3d) | 2019-08-30 → 2019-09-02 A (+3d) |  | 0% → 100% | 2.62d → none | baseline start 2019-08-30 → 2019-09-02; baseline finish 2019-08-30 → 2019-09-02 |
| 16 | Planning the Move Complete | 2019-08-30 → 2019-09-02 A (+3d) | 2019-08-30 → 2019-09-02 A (+3d) |  | 0% → 100% | 2.62d → none | baseline start 2019-08-30 → 2019-09-02; baseline finish 2019-08-30 → 2019-09-02 |
| 17 | **Communications** | 2019-08-30 → 2019-09-02 A (+3d) | 2019-09-09 → 2019-09-10 A (+1d) | 5.5d → 6.38d | 0% → 100% | 2.62d → none | baseline start 2019-08-30 → 2019-09-02; baseline finish 2019-09-09 → 2019-09-10 |
| 18 | Communicate Move Plan to Employees | 2019-08-30 → 2019-09-02 A (+3d) | 2019-09-04 A |  | 0% → 100% | 2.62d → none | baseline start 2019-08-30 → 2019-09-02 |
| 19 | Gather Feedback From Employees | 2019-09-04 → 2019-09-05 A (+1d) | 2019-09-06 → 2019-09-09 A (+3d) |  | 0% → 100% | 2.62d → none | baseline start 2019-09-04 → 2019-09-05; baseline finish 2019-09-06 → 2019-09-09 |
| 20 | Communicate Move Information to Suppliers | 2019-09-06 → 2019-09-09 A (+3d) | 2019-09-09 A |  | 0% → 100% | 2.62d → none | baseline start 2019-09-06 → 2019-09-09 |
| 21 | Communicate Move Information to Customers | 2019-09-09 → 2019-09-10 A (+1d) | 2019-09-09 → 2019-09-10 A (+1d) |  | 0% → 100% | 2.62d → none | baseline start 2019-09-09 → 2019-09-10; baseline finish 2019-09-09 → 2019-09-10 |
| 22 | Communications Complete | 2019-09-09 → 2019-09-10 A (+1d) | 2019-09-09 → 2019-09-10 A (+1d) |  | 0% → 100% | 2.62d → none | baseline start 2019-09-09 → 2019-09-10; baseline finish 2019-09-09 → 2019-09-10 |
| 23 | **JT Corporate Center Preparation** | 2019-09-09 → 2019-09-10 (+1d) | 2019-10-11 → 2019-10-14 (+3d) |  |  | 2.62d → 1.62d | baseline start 2019-09-09 → 2019-09-10; baseline finish 2019-10-11 → 2019-10-14 |
| 24 | **JT Call Center Refurbishing New Location** | 2019-09-09 → 2019-09-10 (+1d) | 2019-10-09 → 2019-10-10 (+1d) |  |  | 2.62d → 1.62d | baseline start 2019-09-09 → 2019-09-10; baseline finish 2019-10-09 → 2019-10-10 |
| 25 | Install Network Cables | 2019-09-09 → 2019-09-10 (+1d) | 2019-09-12 → 2019-09-13 (+1d) |  |  | 2.62d → 1.62d | baseline start 2019-09-09 → 2019-09-10; baseline finish 2019-09-12 → 2019-09-13 |
| 26 | Install TeleCommunication Lines | 2019-09-12 → 2019-09-13 (+1d) | 2019-09-19 → 2019-09-20 (+1d) |  |  | 4.62d → 3.62d | baseline start 2019-09-12 → 2019-09-13; baseline finish 2019-09-19 → 2019-09-20 |
| 27 | Paint the walls | 2019-09-19 → 2019-09-20 (+1d) | 2019-09-23 → 2019-09-24 (+1d) |  |  | 4.62d → 3.62d | baseline start 2019-09-19 → 2019-09-20; baseline finish 2019-09-23 → 2019-09-24 |
| 28 | Lay Carpet | 2019-09-24 → 2019-09-25 (+1d) | 2019-09-26 → 2019-09-27 (+1d) |  |  | 4.62d → 3.62d | baseline start 2019-09-24 → 2019-09-25; baseline finish 2019-09-26 → 2019-09-27 |
| 29 | Install Partitions | 2019-09-26 → 2019-09-27 (+1d) | 2019-09-27 → 2019-09-30 (+3d) |  |  | 4.62d → 3.62d | baseline start 2019-09-26 → 2019-09-27; baseline finish 2019-09-27 → 2019-09-30 |
| 30 | Prepare Offices | 2019-09-27 → 2019-09-30 (+3d) | 2019-10-04 → 2019-10-07 (+3d) |  |  | 4.62d → 3.62d | baseline start 2019-09-27 → 2019-09-30; baseline finish 2019-10-04 → 2019-10-07 |
| 31 | Assemble Furniture | 2019-10-04 → 2019-10-07 (+3d) | 2019-10-08 → 2019-10-09 (+1d) |  |  | 4.62d → 3.62d | baseline start 2019-10-04 → 2019-10-07; baseline finish 2019-10-08 → 2019-10-09 |
| 32 | Hook up Computers | 2019-10-08 → 2019-10-09 (+1d) | 2019-10-09 → 2019-10-10 (+1d) |  |  | 4.62d → 3.62d | baseline start 2019-10-08 → 2019-10-09; baseline finish 2019-10-09 → 2019-10-10 |
| 33 | Hook up Phones | 2019-10-08 → 2019-10-09 (+1d) | 2019-10-09 → 2019-10-10 (+1d) |  |  | 4.62d → 3.62d | baseline start 2019-10-08 → 2019-10-09; baseline finish 2019-10-09 → 2019-10-10 |
| 34 | JT Call Center Complete | 2019-10-09 → 2019-10-10 (+1d) | 2019-10-09 → 2019-10-10 (+1d) |  |  | 4.62d → 3.62d | baseline start 2019-10-09 → 2019-10-10; baseline finish 2019-10-09 → 2019-10-10 |
| 35 | **JT Internet Sales Center Refurbishing New Location** | 2019-09-09 → 2019-09-10 (+1d) | 2019-10-11 → 2019-10-14 (+3d) |  |  | 2.62d → 1.62d | baseline start 2019-09-09 → 2019-09-10; baseline finish 2019-10-11 → 2019-10-14 |
| 36 | Install Network Cables | 2019-09-09 → 2019-09-10 (+1d) | 2019-09-12 → 2019-09-13 (+1d) |  |  | 2.62d → 1.62d | baseline start 2019-09-09 → 2019-09-10; baseline finish 2019-09-12 → 2019-09-13 |
| 37 | Install TeleCommunication Lines | 2019-09-12 → 2019-09-13 (+1d) | 2019-09-19 → 2019-09-20 (+1d) |  |  | 2.62d → 1.62d | baseline start 2019-09-12 → 2019-09-13; baseline finish 2019-09-19 → 2019-09-20 |
| 38 | Paint the walls | 2019-09-19 → 2019-09-20 (+1d) | 2019-09-23 → 2019-09-24 (+1d) |  |  | 2.62d → 1.62d | baseline start 2019-09-19 → 2019-09-20; baseline finish 2019-09-23 → 2019-09-24 |
| 39 | Lay Carpet | 2019-09-24 → 2019-09-25 (+1d) | 2019-09-26 → 2019-09-27 (+1d) |  |  | 2.62d → 1.62d | baseline start 2019-09-24 → 2019-09-25; baseline finish 2019-09-26 → 2019-09-27 |
| 40 | Install Partitions | 2019-09-26 → 2019-09-27 (+1d) | 2019-09-27 → 2019-09-30 (+3d) |  |  | 2.62d → 1.62d | baseline start 2019-09-26 → 2019-09-27; baseline finish 2019-09-27 → 2019-09-30 |
| 41 | Prepare Offices | 2019-09-27 → 2019-09-30 (+3d) | 2019-10-04 → 2019-10-07 (+3d) |  |  | 2.62d → 1.62d | baseline start 2019-09-27 → 2019-09-30; baseline finish 2019-10-04 → 2019-10-07 |
| 42 | Assemble Furniture | 2019-10-04 → 2019-10-07 (+3d) | 2019-10-08 → 2019-10-09 (+1d) |  |  | 2.62d → 1.62d | baseline start 2019-10-04 → 2019-10-07; baseline finish 2019-10-08 → 2019-10-09 |
| 43 | Hook up Computers | 2019-10-08 → 2019-10-09 (+1d) | 2019-10-09 → 2019-10-10 (+1d) |  |  | 2.62d → 1.62d | baseline start 2019-10-08 → 2019-10-09; baseline finish 2019-10-09 → 2019-10-10 |
| 44 | Hook up Phones | 2019-10-08 → 2019-10-09 (+1d) | 2019-10-09 → 2019-10-10 (+1d) |  |  | 2.62d → 1.62d | baseline start 2019-10-08 → 2019-10-09; baseline finish 2019-10-09 → 2019-10-10 |
| 45 | Move in Belongings | 2019-10-09 → 2019-10-10 (+1d) | 2019-10-11 → 2019-10-14 (+3d) |  |  | 2.62d → 1.62d | baseline start 2019-10-09 → 2019-10-10; baseline finish 2019-10-11 → 2019-10-14 |
| 46 | JT Internet Sales Center Complete | 2019-10-11 → 2019-10-14 (+3d) | 2019-10-11 → 2019-10-14 (+3d) |  |  | 2.62d → 1.62d | baseline start 2019-10-11 → 2019-10-14; baseline finish 2019-10-11 → 2019-10-14 |
| 47 | **JT Administration Offices Refurbishing New Location** | 2019-09-09 → 2019-09-10 (+1d) | 2019-10-11 → 2019-10-14 (+3d) |  |  | 2.62d → 1.62d | baseline start 2019-09-09 → 2019-09-10; baseline finish 2019-10-11 → 2019-10-14 |
| 48 | Install Network Cables | 2019-09-09 → 2019-09-10 (+1d) | 2019-09-12 → 2019-09-13 (+1d) |  |  | 2.62d → 1.62d | baseline start 2019-09-09 → 2019-09-10; baseline finish 2019-09-12 → 2019-09-13 |
| 49 | Install TeleCommunication Lines | 2019-09-12 → 2019-09-13 (+1d) | 2019-09-19 → 2019-09-20 (+1d) |  |  | 2.62d → 1.62d | baseline start 2019-09-12 → 2019-09-13; baseline finish 2019-09-19 → 2019-09-20 |
| 50 | Paint the walls | 2019-09-19 → 2019-09-20 (+1d) | 2019-09-23 → 2019-09-24 (+1d) |  |  | 2.62d → 1.62d | baseline start 2019-09-19 → 2019-09-20; baseline finish 2019-09-23 → 2019-09-24 |
| 51 | Lay Carpet | 2019-09-24 → 2019-09-25 (+1d) | 2019-09-26 → 2019-09-27 (+1d) |  |  | 2.62d → 1.62d | baseline start 2019-09-24 → 2019-09-25; baseline finish 2019-09-26 → 2019-09-27 |
| 52 | Install Partitions | 2019-09-26 → 2019-09-27 (+1d) | 2019-09-27 → 2019-09-30 (+3d) |  |  | 2.62d → 1.62d | baseline start 2019-09-26 → 2019-09-27; baseline finish 2019-09-27 → 2019-09-30 |
| 53 | Prepare Offices | 2019-09-27 → 2019-09-30 (+3d) | 2019-10-04 → 2019-10-07 (+3d) |  |  | 2.62d → 1.62d | baseline start 2019-09-27 → 2019-09-30; baseline finish 2019-10-04 → 2019-10-07 |
| 54 | Assemble Furniture | 2019-10-04 → 2019-10-07 (+3d) | 2019-10-08 → 2019-10-09 (+1d) |  |  | 2.62d → 1.62d | baseline start 2019-10-04 → 2019-10-07; baseline finish 2019-10-08 → 2019-10-09 |
| 55 | Hook up Computers | 2019-10-08 → 2019-10-09 (+1d) | 2019-10-09 → 2019-10-10 (+1d) |  |  | 2.62d → 1.62d | baseline start 2019-10-08 → 2019-10-09; baseline finish 2019-10-09 → 2019-10-10 |
| 56 | Hook up Phones | 2019-10-08 → 2019-10-09 (+1d) | 2019-10-09 → 2019-10-10 (+1d) |  |  | 2.62d → 1.62d | baseline start 2019-10-08 → 2019-10-09; baseline finish 2019-10-09 → 2019-10-10 |
| 57 | Move in Belongings | 2019-10-09 → 2019-10-10 (+1d) | 2019-10-11 → 2019-10-14 (+3d) |  |  | 2.62d → 1.62d | baseline start 2019-10-09 → 2019-10-10; baseline finish 2019-10-11 → 2019-10-14 |
| 58 | JT Administrative Offices Complete | 2019-10-11 → 2019-10-14 (+3d) | 2019-10-11 → 2019-10-14 (+3d) |  |  | 2.62d → 1.62d | baseline start 2019-10-11 → 2019-10-14; baseline finish 2019-10-11 → 2019-10-14 |
| 59 | JT Offices Refurbishing Complete | 2019-10-11 → 2019-10-14 (+3d) | 2019-10-11 → 2019-10-14 (+3d) |  |  | 2.62d → 1.62d | baseline start 2019-10-11 → 2019-10-14; baseline finish 2019-10-11 → 2019-10-14 |
