# Finish New Office Workspace.mpp

How a schedule from MS Project changed from version to version. A marks actual dates.

## Version 1 (saved 2019-05-23, file JT New Workspace 3.mpp)

| ID | WBS | Task | Duration | Start | Finish | Predecessors | Complete | Total float |
| --- | --- | --- | --- | --- | --- | --- | --- | --- |
| 1 | 1 | **Office Number 101** | 18d | 2019-07-02 A | 2019-07-26 |  | 13% | 0d |
| 2 |  | Paint the walls | 2d | 2019-07-02 A | 2019-07-03 A |  | 100% |  |
| 3 |  | Install Partitions | 1d | 2019-07-05 A | 2019-07-05 | 2 | 25% | 0d |
| 4 |  | Install Network Cables | 3d | 2019-07-08 | 2019-07-10 | 3 |  | 0d |
| 5 |  | Lay Carpet | 2d | 2019-07-11 | 2019-07-12 | 4 |  | 0d |
| 6 |  | Prepare Offices | 5d | 2019-07-15 | 2019-07-19 | 5 |  | 0d |
| 7 |  | Assemble Furniture | 2d | 2019-07-22 | 2019-07-23 | 6 |  | 0d |
| 8 |  | Hook up Computers | 1d | 2019-07-24 | 2019-07-24 | 7 |  | 0d |
| 9 |  | Move in Belongings | 2d | 2019-07-25 | 2019-07-26 | 8 |  | 0d |
| 10 |  | Office 101 Complete | 0d | 2019-07-26 | 2019-07-26 | 9 |  | 0d |

## Version 2 (saved 2019-05-23, file JT New Workspace.mpp)

Last finish 2019-07-26 → 2019-07-29 (+3d). Complete tasks 1 → 0.

Added:

| ID | Task | Duration | Start | Finish | Predecessors |
| --- | --- | --- | --- | --- | --- |
| 11 | **Office Number 102** | 18d | 2019-07-02 | 2019-07-29 |  |
| 12 | Paint the walls | 0d | 2019-07-02 | 2019-07-02 | 2 |
| 13 | Install Partitions | 1d | 2019-07-03 | 2019-07-03 | 12 |
| 14 | Install Network Cables | 3d | 2019-07-05 | 2019-07-09 | 13 |
| 15 | Lay Carpet | 2d | 2019-07-10 | 2019-07-11 | 14 |
| 16 | Prepare Offices | 5d | 2019-07-12 | 2019-07-18 | 15 |
| 17 | Assemble Furniture | 2d | 2019-07-19 | 2019-07-22 | 16 |
| 18 | Hook up Computers | 1d | 2019-07-23 | 2019-07-23 | 17 |
| 19 | Move in Belongings | 2d | 2019-07-24 | 2019-07-25 | 18 |
| 20 | Office 102 Complete | 0d | 2019-07-25 | 2019-07-25 | 19 |
| 21 | **Office Number 103** | 18d | 2019-07-03 | 2019-07-29 |  |
| 22 | Paint the walls | 2d | 2019-07-03 | 2019-07-05 | 12 |
| 23 | Install Partitions | 1d | 2019-07-08 | 2019-07-08 | 22 |
| 24 | Install Network Cables | 3d | 2019-07-09 | 2019-07-11 | 23 |
| 25 | Lay Carpet | 2d | 2019-07-12 | 2019-07-15 | 24 |
| 26 | Prepare Offices | 5d | 2019-07-16 | 2019-07-22 | 25 |
| 27 | Assemble Furniture | 2d | 2019-07-23 | 2019-07-24 | 26 |
| 28 | Hook up Computers | 1d | 2019-07-25 | 2019-07-25 | 27 |
| 29 | Move in Belongings | 2d | 2019-07-26 | 2019-07-29 | 28 |
| 30 | Office 103 Complete | 0d | 2019-07-29 | 2019-07-29 | 29 |
| 31 | Finsih New Office Worspace Complete | 0d | 2019-07-29 | 2019-07-29 | 30, 10, 20 |

Changed:

| ID | Task | Start | Finish | Duration | Complete | Total float | Other |
| --- | --- | --- | --- | --- | --- | --- | --- |
| 1 | **Office Number 101** | 2019-07-02 A → 2019-07-01 (-1d) | 2019-07-26 → 2019-07-24 (-2d) | 18d → 17d | 13% → 0% |  | baseline start 2018-07-02 → none; baseline finish 2018-07-25 → none |
| 2 | Paint the walls | 2019-07-02 A → 2019-07-01 (-1d) | 2019-07-03 A → 2019-07-02 (-1d) |  | 100% → 0% | none → 0d | baseline start 2018-07-02 → none; baseline finish 2018-07-03 → none |
| 3 | Install Partitions | 2019-07-05 A → 2019-07-03 (-2d) | 2019-07-05 → 2019-07-03 (-2d) |  | 25% → 0% | 0d → 2d | baseline start 2018-07-04 → none; baseline finish 2018-07-04 → none |
| 4 | Install Network Cables | 2019-07-08 → 2019-07-04 (-4d) | 2019-07-10 → 2019-07-08 (-2d) |  |  | 0d → 2d | baseline start 2018-07-05 → none; baseline finish 2018-07-09 → none |
| 5 | Lay Carpet | 2019-07-11 → 2019-07-09 (-2d) | 2019-07-12 → 2019-07-10 (-2d) |  |  | 0d → 3d | baseline start 2018-07-10 → none; baseline finish 2018-07-11 → none |
| 6 | Prepare Offices | 2019-07-15 → 2019-07-11 (-4d) | 2019-07-19 → 2019-07-17 (-2d) |  |  | 0d → 3d | baseline start 2018-07-12 → none; baseline finish 2018-07-18 → none |
| 7 | Assemble Furniture | 2019-07-22 → 2019-07-18 (-4d) | 2019-07-23 → 2019-07-19 (-4d) |  |  | 0d → 3d | baseline start 2018-07-19 → none; baseline finish 2018-07-20 → none |
| 8 | Hook up Computers | 2019-07-24 → 2019-07-22 (-2d) | 2019-07-24 → 2019-07-22 (-2d) |  |  | 0d → 3d | baseline start 2018-07-23 → none; baseline finish 2018-07-23 → none |
| 9 | Move in Belongings | 2019-07-25 → 2019-07-23 (-2d) | 2019-07-26 → 2019-07-24 (-2d) |  |  | 0d → 3d | baseline start 2018-07-24 → none; baseline finish 2018-07-25 → none |
| 10 | Office 101 Complete | 2019-07-26 → 2019-07-24 (-2d) | 2019-07-26 → 2019-07-24 (-2d) |  |  | 0d → 3d | baseline start 2018-07-25 → none; baseline finish 2018-07-25 → none |

## Version 3 (saved 2019-05-23, file JT New Workspace 2.mpp)

Last finish 2019-07-29 → 2019-07-30 (+1d). Complete tasks 0 → 1.

Changed:

| ID | Task | Start | Finish | Duration | Complete | Total float | Other |
| --- | --- | --- | --- | --- | --- | --- | --- |
| 1 | **Office Number 101** | 2019-07-01 → 2019-07-02 A (+1d) | 2019-07-24 → 2019-07-26 (+2d) | 17d → 18d | 0% → 13% | 0d → 2d | baseline start none → 2018-07-02; baseline finish none → 2018-07-25 |
| 2 | Paint the walls | 2019-07-01 → 2019-07-02 A (+1d) | 2019-07-02 → 2019-07-03 A (+1d) |  | 0% → 100% | 0d → none | baseline start none → 2018-07-02; baseline finish none → 2018-07-03 |
| 3 | Install Partitions | 2019-07-03 → 2019-07-05 A (+2d) | 2019-07-03 → 2019-07-05 (+2d) |  | 0% → 25% |  | baseline start none → 2018-07-04; baseline finish none → 2018-07-04 |
| 4 | Install Network Cables | 2019-07-04 → 2019-07-08 (+4d) | 2019-07-08 → 2019-07-10 (+2d) |  |  |  | baseline start none → 2018-07-05; baseline finish none → 2018-07-09 |
| 5 | Lay Carpet | 2019-07-09 → 2019-07-11 (+2d) | 2019-07-10 → 2019-07-12 (+2d) |  |  | 3d → 2d | baseline start none → 2018-07-10; baseline finish none → 2018-07-11 |
| 6 | Prepare Offices | 2019-07-11 → 2019-07-15 (+4d) | 2019-07-17 → 2019-07-19 (+2d) |  |  | 3d → 2d | baseline start none → 2018-07-12; baseline finish none → 2018-07-18 |
| 7 | Assemble Furniture | 2019-07-18 → 2019-07-22 (+4d) | 2019-07-19 → 2019-07-23 (+4d) |  |  | 3d → 2d | baseline start none → 2018-07-19; baseline finish none → 2018-07-20 |
| 8 | Hook up Computers | 2019-07-22 → 2019-07-24 (+2d) | 2019-07-22 → 2019-07-24 (+2d) |  |  | 3d → 2d | baseline start none → 2018-07-23; baseline finish none → 2018-07-23 |
| 9 | Move in Belongings | 2019-07-23 → 2019-07-25 (+2d) | 2019-07-24 → 2019-07-26 (+2d) |  |  | 3d → 2d | baseline start none → 2018-07-24; baseline finish none → 2018-07-25 |
| 10 | Office 101 Complete | 2019-07-24 → 2019-07-26 (+2d) | 2019-07-24 → 2019-07-26 (+2d) |  |  | 3d → 2d | baseline start none → 2018-07-25; baseline finish none → 2018-07-25 |
| 11 | **Office Number 102** | 2019-07-02 → 2019-07-03 (+1d) | 2019-07-29 → 2019-07-30 (+1d) |  |  |  | baseline start none → 2018-07-05; baseline finish none → 2018-08-01 |
| 12 | Paint the walls | 2019-07-02 → 2019-07-03 (+1d) | 2019-07-02 → 2019-07-03 (+1d) |  |  |  | baseline start none → 2018-07-05; baseline finish none → 2018-07-06 |
| 13 | Install Partitions | 2019-07-03 → 2019-07-05 (+2d) | 2019-07-03 → 2019-07-05 (+2d) |  |  |  | baseline start none → 2018-07-09; baseline finish none → 2018-07-09 |
| 14 | Install Network Cables | 2019-07-05 → 2019-07-08 (+3d) | 2019-07-09 → 2019-07-10 (+1d) |  |  |  | baseline start none → 2018-07-10; baseline finish none → 2018-07-12 |
| 15 | Lay Carpet | 2019-07-10 → 2019-07-11 (+1d) | 2019-07-11 → 2019-07-12 (+1d) |  |  |  | baseline start none → 2018-07-13; baseline finish none → 2018-07-16 |
| 16 | Prepare Offices | 2019-07-12 → 2019-07-15 (+3d) | 2019-07-18 → 2019-07-19 (+1d) |  |  |  | baseline start none → 2018-07-17; baseline finish none → 2018-07-23 |
| 17 | Assemble Furniture | 2019-07-19 → 2019-07-22 (+3d) | 2019-07-22 → 2019-07-23 (+1d) |  |  |  | baseline start none → 2018-07-24; baseline finish none → 2018-07-25 |
| 18 | Hook up Computers | 2019-07-23 → 2019-07-24 (+1d) | 2019-07-23 → 2019-07-24 (+1d) |  |  |  | baseline start none → 2018-07-26; baseline finish none → 2018-07-26 |
| 19 | Move in Belongings | 2019-07-24 → 2019-07-25 (+1d) | 2019-07-25 → 2019-07-26 (+1d) |  |  |  | baseline start none → 2018-07-27; baseline finish none → 2018-07-30 |
| 20 | Office 102 Complete | 2019-07-25 → 2019-07-26 (+1d) | 2019-07-25 → 2019-07-26 (+1d) |  |  |  | baseline start none → 2018-07-30; baseline finish none → 2018-07-30 |
| 21 | **Office Number 103** | 2019-07-03 → 2019-07-05 (+2d) | 2019-07-29 → 2019-07-30 (+1d) |  |  |  | baseline start none → 2018-07-09; baseline finish none → 2018-08-01 |
| 22 | Paint the walls | 2019-07-03 → 2019-07-05 (+2d) | 2019-07-05 → 2019-07-08 (+3d) |  |  |  | baseline start none → 2018-07-09; baseline finish none → 2018-07-10 |
| 23 | Install Partitions | 2019-07-08 → 2019-07-09 (+1d) | 2019-07-08 → 2019-07-09 (+1d) |  |  |  | baseline start none → 2018-07-11; baseline finish none → 2018-07-11 |
| 24 | Install Network Cables | 2019-07-09 → 2019-07-10 (+1d) | 2019-07-11 → 2019-07-12 (+1d) |  |  |  | baseline start none → 2018-07-12; baseline finish none → 2018-07-16 |
| 25 | Lay Carpet | 2019-07-12 → 2019-07-15 (+3d) | 2019-07-15 → 2019-07-16 (+1d) |  |  |  | baseline start none → 2018-07-17; baseline finish none → 2018-07-18 |
| 26 | Prepare Offices | 2019-07-16 → 2019-07-17 (+1d) | 2019-07-22 → 2019-07-23 (+1d) |  |  |  | baseline start none → 2018-07-19; baseline finish none → 2018-07-25 |
| 27 | Assemble Furniture | 2019-07-23 → 2019-07-24 (+1d) | 2019-07-24 → 2019-07-25 (+1d) |  |  |  | baseline start none → 2018-07-26; baseline finish none → 2018-07-27 |
| 28 | Hook up Computers | 2019-07-25 → 2019-07-26 (+1d) | 2019-07-25 → 2019-07-26 (+1d) |  |  |  | baseline start none → 2018-07-30; baseline finish none → 2018-07-30 |
| 29 | Move in Belongings | 2019-07-26 → 2019-07-29 (+3d) | 2019-07-29 → 2019-07-30 (+1d) |  |  |  | baseline start none → 2018-07-31; baseline finish none → 2018-08-01 |
| 30 | Office 103 Complete | 2019-07-29 → 2019-07-30 (+1d) | 2019-07-29 → 2019-07-30 (+1d) |  |  |  | baseline start none → 2018-08-01; baseline finish none → 2018-08-01 |
| 31 | Finsih New Office Worspace Complete | 2019-07-29 → 2019-07-30 (+1d) | 2019-07-29 → 2019-07-30 (+1d) |  |  |  | baseline start none → 2018-08-01; baseline finish none → 2018-08-01 |

## Version 4 (saved 2019-05-23, file JT New Workspace 4.mpp)

Last finish 2019-07-30 → 2019-07-26 (-4d).

Added:

| ID | Task | Duration | Start | Finish |
| --- | --- | --- | --- | --- |
| 11 | Office Number 102 | 1d? | 2019-07-01 | 2019-07-01 |

Removed: 11 Office Number 102; 12 Paint the walls; 13 Install Partitions; 14 Install Network Cables; 15 Lay Carpet; 16 Prepare Offices; 17 Assemble Furniture; 18 Hook up Computers; 19 Move in Belongings; 20 Office 102 Complete; 21 Office Number 103; 22 Paint the walls; 23 Install Partitions; 24 Install Network Cables; 25 Lay Carpet; 26 Prepare Offices; 27 Assemble Furniture; 28 Hook up Computers; 29 Move in Belongings; 30 Office 103 Complete; 31 Finsih New Office Worspace Complete

## Version 5 (saved 2019-05-23, file JT New Workspace 6.mpp)

Last finish stays 2019-07-26.

Added:

| ID | Task | Duration | Start | Finish |
| --- | --- | --- | --- | --- |
| 12 | Paint the walls | 2d | 2019-07-01 | 2019-07-02 |
| 13 | Lay Carpet | 2d | 2019-07-01 | 2019-07-02 |
| 14 | Install Partitions | 1d | 2019-07-01 | 2019-07-01 |
| 15 | Install Network Cables | 3d | 2019-07-01 | 2019-07-03 |
| 16 | Hook up Computers | 1d | 2019-07-01 | 2019-07-01 |
| 17 | Move in Belongings | 2d | 2019-07-01 | 2019-07-02 |
| 18 | Prepare Offices | 5d | 2019-07-01 | 2019-07-08 |
| 19 | Assemble Furniture | 2d | 2019-07-01 | 2019-07-02 |
| 20 | Office 102 Complete | 0d | 2019-07-01 | 2019-07-01 |

Changed:

| ID | Task | Finish | Duration | Total float |
| --- | --- | --- | --- | --- |
| 11 | **Office Number 102** | 2019-07-01 → 2019-07-08 (+7d) | 1d? → 5d | 18d → 14d |

## Version 6 (saved 2019-05-23, file JT New Workspace 5.mpp)

Last finish stays 2019-07-26.

Removed: 20 Office 102 Complete

## Version 7 (saved 2019-05-23, file JT New Workspace 7.mpp)

Last finish stays 2019-07-26.

Added:

| ID | Task | Duration | Start | Finish |
| --- | --- | --- | --- | --- |
| 15 | Install New Baseboard | 1d | 2019-07-01 | 2019-07-01 |
| 21 | Office 102 Complete | 0d | 2019-07-01 | 2019-07-01 |

## Version 8 (saved 2019-05-23, file JT New Workspace 9.mpp)

Last finish stays 2019-07-26.

Removed: 15 Install New Baseboard

## Version 9 (saved 2019-05-23, file JT New Workspace 10.mpp)

Last finish stays 2019-07-26.

Added:

| ID | Task | Duration | Start | Finish | Constraint |
| --- | --- | --- | --- | --- | --- |
| 1 | **JT Move Status Meetings** | 10.12d | 2019-07-05 | 2019-07-19 |  |
| 2 | JT Move Status Meetings 1 | 1h | 2019-07-05 | 2019-07-05 | start no earlier than 2019-07-05 |
| 3 | JT Move Status Meetings 2 | 1h | 2019-07-12 | 2019-07-12 | start no earlier than 2019-07-12 |
| 4 | JT Move Status Meetings 3 | 1h | 2019-07-19 | 2019-07-19 | start no earlier than 2019-07-19 |
