# Asbestos Abatement Encapsulation JT Processing Facilities

How a schedule from MS Project changed from version to version. A marks actual dates.

## Version 1 (data date 2018-12-18, saved 2019-06-26, file Working With Project Data Synthesis - JT Asbestos Abatement Processing Facility.mpp)

| ID | WBS | Task | Duration | Start | Finish | Predecessors | Complete |
| --- | --- | --- | --- | --- | --- | --- | --- |
| 1 |  | Notice to Proceed from JT CEO, JT CFO | 5d | 2018-11-01 A | 2018-11-07 A |  | 100% |
| 2 |  | Project Award to High (best) Bid Contractor | 0d | 2018-11-07 A | 2018-11-07 A | 1 | 100% |
| 3 | 3 | **General Requirements (Start-up)** | 70d | 2018-11-01 A | 2019-02-06 A |  | 100% |
| 4 |  | General Requirements (Start-up) Insurance & Bonds | 1d | 2018-11-08 A | 2018-11-08 A | 2 | 100% |
| 5 |  | Post Award Site Survey | 5d | 2018-11-09 A | 2018-11-15 A | 4 | 100% |
| 6 |  | DRAFT Work Plan | 35d | 2018-11-01 A | 2018-12-19 A | 5FF | 100% |
| 7 |  | EPA Review | 14d | 2018-11-01 A | 2018-11-20 A |  | 100% |
| 8 |  | Finalize Final Work Plan | 19d | 2018-11-16 A | 2018-12-10 A | 7FS-3d | 100% |
| 9 |  | Submit Final Work Plan | 1d | 2018-12-11 A | 2018-12-11 A | 8 | 100% |
| 10 |  | EPA Approval | 11d | 2018-12-17 A | 2018-12-31 A | 9 | 100% |
| 11 |  | Local Government Review/Approval of Local Submittals | 10d | 2019-01-01 A | 2019-01-14 A | 10 | 100% |
| 12 |  | Procure/Fabrication/Transportation/Arrival of Local Equipment | 10d | 2019-01-15 A | 2019-01-28 A | 11 | 100% |
| 13 |  | General Requirements (Start-up) Administration Complete | 0d | 2019-01-28 A | 2019-01-28 A | 12 | 100% |
| 14 | 3.11 | **General Requirements (Start-up) Temporary Facilities & Mobilization** | 7d | 2019-01-29 A | 2019-02-06 A |  | 100% |
| 15 |  | Temporary Staging Facilities/Laydown Yard | 4d | 2019-01-29 A | 2019-02-01 A | 13 | 100% |
| 16 |  | Temporary Site Access & Parking | 2d | 2019-01-29 A | 2019-01-30 A | 15SS | 100% |
| 17 |  | General Requirements (Start-up) Permits | 7d | 2019-01-29 A | 2019-02-06 A | 16SS | 100% |
| 18 |  | General Requirements (Start-up) Temporary Facilities & Mobilization Complete | 0d | 2019-02-06 A | 2019-02-06 A | 17 | 100% |
| 19 |  | General Requirements (Start-up) Complete | 0d | 2019-02-06 A | 2019-02-06 A | 18 | 100% |
| 20 |  | Field Project Management & Supervision | 124d | 2019-02-04 A | 2019-07-26 A | 15 | 100% |
| 21 | 5 | **Field Work- Asbestos Inspection, Abatement and Encapsulation** | 85d | 2019-02-07 A | 2019-06-05 A |  | 100% |
| 22 |  | Abate and Encapsulate Processing Facility 1 | 30d | 2019-02-07 A | 2019-03-20 A | 19 | 100% |
| 23 |  | Mobilization to Processing Facility 2 | 5d | 2019-03-21 A | 2019-03-27 A | 22 | 100% |
| 24 |  | Abate and Encapsulate Processing Facility 2 | 50d | 2019-03-28 A | 2019-06-05 A | 23 | 100% |
| 25 |  | Field Work- Asbestos Inspection, Abatement and Encapsulation Complete | 0d | 2019-06-05 A | 2019-06-05 A | 24 | 100% |
| 26 | 6 | **Project Closeout** | 42d | 2019-06-06 A | 2019-08-05 A |  | 100% |
| 27 |  | Demobilization/Cleanup/Restoration | 2d | 2019-06-06 A | 2019-06-07 A | 25 | 100% |
| 28 |  | Post Fieldwork Inspection / Documentation | 10d | 2019-06-10 A | 2019-06-21 A | 27 | 100% |
| 29 |  | Final Report | 30d | 2019-06-24 A | 2019-08-05 A | 28 | 100% |
| 30 |  | Closeout Complete | 0d | 2019-08-05 A | 2019-08-05 A | 29 | 100% |
| 31 |  | Asbestos Abatement Encapsulation JT Processing Facilities Complete | 0d | 2019-08-05 A | 2019-08-05 A | 30, 20 | 100% |

## Version 2 (data date 2019-08-05, saved 2019-06-26, file JT Asbestos Abatement Processing Facility.mpp)

Last finish 2019-08-05 → 2019-07-31 (-5d). Complete tasks 27 → 0.

Changed:

| ID | Task | Start | Finish | Duration | Complete | Total float | Other |
| --- | --- | --- | --- | --- | --- | --- | --- |
| 1 | Notice to Proceed from JT CEO, JT CFO | 2018-11-01 A → 2018-11-01 | 2018-11-07 A → 2018-11-07 |  | 100% → 0% | none → 183d | baseline start 2018-11-01 → none; baseline finish 2018-11-07 → none |
| 2 | Project Award to High (best) Bid Contractor | 2018-11-07 A → 2018-11-07 | 2018-11-07 A → 2018-11-07 |  | 100% → 0% | none → 183d | baseline start 2018-11-07 → none; baseline finish 2018-11-07 → none |
| 3 | **General Requirements (Start-up)** | 2018-11-01 A → 2018-11-01 | 2019-02-06 A → 2019-02-01 (-5d) | 70d → 67d | 100% → 0% | none → -3d | baseline start 2018-11-01 → none; baseline finish 2019-01-28 → none |
| 4 | General Requirements (Start-up) Insurance & Bonds | 2018-11-08 A → 2018-11-08 | 2018-11-08 A → 2018-11-08 |  | 100% → 0% | none → 183d | baseline start 2018-11-08 → none; baseline finish 2018-11-08 → none |
| 5 | Post Award Site Survey | 2018-11-09 A → 2018-11-09 | 2018-11-15 A → 2018-11-15 |  | 100% → 0% | none → 183d | baseline start 2018-11-09 → none; baseline finish 2018-11-15 → none |
| 6 | DRAFT Work Plan | 2018-11-01 A → 2018-11-01 | 2018-12-19 A → 2018-12-19 |  | 100% → 0% | none → 159d | baseline start 2018-11-01 → none; baseline finish 2018-12-12 → none |
| 7 | EPA Review | 2018-11-01 A → 2018-11-01 | 2018-11-20 A → 2018-11-20 |  | 100% → 0% | none → -3d | baseline start 2018-11-01 → none; baseline finish 2018-11-20 → none |
| 8 | Finalize Final Work Plan | 2018-11-16 A → 2018-11-16 | 2018-12-10 A → 2018-12-10 |  | 100% → 0% | none → -3d | baseline start 2018-11-16 → none; baseline finish 2018-12-05 → none |
| 9 | Submit Final Work Plan | 2018-12-11 A → 2018-12-11 | 2018-12-11 A → 2018-12-11 |  | 100% → 0% | none → -3d | baseline start 2018-12-06 → none; baseline finish 2018-12-06 → none |
| 10 | EPA Approval | 2018-12-17 A → 2018-12-12 (-5d) | 2018-12-31 A → 2018-12-26 (-5d) |  | 100% → 0% | none → 0d | baseline start 2018-12-07 → none; baseline finish 2018-12-20 → none |
| 11 | Local Government Review/Approval of Local Submittals | 2019-01-01 A → 2018-12-27 (-5d) | 2019-01-14 A → 2019-01-09 (-5d) |  | 100% → 0% | none → 0d | baseline start 2018-12-21 → none; baseline finish 2019-01-03 → none |
| 12 | Procure/Fabrication/Transportation/Arrival of Local Equipment | 2019-01-15 A → 2019-01-10 (-5d) | 2019-01-28 A → 2019-01-23 (-5d) |  | 100% → 0% | none → 0d | baseline start 2019-01-04 → none; baseline finish 2019-01-17 → none |
| 13 | General Requirements (Start-up) Administration Complete | 2019-01-28 A → 2019-01-23 (-5d) | 2019-01-28 A → 2019-01-23 (-5d) |  | 100% → 0% | none → 0d | baseline start 2019-01-17 → none; baseline finish 2019-01-17 → none |
| 14 | **General Requirements (Start-up) Temporary Facilities & Mobilization** | 2019-01-29 A → 2019-01-24 (-5d) | 2019-02-06 A → 2019-02-01 (-5d) |  | 100% → 0% | none → 0d | baseline start 2019-01-18 → none; baseline finish 2019-01-28 → none |
| 15 | Temporary Staging Facilities/Laydown Yard | 2019-01-29 A → 2019-01-24 (-5d) | 2019-02-01 A → 2019-01-29 (-3d) |  | 100% → 0% | none → 0d | baseline start 2019-01-18 → none; baseline finish 2019-01-23 → none |
| 16 | Temporary Site Access & Parking | 2019-01-29 A → 2019-01-24 (-5d) | 2019-01-30 A → 2019-01-25 (-5d) |  | 100% → 0% | none → 0d | baseline start 2019-01-18 → none; baseline finish 2019-01-21 → none |
| 17 | General Requirements (Start-up) Permits | 2019-01-29 A → 2019-01-24 (-5d) | 2019-02-06 A → 2019-02-01 (-5d) |  | 100% → 0% | none → 0d | baseline start 2019-01-18 → none; baseline finish 2019-01-28 → none |
| 18 | General Requirements (Start-up) Temporary Facilities & Mobilization Complete | 2019-02-06 A → 2019-02-01 (-5d) | 2019-02-06 A → 2019-02-01 (-5d) |  | 100% → 0% | none → 0d | baseline start 2019-01-28 → none; baseline finish 2019-01-28 → none |
| 19 | General Requirements (Start-up) Complete | 2019-02-06 A → 2019-02-01 (-5d) | 2019-02-06 A → 2019-02-01 (-5d) |  | 100% → 0% | none → 0d | baseline start 2019-01-28 → none; baseline finish 2019-01-28 → none |
| 20 | Field Project Management & Supervision | 2019-02-04 A → 2019-01-30 (-5d) | 2019-07-26 A → 2019-07-23 (-3d) |  | 100% → 0% | none → 6d | baseline start 2019-01-24 → none; baseline finish 2019-07-17 → none |
| 21 | **Field Work- Asbestos Inspection, Abatement and Encapsulation** | 2019-02-07 A → 2019-02-04 (-3d) | 2019-06-05 A → 2019-05-31 (-5d) |  | 100% → 0% | none → 0d | baseline start 2019-01-29 → none; baseline finish 2019-05-27 → none |
| 22 | Abate and Encapsulate Processing Facility 1 | 2019-02-07 A → 2019-02-04 (-3d) | 2019-03-20 A → 2019-03-15 (-5d) |  | 100% → 0% | none → 0d | baseline start 2019-01-29 → none; baseline finish 2019-03-11 → none |
| 23 | Mobilization to Processing Facility 2 | 2019-03-21 A → 2019-03-18 (-3d) | 2019-03-27 A → 2019-03-22 (-5d) |  | 100% → 0% | none → 0d | baseline start 2019-03-12 → none; baseline finish 2019-03-18 → none |
| 24 | Abate and Encapsulate Processing Facility 2 | 2019-03-28 A → 2019-03-25 (-3d) | 2019-06-05 A → 2019-05-31 (-5d) |  | 100% → 0% | none → 0d | baseline start 2019-03-19 → none; baseline finish 2019-05-27 → none |
| 25 | Field Work- Asbestos Inspection, Abatement and Encapsulation Complete | 2019-06-05 A → 2019-05-31 (-5d) | 2019-06-05 A → 2019-05-31 (-5d) |  | 100% → 0% | none → 0d | baseline start 2019-05-27 → none; baseline finish 2019-05-27 → none |
| 26 | **Project Closeout** | 2019-06-06 A → 2019-06-03 (-3d) | 2019-08-05 A → 2019-07-31 (-5d) |  | 100% → 0% | none → 0d | baseline start 2019-05-28 → none; baseline finish 2019-07-25 → none |
| 27 | Demobilization/Cleanup/Restoration | 2019-06-06 A → 2019-06-03 (-3d) | 2019-06-07 A → 2019-06-04 (-3d) |  | 100% → 0% | none → 0d | baseline start 2019-05-28 → none; baseline finish 2019-05-29 → none |
| 28 | Post Fieldwork Inspection / Documentation | 2019-06-10 A → 2019-06-05 (-5d) | 2019-06-21 A → 2019-06-18 (-3d) |  | 100% → 0% | none → 0d | baseline start 2019-05-30 → none; baseline finish 2019-06-12 → none |
| 29 | Final Report | 2019-06-24 A → 2019-06-19 (-5d) | 2019-08-05 A → 2019-07-31 (-5d) |  | 100% → 0% | none → 0d | baseline start 2019-06-13 → none; baseline finish 2019-07-25 → none |
| 30 | Closeout Complete | 2019-08-05 A → 2019-07-31 (-5d) | 2019-08-05 A → 2019-07-31 (-5d) |  | 100% → 0% | none → 0d | baseline start 2019-07-25 → none; baseline finish 2019-07-25 → none |
| 31 | Asbestos Abatement Encapsulation JT Processing Facilities Complete | 2019-08-05 A → 2019-07-31 (-5d) | 2019-08-05 A → 2019-07-31 (-5d) |  | 100% → 0% | none → 0d | baseline start 2019-07-25 → none; baseline finish 2019-07-25 → none |
