# JT Network Upgrades

How a schedule from MS Project changed from version to version. A marks actual dates.

## Version 1 (saved 2017-07-01, file JT Network Upgrades.mpt)

| ID | WBS | Task | Duration | Start | Finish | Predecessors | Total float | Constraint |
| --- | --- | --- | --- | --- | --- | --- | --- | --- |
| 1 | 1 | **Project Status Meetings** | 75.12d | 2019-11-18 08:00 | 2020-03-02 09:00 |  | 2.19d |  |
| 2 |  | Project Status Meetings 1 | 1h | 2019-11-18 08:00 | 2019-11-18 09:00 |  | 77.19d | start no earlier than 2019-11-18 08:00 |
| 3 |  | Project Status Meetings 2 | 1h | 2019-11-25 08:00 | 2019-11-25 09:00 |  | 72.19d | start no earlier than 2019-11-25 08:00 |
| 4 |  | Project Status Meetings 3 | 1h | 2019-12-02 08:00 | 2019-12-02 09:00 |  | 67.19d | start no earlier than 2019-12-02 08:00 |
| 5 |  | Project Status Meetings 4 | 1h | 2019-12-09 08:00 | 2019-12-09 09:00 |  | 62.19d | start no earlier than 2019-12-09 08:00 |
| 6 |  | Project Status Meetings 5 | 1h | 2019-12-16 08:00 | 2019-12-16 09:00 |  | 57.19d | start no earlier than 2019-12-16 08:00 |
| 7 |  | Project Status Meetings 6 | 1h | 2019-12-23 08:00 | 2019-12-23 09:00 |  | 52.19d | start no earlier than 2019-12-23 08:00 |
| 8 |  | Project Status Meetings 7 | 1h | 2019-12-30 08:00 | 2019-12-30 09:00 |  | 47.19d | start no earlier than 2019-12-30 08:00 |
| 9 |  | Project Status Meetings 8 | 1h | 2020-01-06 08:00 | 2020-01-06 09:00 |  | 42.19d | start no earlier than 2020-01-06 08:00 |
| 10 |  | Project Status Meetings 9 | 1h | 2020-01-13 08:00 | 2020-01-13 09:00 |  | 37.19d | start no earlier than 2020-01-13 08:00 |
| 11 |  | Project Status Meetings 10 | 1h | 2020-01-20 08:00 | 2020-01-20 09:00 |  | 32.19d | start no earlier than 2020-01-20 08:00 |
| 12 |  | Project Status Meetings 11 | 1h | 2020-01-27 08:00 | 2020-01-27 09:00 |  | 27.19d | start no earlier than 2020-01-27 08:00 |
| 13 |  | Project Status Meetings 12 | 1h | 2020-02-03 08:00 | 2020-02-03 09:00 |  | 22.19d | start no earlier than 2020-02-03 08:00 |
| 14 |  | Project Status Meetings 13 | 1h | 2020-02-10 08:00 | 2020-02-10 09:00 |  | 17.19d | start no earlier than 2020-02-10 08:00 |
| 15 |  | Project Status Meetings 14 | 1h | 2020-02-17 08:00 | 2020-02-17 09:00 |  | 12.19d | start no earlier than 2020-02-17 08:00 |
| 16 |  | Project Status Meetings 15 | 1h | 2020-02-24 08:00 | 2020-02-24 09:00 |  | 7.19d | start no earlier than 2020-02-24 08:00 |
| 17 |  | Project Status Meetings 16 | 1h | 2020-03-02 08:00 | 2020-03-02 09:00 |  | 2.19d | start no earlier than 2020-03-02 08:00 |
| 18 | 2 | **Planning Phase** | 36.5d | 2019-11-15 08:00 | 2020-01-06 12:00 |  | 0d |  |
| 19 |  | Document Current Environment | 4d | 2019-11-15 08:00 | 2019-11-20 17:00 |  | 0d |  |
| 20 |  | Conduct Needs Analysis | 2w | 2019-11-21 08:00 | 2019-12-04 17:00 | 19 | 0d |  |
| 21 |  | Identify Hardware, Software,Equipment, and Supplies Required | 4h | 2019-12-05 08:00 | 2019-12-05 12:00 | 20 | 0d |  |
| 22 |  | Create Request for Proposal and Timeline | 4d | 2019-12-05 13:00 | 2019-12-11 12:00 | 21 | 0d |  |
| 23 |  | Gather Vendor Bids | 2w | 2019-12-11 13:00 | 2019-12-25 12:00 | 22 | 0d |  |
| 24 |  | Choose Vendors | 1w | 2019-12-25 13:00 | 2020-01-01 12:00 | 23 | 0d |  |
| 25 |  | Sign Contracts | 3d | 2020-01-01 13:00 | 2020-01-06 12:00 | 24 | 0d |  |
| 26 |  | Planning Phase Complete | 0d | 2020-01-06 12:00 | 2020-01-06 12:00 | 25 | 0d |  |
| 27 | 3 | **Procurement Phase** | 20.5d | 2020-01-06 13:00 | 2020-02-03 17:00 |  | 0d |  |
| 28 |  | Order Hardware Components | 7.5d | 2020-01-06 13:00 | 2020-01-15 17:00 | 26 | 0d |  |
| 29 |  | Order Infustructure Components | 11d | 2020-01-16 08:00 | 2020-01-30 17:00 | 28 | 0d |  |
| 30 |  | Purchase Software Licenses | 1d | 2020-01-31 08:00 | 2020-01-31 17:00 | 29 | 0d |  |
| 31 |  | Identify Additional Needed Components and Order | 1d | 2020-02-03 08:00 | 2020-02-03 17:00 | 30 | 0d |  |
| 32 |  | Procurement Phase Complete | 0d | 2020-02-03 17:00 | 2020-02-03 17:00 | 31 | 0d |  |
| 33 | 4 | **Installation and Testing Phase** | 10d | 2020-02-04 08:00 | 2020-02-17 17:00 |  | 0d |  |
| 34 |  | Install Cabling | 2w | 2020-02-04 08:00 | 2020-02-17 17:00 | 32 | 0d |  |
| 35 |  | Install Hardware | 1w | 2020-02-04 08:00 | 2020-02-10 17:00 | 34SS | 0d |  |
| 36 |  | Install Software | 3d | 2020-02-11 08:00 | 2020-02-13 17:00 | 35 | 0d |  |
| 37 |  | Test Network | 2d | 2020-02-14 08:00 | 2020-02-17 17:00 | 36 | 0d |  |
| 38 |  | Installation and Testing Phase Complete | 0d | 2020-02-17 17:00 | 2020-02-17 17:00 | 37 | 0d |  |
| 39 | 5 | **Training and Communication Phase** | 6.44d | 2020-02-18 08:00 | 2020-02-26 11:30 |  | 0d |  |
| 40 |  | Communicate Information Updates | 3h | 2020-02-18 08:00 | 2020-02-18 11:00 | 38 | 0d |  |
| 41 |  | Communicate "Go Live" Date | 0.5h | 2020-02-18 11:00 | 2020-02-18 11:30 | 40 | 0d |  |
| 42 |  | Train Management | 3d | 2020-02-18 11:30 | 2020-02-21 11:30 | 41 | 0d |  |
| 43 |  | Train Users | 3d | 2020-02-21 11:30 | 2020-02-26 11:30 | 42 | 0d |  |
| 44 |  | Traning and Communication Phase Complete | 0d | 2020-02-26 11:30 | 2020-02-26 11:30 | 43 | 0d |  |
| 45 | 6 | **Evaluation and Close Out Phase** | 4.88d | 2020-02-26 11:30 | 2020-03-04 10:30 |  | 0d |  |
| 46 |  | Assess Project Success | 4d | 2020-02-26 11:30 | 2020-03-03 11:30 | 44 | 0d |  |
| 47 |  | Establish Maintenance Schedule | 5h | 2020-03-03 11:30 | 2020-03-04 08:30 | 46 | 0d |  |
| 48 |  | Review Meeting - Successes and Improvements Needed | 2h | 2020-03-04 08:30 | 2020-03-04 10:30 | 47 | 0d |  |
| 49 |  | Evaluation and Closeout Phase Complete | 0d | 2020-03-04 10:30 | 2020-03-04 10:30 | 48 | 0d |  |
| 50 |  | JT Network Upgrades Complete | 0d | 2020-03-04 10:30 | 2020-03-04 10:30 | 49 | 0d |  |

## Version 2 (saved 2019-06-26, file JT Network Upgrades Annotations.mpp)

Last finish 2020-03-04 → 2020-03-02 (-2d).

Changed:

| ID | Task | Start | Finish | Duration | Total float | Other |
| --- | --- | --- | --- | --- | --- | --- |
| 1 | **Project Status Meetings** |  |  |  | 2.19d → 0d | baseline start none → 2019-11-18 08:00; baseline finish none → 2020-03-02 09:00 |
| 2 | Project Status Meetings 1 |  |  |  | 77.19d → 75d | baseline start none → 2019-11-18 08:00; baseline finish none → 2019-11-18 09:00 |
| 3 | Project Status Meetings 2 |  |  |  | 72.19d → 70d | baseline start none → 2019-11-25 08:00; baseline finish none → 2019-11-25 09:00 |
| 4 | Project Status Meetings 3 |  |  |  | 67.19d → 65d | baseline start none → 2019-12-02 08:00; baseline finish none → 2019-12-02 09:00 |
| 5 | Project Status Meetings 4 |  |  |  | 62.19d → 60d | baseline start none → 2019-12-09 08:00; baseline finish none → 2019-12-09 09:00 |
| 6 | Project Status Meetings 5 |  |  |  | 57.19d → 55d | baseline start none → 2019-12-16 08:00; baseline finish none → 2019-12-16 09:00 |
| 7 | Project Status Meetings 6 |  |  |  | 52.19d → 50d | baseline start none → 2019-12-23 08:00; baseline finish none → 2019-12-23 09:00 |
| 8 | Project Status Meetings 7 |  |  |  | 47.19d → 45d | baseline start none → 2019-12-30 08:00; baseline finish none → 2019-12-30 09:00 |
| 9 | Project Status Meetings 8 |  |  |  | 42.19d → 40d | baseline start none → 2020-01-06 08:00; baseline finish none → 2020-01-06 09:00 |
| 10 | Project Status Meetings 9 |  |  |  | 37.19d → 35d | baseline start none → 2020-01-13 08:00; baseline finish none → 2020-01-13 09:00 |
| 11 | Project Status Meetings 10 |  |  |  | 32.19d → 30d | baseline start none → 2020-01-20 08:00; baseline finish none → 2020-01-20 09:00 |
| 12 | Project Status Meetings 11 |  |  |  | 27.19d → 25d | baseline start none → 2020-01-27 08:00; baseline finish none → 2020-01-27 09:00 |
| 13 | Project Status Meetings 12 |  |  |  | 22.19d → 20d | baseline start none → 2020-02-03 08:00; baseline finish none → 2020-02-03 09:00 |
| 14 | Project Status Meetings 13 |  |  |  | 17.19d → 15d | baseline start none → 2020-02-10 08:00; baseline finish none → 2020-02-10 09:00 |
| 15 | Project Status Meetings 14 |  |  |  | 12.19d → 10d | baseline start none → 2020-02-17 08:00; baseline finish none → 2020-02-17 09:00 |
| 16 | Project Status Meetings 15 |  |  |  | 7.19d → 5d | baseline start none → 2020-02-24 08:00; baseline finish none → 2020-02-24 09:00 |
| 17 | Project Status Meetings 16 |  |  |  | 2.19d → 0d | baseline start none → 2020-03-02 08:00; baseline finish none → 2020-03-02 09:00 |
| 18 | **Planning Phase** |  |  |  | 0d → 10.31d | baseline start none → 2019-11-15 08:00; baseline finish none → 2020-01-06 12:00 |
| 19 | Document Current Environment |  |  |  | 0d → 10.31d | baseline start none → 2019-11-15 08:00; baseline finish none → 2019-11-20 17:00 |
| 20 | Conduct Needs Analysis |  |  |  | 0d → 10.31d | baseline start none → 2019-11-21 08:00; baseline finish none → 2019-12-04 17:00 |
| 21 | Identify Hardware, Software,Equipment, and Supplies Required |  |  |  | 0d → 10.31d | baseline start none → 2019-12-05 08:00; baseline finish none → 2019-12-05 12:00 |
| 22 | Create Request for Proposal and Timeline |  |  |  | 0d → 10.31d | baseline start none → 2019-12-05 13:00; baseline finish none → 2019-12-11 12:00 |
| 23 | Gather Vendor Bids |  |  |  | 0d → 10.31d | baseline start none → 2019-12-11 13:00; baseline finish none → 2019-12-25 12:00 |
| 24 | Choose Vendors |  |  |  | 0d → 10.31d | baseline start none → 2019-12-25 13:00; baseline finish none → 2020-01-01 12:00 |
| 25 | Sign Contracts |  |  |  | 0d → 10.31d | baseline start none → 2020-01-01 13:00; baseline finish none → 2020-01-06 12:00 |
| 26 | Planning Phase Complete |  |  |  | 0d → 10.31d | baseline start none → 2020-01-06 12:00; baseline finish none → 2020-01-06 12:00 |
| 27 | **Procurement Phase** |  | 2020-02-03 17:00 → 2020-01-16 12:00 (-18d) | 20.5d → 8d | 0d → 10.31d | baseline start none → 2020-01-06 13:00; baseline finish none → 2020-01-16 12:00 |
| 28 | Order Hardware Components |  | 2020-01-15 17:00 → 2020-01-09 12:00 (-6d) | 7.5d → 3d | 0d → 10.31d | baseline start none → 2020-01-06 13:00; baseline finish none → 2020-01-09 12:00 |
| 29 | Order Infustructure Components | 2020-01-16 08:00 → 2020-01-09 13:00 (-7d) | 2020-01-30 17:00 → 2020-01-14 12:00 (-16d) | 11d → 3d | 0d → 10.31d | baseline start none → 2020-01-09 13:00; baseline finish none → 2020-01-14 12:00 |
| 30 | Purchase Software Licenses | 2020-01-31 08:00 → 2020-01-14 13:00 (-17d) | 2020-01-31 17:00 → 2020-01-15 12:00 (-16d) |  | 0d → 10.31d | baseline start none → 2020-01-14 13:00; baseline finish none → 2020-01-15 12:00 |
| 31 | Identify Additional Needed Components and Order | 2020-02-03 08:00 → 2020-01-15 13:00 (-19d) | 2020-02-03 17:00 → 2020-01-16 12:00 (-18d) |  | 0d → 10.31d | baseline start none → 2020-01-15 13:00; baseline finish none → 2020-01-16 12:00 |
| 32 | Procurement Phase Complete | 2020-02-03 17:00 → 2020-01-16 12:00 (-18d) | 2020-02-03 17:00 → 2020-01-16 12:00 (-18d) |  | 0d → 10.31d | baseline start none → 2020-01-16 12:00; baseline finish none → 2020-01-16 12:00 |
| 33 | **Installation and Testing Phase** | 2020-02-04 08:00 → 2020-01-16 13:00 (-19d) | 2020-02-17 17:00 → 2020-01-30 12:00 (-18d) |  | 0d → 10.31d | baseline start none → 2020-01-16 13:00; baseline finish none → 2020-01-30 12:00 |
| 34 | Install Cabling | 2020-02-04 08:00 → 2020-01-16 13:00 (-19d) | 2020-02-17 17:00 → 2020-01-30 12:00 (-18d) |  | 0d → 10.31d | baseline start none → 2020-01-16 13:00; baseline finish none → 2020-01-30 12:00 |
| 35 | Install Hardware | 2020-02-04 08:00 → 2020-01-16 13:00 (-19d) | 2020-02-10 17:00 → 2020-01-23 12:00 (-18d) |  | 0d → 10.31d | baseline start none → 2020-01-16 13:00; baseline finish none → 2020-01-23 12:00 |
| 36 | Install Software | 2020-02-11 08:00 → 2020-01-23 13:00 (-19d) | 2020-02-13 17:00 → 2020-01-28 12:00 (-16d) |  | 0d → 10.31d | baseline start none → 2020-01-23 13:00; baseline finish none → 2020-01-28 12:00 |
| 37 | Test Network | 2020-02-14 08:00 → 2020-01-28 13:00 (-17d) | 2020-02-17 17:00 → 2020-01-30 12:00 (-18d) |  | 0d → 10.31d | baseline start none → 2020-01-28 13:00; baseline finish none → 2020-01-30 12:00 |
| 38 | Installation and Testing Phase Complete | 2020-02-17 17:00 → 2020-01-30 12:00 (-18d) | 2020-02-17 17:00 → 2020-01-30 12:00 (-18d) |  | 0d → 10.31d | baseline start none → 2020-01-30 12:00; baseline finish none → 2020-01-30 12:00 |
| 39 | **Training and Communication Phase** | 2020-02-18 08:00 → 2020-01-30 13:00 (-19d) | 2020-02-26 11:30 → 2020-02-07 16:30 (-19d) |  | 0d → 10.31d | baseline start none → 2020-01-30 13:00; baseline finish none → 2020-02-07 16:30 |
| 40 | Communicate Information Updates | 2020-02-18 08:00 → 2020-01-30 13:00 (-19d) | 2020-02-18 11:00 → 2020-01-30 16:00 (-19d) |  | 0d → 10.31d | baseline start none → 2020-01-30 13:00; baseline finish none → 2020-01-30 16:00 |
| 41 | Communicate "Go Live" Date | 2020-02-18 11:00 → 2020-01-30 16:00 (-19d) | 2020-02-18 11:30 → 2020-01-30 16:30 (-19d) |  | 0d → 10.31d | baseline start none → 2020-01-30 16:00; baseline finish none → 2020-01-30 16:30 |
| 42 | Train Management | 2020-02-18 11:30 → 2020-01-30 16:30 (-19d) | 2020-02-21 11:30 → 2020-02-04 16:30 (-17d) |  | 0d → 10.31d | baseline start none → 2020-01-30 16:30; baseline finish none → 2020-02-04 16:30 |
| 43 | Train Users | 2020-02-21 11:30 → 2020-02-04 16:30 (-17d) | 2020-02-26 11:30 → 2020-02-07 16:30 (-19d) |  | 0d → 10.31d | baseline start none → 2020-02-04 16:30; baseline finish none → 2020-02-07 16:30 |
| 44 | Traning and Communication Phase Complete | 2020-02-26 11:30 → 2020-02-07 16:30 (-19d) | 2020-02-26 11:30 → 2020-02-07 16:30 (-19d) |  | 0d → 10.31d | baseline start none → 2020-02-07 16:30; baseline finish none → 2020-02-07 16:30 |
| 45 | **Evaluation and Close Out Phase** | 2020-02-26 11:30 → 2020-02-07 16:30 (-19d) | 2020-03-04 10:30 → 2020-02-14 15:30 (-19d) |  | 0d → 10.31d | baseline start none → 2020-02-07 16:30; baseline finish none → 2020-02-14 15:30 |
| 46 | Assess Project Success | 2020-02-26 11:30 → 2020-02-07 16:30 (-19d) | 2020-03-03 11:30 → 2020-02-13 16:30 (-19d) |  | 0d → 10.31d | baseline start none → 2020-02-07 16:30; baseline finish none → 2020-02-13 16:30 |
| 47 | Establish Maintenance Schedule | 2020-03-03 11:30 → 2020-02-13 16:30 (-19d) | 2020-03-04 08:30 → 2020-02-14 13:30 (-19d) |  | 0d → 10.31d | baseline start none → 2020-02-13 16:30; baseline finish none → 2020-02-14 13:30 |
| 48 | Review Meeting - Successes and Improvements Needed | 2020-03-04 08:30 → 2020-02-14 13:30 (-19d) | 2020-03-04 10:30 → 2020-02-14 15:30 (-19d) |  | 0d → 10.31d | baseline start none → 2020-02-14 13:30; baseline finish none → 2020-02-14 15:30 |
| 49 | Evaluation and Closeout Phase Complete | 2020-03-04 10:30 → 2020-02-14 15:30 (-19d) | 2020-03-04 10:30 → 2020-02-14 15:30 (-19d) |  | 0d → 10.31d | baseline start none → 2020-02-14 15:30; baseline finish none → 2020-02-14 15:30 |
| 50 | JT Network Upgrades Complete | 2020-03-04 10:30 → 2020-02-14 15:30 (-19d) | 2020-03-04 10:30 → 2020-02-14 15:30 (-19d) |  | 0d → 10.31d | baseline start none → 2020-02-14 15:30; baseline finish none → 2020-02-14 15:30 |

## Version 3 (saved 2019-06-26, file JT Network Upgrades Final Reports.mpp)

Last finish 2020-03-02 → 2020-03-04 (+2d). Complete tasks 0 → 28.

Changed:

| ID | Task | Start | Finish | Duration | Complete | Total float |
| --- | --- | --- | --- | --- | --- | --- |
| 18 | **Planning Phase** | 2019-11-15 08:00 A | 2020-01-06 12:00 A |  | 0% → 100% | 10.31d → none |
| 19 | Document Current Environment | 2019-11-15 08:00 A | 2019-11-20 17:00 A |  | 0% → 100% | 10.31d → none |
| 20 | Conduct Needs Analysis | 2019-11-21 08:00 A | 2019-12-04 17:00 A |  | 0% → 100% | 10.31d → none |
| 21 | Identify Hardware, Software,Equipment, and Supplies Required | 2019-12-05 08:00 A | 2019-12-05 12:00 A |  | 0% → 100% | 10.31d → none |
| 22 | Create Request for Proposal and Timeline | 2019-12-05 13:00 A | 2019-12-11 12:00 A |  | 0% → 100% | 10.31d → none |
| 23 | Gather Vendor Bids | 2019-12-11 13:00 A | 2019-12-25 12:00 A |  | 0% → 100% | 10.31d → none |
| 24 | Choose Vendors | 2019-12-25 13:00 A | 2020-01-01 12:00 A |  | 0% → 100% | 10.31d → none |
| 25 | Sign Contracts | 2020-01-01 13:00 A | 2020-01-06 12:00 A |  | 0% → 100% | 10.31d → none |
| 26 | Planning Phase Complete | 2020-01-06 12:00 A | 2020-01-06 12:00 A |  | 0% → 100% | 10.31d → none |
| 27 | **Procurement Phase** | 2020-01-06 13:00 A | 2020-01-16 12:00 → 2020-02-03 17:00 A (+18d) | 8d → 20.5d | 0% → 100% | 10.31d → none |
| 28 | Order Hardware Components | 2020-01-06 13:00 A | 2020-01-09 12:00 → 2020-01-15 17:00 A (+6d) | 3d → 7.5d | 0% → 100% | 10.31d → none |
| 29 | Order Infustructure Components | 2020-01-09 13:00 → 2020-01-16 08:00 A (+7d) | 2020-01-14 12:00 → 2020-01-30 17:00 A (+16d) | 3d → 11d | 0% → 100% | 10.31d → none |
| 30 | Purchase Software Licenses | 2020-01-14 13:00 → 2020-01-31 08:00 A (+17d) | 2020-01-15 12:00 → 2020-01-31 17:00 A (+16d) |  | 0% → 100% | 10.31d → none |
| 31 | Identify Additional Needed Components and Order | 2020-01-15 13:00 → 2020-02-03 08:00 A (+19d) | 2020-01-16 12:00 → 2020-02-03 17:00 A (+18d) |  | 0% → 100% | 10.31d → none |
| 32 | Procurement Phase Complete | 2020-01-16 12:00 → 2020-02-03 17:00 A (+18d) | 2020-01-16 12:00 → 2020-02-03 17:00 A (+18d) |  | 0% → 100% | 10.31d → none |
| 33 | **Installation and Testing Phase** | 2020-01-16 13:00 → 2020-02-04 08:00 A (+19d) | 2020-01-30 12:00 → 2020-02-17 17:00 A (+18d) |  | 0% → 100% | 10.31d → none |
| 34 | Install Cabling | 2020-01-16 13:00 → 2020-02-04 08:00 A (+19d) | 2020-01-30 12:00 → 2020-02-17 17:00 A (+18d) |  | 0% → 100% | 10.31d → none |
| 35 | Install Hardware | 2020-01-16 13:00 → 2020-02-04 08:00 A (+19d) | 2020-01-23 12:00 → 2020-02-10 17:00 A (+18d) |  | 0% → 100% | 10.31d → none |
| 36 | Install Software | 2020-01-23 13:00 → 2020-02-11 08:00 A (+19d) | 2020-01-28 12:00 → 2020-02-13 17:00 A (+16d) |  | 0% → 100% | 10.31d → none |
| 37 | Test Network | 2020-01-28 13:00 → 2020-02-14 08:00 A (+17d) | 2020-01-30 12:00 → 2020-02-17 17:00 A (+18d) |  | 0% → 100% | 10.31d → none |
| 38 | Installation and Testing Phase Complete | 2020-01-30 12:00 → 2020-02-17 17:00 A (+18d) | 2020-01-30 12:00 → 2020-02-17 17:00 A (+18d) |  | 0% → 100% | 10.31d → none |
| 39 | **Training and Communication Phase** | 2020-01-30 13:00 → 2020-02-18 08:00 A (+19d) | 2020-02-07 16:30 → 2020-02-26 11:30 A (+19d) |  | 0% → 100% | 10.31d → none |
| 40 | Communicate Information Updates | 2020-01-30 13:00 → 2020-02-18 08:00 A (+19d) | 2020-01-30 16:00 → 2020-02-18 11:00 A (+19d) |  | 0% → 100% | 10.31d → none |
| 41 | Communicate "Go Live" Date | 2020-01-30 16:00 → 2020-02-18 11:00 A (+19d) | 2020-01-30 16:30 → 2020-02-18 11:30 A (+19d) |  | 0% → 100% | 10.31d → none |
| 42 | Train Management | 2020-01-30 16:30 → 2020-02-18 11:30 A (+19d) | 2020-02-04 16:30 → 2020-02-21 11:30 A (+17d) |  | 0% → 100% | 10.31d → none |
| 43 | Train Users | 2020-02-04 16:30 → 2020-02-21 11:30 A (+17d) | 2020-02-07 16:30 → 2020-02-26 11:30 A (+19d) |  | 0% → 100% | 10.31d → none |
| 44 | Traning and Communication Phase Complete | 2020-02-07 16:30 → 2020-02-26 11:30 A (+19d) | 2020-02-07 16:30 → 2020-02-26 11:30 A (+19d) |  | 0% → 100% | 10.31d → none |
| 45 | **Evaluation and Close Out Phase** | 2020-02-07 16:30 → 2020-02-26 11:30 A (+19d) | 2020-02-14 15:30 → 2020-03-04 10:30 A (+19d) |  | 0% → 100% | 10.31d → none |
| 46 | Assess Project Success | 2020-02-07 16:30 → 2020-02-26 11:30 A (+19d) | 2020-02-13 16:30 → 2020-03-03 11:30 A (+19d) |  | 0% → 100% | 10.31d → none |
| 47 | Establish Maintenance Schedule | 2020-02-13 16:30 → 2020-03-03 11:30 A (+19d) | 2020-02-14 13:30 → 2020-03-04 08:30 A (+19d) |  | 0% → 100% | 10.31d → none |
| 48 | Review Meeting - Successes and Improvements Needed | 2020-02-14 13:30 → 2020-03-04 08:30 A (+19d) | 2020-02-14 15:30 → 2020-03-04 10:30 A (+19d) |  | 0% → 100% | 10.31d → none |
| 49 | Evaluation and Closeout Phase Complete | 2020-02-14 15:30 → 2020-03-04 10:30 A (+19d) | 2020-02-14 15:30 → 2020-03-04 10:30 A (+19d) |  | 0% → 100% | 10.31d → none |
| 50 | JT Network Upgrades Complete | 2020-02-14 15:30 → 2020-03-04 10:30 A (+19d) | 2020-02-14 15:30 → 2020-03-04 10:30 A (+19d) |  | 0% → 100% | 10.31d → none |

## Version 4 (saved 2019-06-26, file JT Network Upgrades Working with Data.mpp)

Last finish 2020-03-04 → 2020-03-02 (-2d). Complete tasks 28 → 0.

Changed:

| ID | Task | Start | Finish | Duration | Complete | Total float |
| --- | --- | --- | --- | --- | --- | --- |
| 18 | **Planning Phase** | 2019-11-15 08:00 A → 2019-11-15 08:00 | 2020-01-06 12:00 A → 2020-01-06 12:00 |  | 100% → 0% | none → 10.31d |
| 19 | Document Current Environment | 2019-11-15 08:00 A → 2019-11-15 08:00 | 2019-11-20 17:00 A → 2019-11-20 17:00 |  | 100% → 0% | none → 10.31d |
| 20 | Conduct Needs Analysis | 2019-11-21 08:00 A → 2019-11-21 08:00 | 2019-12-04 17:00 A → 2019-12-04 17:00 |  | 100% → 0% | none → 10.31d |
| 21 | Identify Hardware, Software,Equipment, and Supplies Required | 2019-12-05 08:00 A → 2019-12-05 08:00 | 2019-12-05 12:00 A → 2019-12-05 12:00 |  | 100% → 0% | none → 10.31d |
| 22 | Create Request for Proposal and Timeline | 2019-12-05 13:00 A → 2019-12-05 13:00 | 2019-12-11 12:00 A → 2019-12-11 12:00 |  | 100% → 0% | none → 10.31d |
| 23 | Gather Vendor Bids | 2019-12-11 13:00 A → 2019-12-11 13:00 | 2019-12-25 12:00 A → 2019-12-25 12:00 |  | 100% → 0% | none → 10.31d |
| 24 | Choose Vendors | 2019-12-25 13:00 A → 2019-12-25 13:00 | 2020-01-01 12:00 A → 2020-01-01 12:00 |  | 100% → 0% | none → 10.31d |
| 25 | Sign Contracts | 2020-01-01 13:00 A → 2020-01-01 13:00 | 2020-01-06 12:00 A → 2020-01-06 12:00 |  | 100% → 0% | none → 10.31d |
| 26 | Planning Phase Complete | 2020-01-06 12:00 A → 2020-01-06 12:00 | 2020-01-06 12:00 A → 2020-01-06 12:00 |  | 100% → 0% | none → 10.31d |
| 27 | **Procurement Phase** | 2020-01-06 13:00 A → 2020-01-06 13:00 | 2020-02-03 17:00 A → 2020-01-16 12:00 (-18d) | 20.5d → 8d | 100% → 0% | none → 10.31d |
| 28 | Order Hardware Components | 2020-01-06 13:00 A → 2020-01-06 13:00 | 2020-01-15 17:00 A → 2020-01-09 12:00 (-6d) | 7.5d → 3d | 100% → 0% | none → 10.31d |
| 29 | Order Infustructure Components | 2020-01-16 08:00 A → 2020-01-09 13:00 (-7d) | 2020-01-30 17:00 A → 2020-01-14 12:00 (-16d) | 11d → 3d | 100% → 0% | none → 10.31d |
| 30 | Purchase Software Licenses | 2020-01-31 08:00 A → 2020-01-14 13:00 (-17d) | 2020-01-31 17:00 A → 2020-01-15 12:00 (-16d) |  | 100% → 0% | none → 10.31d |
| 31 | Identify Additional Needed Components and Order | 2020-02-03 08:00 A → 2020-01-15 13:00 (-19d) | 2020-02-03 17:00 A → 2020-01-16 12:00 (-18d) |  | 100% → 0% | none → 10.31d |
| 32 | Procurement Phase Complete | 2020-02-03 17:00 A → 2020-01-16 12:00 (-18d) | 2020-02-03 17:00 A → 2020-01-16 12:00 (-18d) |  | 100% → 0% | none → 10.31d |
| 33 | **Installation and Testing Phase** | 2020-02-04 08:00 A → 2020-01-16 13:00 (-19d) | 2020-02-17 17:00 A → 2020-01-30 12:00 (-18d) |  | 100% → 0% | none → 10.31d |
| 34 | Install Cabling | 2020-02-04 08:00 A → 2020-01-16 13:00 (-19d) | 2020-02-17 17:00 A → 2020-01-30 12:00 (-18d) |  | 100% → 0% | none → 10.31d |
| 35 | Install Hardware | 2020-02-04 08:00 A → 2020-01-16 13:00 (-19d) | 2020-02-10 17:00 A → 2020-01-23 12:00 (-18d) |  | 100% → 0% | none → 10.31d |
| 36 | Install Software | 2020-02-11 08:00 A → 2020-01-23 13:00 (-19d) | 2020-02-13 17:00 A → 2020-01-28 12:00 (-16d) |  | 100% → 0% | none → 10.31d |
| 37 | Test Network | 2020-02-14 08:00 A → 2020-01-28 13:00 (-17d) | 2020-02-17 17:00 A → 2020-01-30 12:00 (-18d) |  | 100% → 0% | none → 10.31d |
| 38 | Installation and Testing Phase Complete | 2020-02-17 17:00 A → 2020-01-30 12:00 (-18d) | 2020-02-17 17:00 A → 2020-01-30 12:00 (-18d) |  | 100% → 0% | none → 10.31d |
| 39 | **Training and Communication Phase** | 2020-02-18 08:00 A → 2020-01-30 13:00 (-19d) | 2020-02-26 11:30 A → 2020-02-07 16:30 (-19d) |  | 100% → 0% | none → 10.31d |
| 40 | Communicate Information Updates | 2020-02-18 08:00 A → 2020-01-30 13:00 (-19d) | 2020-02-18 11:00 A → 2020-01-30 16:00 (-19d) |  | 100% → 0% | none → 10.31d |
| 41 | Communicate "Go Live" Date | 2020-02-18 11:00 A → 2020-01-30 16:00 (-19d) | 2020-02-18 11:30 A → 2020-01-30 16:30 (-19d) |  | 100% → 0% | none → 10.31d |
| 42 | Train Management | 2020-02-18 11:30 A → 2020-01-30 16:30 (-19d) | 2020-02-21 11:30 A → 2020-02-04 16:30 (-17d) |  | 100% → 0% | none → 10.31d |
| 43 | Train Users | 2020-02-21 11:30 A → 2020-02-04 16:30 (-17d) | 2020-02-26 11:30 A → 2020-02-07 16:30 (-19d) |  | 100% → 0% | none → 10.31d |
| 44 | Traning and Communication Phase Complete | 2020-02-26 11:30 A → 2020-02-07 16:30 (-19d) | 2020-02-26 11:30 A → 2020-02-07 16:30 (-19d) |  | 100% → 0% | none → 10.31d |
| 45 | **Evaluation and Close Out Phase** | 2020-02-26 11:30 A → 2020-02-07 16:30 (-19d) | 2020-03-04 10:30 A → 2020-02-14 15:30 (-19d) |  | 100% → 0% | none → 10.31d |
| 46 | Assess Project Success | 2020-02-26 11:30 A → 2020-02-07 16:30 (-19d) | 2020-03-03 11:30 A → 2020-02-13 16:30 (-19d) |  | 100% → 0% | none → 10.31d |
| 47 | Establish Maintenance Schedule | 2020-03-03 11:30 A → 2020-02-13 16:30 (-19d) | 2020-03-04 08:30 A → 2020-02-14 13:30 (-19d) |  | 100% → 0% | none → 10.31d |
| 48 | Review Meeting - Successes and Improvements Needed | 2020-03-04 08:30 A → 2020-02-14 13:30 (-19d) | 2020-03-04 10:30 A → 2020-02-14 15:30 (-19d) |  | 100% → 0% | none → 10.31d |
| 49 | Evaluation and Closeout Phase Complete | 2020-03-04 10:30 A → 2020-02-14 15:30 (-19d) | 2020-03-04 10:30 A → 2020-02-14 15:30 (-19d) |  | 100% → 0% | none → 10.31d |
| 50 | JT Network Upgrades Complete | 2020-03-04 10:30 A → 2020-02-14 15:30 (-19d) | 2020-03-04 10:30 A → 2020-02-14 15:30 (-19d) |  | 100% → 0% | none → 10.31d |
